# Calendário do Projeto

Schedule from MS Project, 2023-07-31 to 2025-09-16, status date 2023-06-12, 8.8 hours a day, costs in R$.

## Calendars

- Curso Unichristus: Mon-Fri 07:00-12:00, 13:00-16:48; Sat-Sun off. Exceptions (off unless hours are given): 2023-01-01 to 2032-01-01 (Confraternização Mundial, recurring), 2023-03-19 to 2032-03-19 (São José, recurring), 2023-03-25 to 2032-03-25 (Carta Magna, recurring), 2023-04-21 to 2032-04-21 (Tiradentes, recurring), 2023-05-01 to 2032-05-01 (Dia do Trabalho, recurring), 2023-09-07 to 2032-09-07 (Independência do Brasil, recurring), 2023-10-12 to 2032-10-12 (Nossa Senhora Aparecida, recurring), 2023-11-02 to 2032-11-02 (Finado, recurring), 2023-11-15 to 2032-11-15 (Proclamação da República, recurring), 2023-12-25 to 2032-12-25 (Natal, recurring), 2023-12-26 to 2023-12-29 (Recesso fim de ano 2023), 2024-02-12 to 2024-02-14 (Carnaval 2024), 2024-03-29 (Paixão de Cristo 2024), 2024-05-30 to 2024-05-31 (Corpus Christi 2024), 2025-03-03 to 2025-03-05 (Carnaval 2025), 2025-04-18 (Paixão de Cristo 2025), 2025-06-19 to 2025-06-20 (Corpus Christi 2025).

## Resources

| Resource |
| --- |
| carpinteiro |
| ferreiro |
| servente estrutura |
| aux. Carpinteiro |
| aux. ferreiro |
| enc. carpinteiro |
| enc. ferreiro |
| pedreiro alv. |
| servente alv. |
| gesseiro |
| aux. gesseiro |
| aplicador de manta |
| aux. aplicador |
| pedreiro acab. |
| servente acab. |
| pedreiro fac. |
| servente fac. |
| montador esquadrias |
| aux.Marceneiro |
| marceneiro |
| aux. eletricista |
| eletricista |
| pintor |
| aux. Pintor |
| aux. bombeiro |
| bombeiro |
| Diarista |
| mecânico |
| servente geral |
| pedreiro |
| servente |
| aux.pintor |

## Schedule

| ID | WBS | Task | Duration | Start | Finish | Predecessors | Total slack | Free slack | Resources | Work | Cost | Casa | Pav | Equipe | Empresa | Pacote | Cor | LB |
| --- | --- | --- | --- | --- | --- | --- | --- | --- | --- | --- | --- | --- | --- | --- | --- | --- | --- | --- |
| 1 | 1 | **Curso PO CREA-CE 2023** | 525d? | 2023-07-31 | 2025-09-16 |  | -1d | 0d |  | 133663h | 9,173,149.99 |  |  |  |  |  |  |  |
| 2 | 1.1 | Custo Indireto | 1d? | 2023-07-31 | 2023-07-31 |  | 1206d |  |  |  | 2,083,229.72 |  |  |  |  |  |  |  |
| 3 | 1.2 | Áreas Comuns | 1d? | 2023-07-31 | 2023-07-31 |  | 1206d |  |  |  | 520,807.43 |  |  |  |  |  |  |  |
| 4 | 1.3 | **Obra Civil** | 525d | 2023-07-31 | 2025-09-16 |  | -1d | 0d |  | 121273h | 5,416,318.92 |  |  |  |  |  |  |  |
| 5 | 1.3.1 | **1. Casa 1** | 495d | 2023-07-31 | 2025-08-06 |  | -1d | 0d |  | 7568h | 338,552.33 |  |  |  |  |  |  |  |
| 6 | 1.3.1.1 | **0. Térreo** | 494d | 2023-07-31 | 2025-08-05 |  | -1d | 0d |  | 3801.6h | 165,509.25 |  |  |  |  |  |  |  |
| 7 | 1.3.1.1.1 | 0. Locação | 2d | 2023-07-31 | 2023-08-01 |  | -1d | 0d | carpinteiro; aux. Carpinteiro | 35.2h | 456.99 | 1. Casa 1 | 0. Térreo | 0. Locação 1 | Própria |  |  |  |
| 8 | 1.3.1.1.2 | 1. Fundação | 9d | 2023-08-24 | 2023-09-05 | 383 | -1d | 0d | servente estrutura [300%]; aux. Carpinteiro; aux. ferreiro; ferreiro; carpinteiro [200%] | 633.6h | 19,882.86 | 1. Casa 1 | 0. Térreo | 1. Fundação 1 | Própria |  |  |  |
| 9 | 1.3.1.1.3 | 2. Estrutura | 7d | 2023-10-04 | 2023-10-13 | 8FS+28ed | -1d | 0d | servente estrutura [300%]; aux. Carpinteiro [200%]; aux. ferreiro [200%]; ferreiro [500%]; carpinteiro [200%] | 862.4h | 46,439.03 | 1. Casa 1 | 0. Térreo | 2. Estrutura 1 | Própria |  |  |  |
| 10 | 1.3.1.1.4 | 3. Alvenarias | 5d | 2023-11-13 | 2023-11-20 | 9FS+28ed | -2d | 0d | pedreiro [400%]; servente [400%] | 352h | 8,388.41 | 1. Casa 1 | 0. Térreo | 3. Alvenarias 1 | Própria |  |  |  |
| 11 | 1.3.1.1.5 | 5. Ref. Inter. Arg (Parede) | 3d | 2024-05-13 | 2024-05-15 | 427 | -2d | 0d | pedreiro [600%]; servente [600%] | 316.8h | 5,776 | 1. Casa 1 | 0. Térreo | 5. Ref. Inter. Arg (Parede) 1 | Própria |  |  |  |
| 12 | 1.3.1.1.6 | 6. Revest. Gesso (Parede + Teto) | 3d | 2024-05-28 | 2024-06-04 | 32SF | 323d |  | gesseiro [400%]; aux. gesseiro [200%] | 158.4h | 2,119.41 | 1. Casa 1 | 0. Térreo | 6. Revest. Gesso (Parede + Teto) 1 | Própria |  |  |  |
| 13 | 1.3.1.1.7 | 7. Impermeabilização | 2d | 2024-06-25 | 2024-06-27 | 33SF | 306d |  | aplicador de manta | 17.6h | 3,288.15 | 1. Casa 1 | 0. Térreo | 7. Impermeabilização 1 | Própria |  |  |  |
| 14 | 1.3.1.1.8 | 8. Contrapiso | 2d | 2024-07-03 | 2024-07-05 | 81SF | 300d | 0d | pedreiro [200%]; servente | 52.8h | 3,735.07 | 1. Casa 1 | 0. Térreo | 8. Contrapiso 1 | Própria |  |  |  |
| 15 | 1.3.1.1.9 | 9.1. Chapisco | 0.5d | 2024-09-25 | 2024-09-25 | 739 | 84.5d | 0d | pedreiro [600%]; servente [400%] | 44h | 5,131.51 | 1. Casa 1 | 0. Térreo | 9. Fachada 1 | Própria |  |  |  |
| 16 | 1.3.1.1.10 | 9.2. Emboço | 1.5d | 2024-10-18 | 2024-10-21 | 36 | 84.5d | 0d | pedreiro [600%]; servente [400%] | 132h | 7,697.26 | 1. Casa 1 | 0. Térreo | 9. Fachada 1 | Própria |  |  |  |
| 17 | 1.3.1.1.11 | 9.3. Pint. 1 Demão | 1d | 2024-12-24 | 2024-12-26 | 37 | 84.5d | 0d | pintor [400%]; aux.pintor [200%] | 52.8h | 1,135.92 | 1. Casa 1 | 0. Térreo | 9. Fachada 1 | Própria |  |  |  |
| 18 | 1.3.1.1.12 | 9.4. Pint. 2 Demão | 2d | 2025-02-10 | 2025-02-12 | 38 | 84.5d | 0d | pintor [400%]; aux.pintor [200%] | 105.6h | 757.28 | 1. Casa 1 | 0. Térreo | 9. Fachada 1 | Própria |  |  |  |
| 19 | 1.3.1.1.13 | 10. Cer. Piso | 4d | 2024-09-09 | 2024-09-12 | 363FS+28ed | 0d |  | pedreiro [400%]; servente [200%] | 211.2h | 25,485.98 | 1. Casa 1 | 0. Térreo | 10. Cer. Piso 1 | Própria | 10 | 10 | 10 |
| 20 | 1.3.1.1.14 | 11. Cer. Parede | 3d | 2024-12-09 | 2024-12-11 | 368 | 0d |  | pedreiro [400%]; servente [200%] | 158.4h | 4,238.82 | 1. Casa 1 | 0. Térreo | 11. Cer. Parede 1 | Própria | 11 | 11 | 11 |
| 21 | 1.3.1.1.15 | 12. Forro (WC's e cozinha) | 1d | 2025-01-14 | 2025-01-15 | 41SF | 165d |  | gesseiro; aux. gesseiro | 17.6h | 635.82 | 1. Casa 1 | 0. Térreo | 12. Forro (WC's e cozinha) 1 | Própria | 12 | 12 | 12 |
| 22 | 1.3.1.1.16 | 13. Esq. Alumínio | 2d | 2025-01-16 | 2025-01-17 | 41 | 0d |  | montador esquadrias | 17.6h | 11,307.22 | 1. Casa 1 | 0. Térreo | 13. Esq. Alumínio 1 | Própria | 13 | 13 | 13 |
| 23 | 1.3.1.1.17 | 14. Portas | 2d | 2025-01-20 | 2025-01-21 | 22 | 0d |  | marceneiro [200%] | 35.2h | 2,827.85 | 1. Casa 1 | 0. Térreo | 14. Portas 1 | Própria | 14 | 14 | 14 |
| 24 | 1.3.1.1.18 | 15. Pintura (1ª Demão) | 4d | 2025-03-10 | 2025-03-13 | 372 | 0d |  | pintor [600%]; aux.pintor [300%] | 316.8h | 3,764.82 | 1. Casa 1 | 0. Térreo | 15. Pintura (1ª Demão) 1 | Própria | 15 | 15 | 15 |
| 25 | 1.3.1.1.19 | 16. Bancadas | 1d | 2025-05-23 | 2025-05-26 | 45SF | 80d |  | pedreiro [200%]; servente | 26.4h | 10,458.12 | 1. Casa 1 | 0. Térreo | 16. Bancadas 1 | Própria | 16 | 16 | 16 |
| 26 | 1.3.1.1.20 | 17. Pintura (2ª Demão) | 3d | 2025-06-13 | 2025-06-17 | 373 | 0d |  | pintor [600%]; aux.pintor [300%] | 237.6h | 1,563.98 | 1. Casa 1 | 0. Térreo | 17. Pintura (2ª Demão) 1 | Própria | 17 | 17 | 17 |
| 27 | 1.3.1.1.21 | 18. Limp. Interna | 1d | 2025-08-04 | 2025-08-05 | 47SF | 31d |  | Diarista [200%] | 17.6h | 418.75 | 1. Casa 1 | 0. Térreo | 18. Limp. Interna 1 | Própria | 18 | 18 | 18 |

| ID | WBS | Task | Duration | Start | Finish | Predecessors | Total slack | Free slack | Resources | Work | Cost | Casa | Pav | Equipe | Empresa | Pacote | Cor | LB |
| --- | --- | --- | --- | --- | --- | --- | --- | --- | --- | --- | --- | --- | --- | --- | --- | --- | --- | --- |
| 28 | 1.3.1.2 | **1. Pav. Superior** | 442d | 2023-10-16 | 2025-08-06 |  | 22d |  |  | 3229.6h | 114,879.9 |  |  |  |  |  |  |  |
| 29 | 1.3.1.2.1 | 2. Estrutura | 7d | 2023-10-16 | 2023-10-24 | 9 | 367d | 0d | servente estrutura [300%]; aux. Carpinteiro [200%]; aux. ferreiro [200%]; ferreiro [500%]; carpinteiro [200%] | 862.4h | 30,006.55 | 1. Casa 1 | 1. Pav. Superior | 2. Estrutura 1 | Própria |  |  |  |
| 30 | 1.3.1.2.2 | 3. Alvenarias | 5d | 2023-11-21 | 2023-11-27 | 10 | -2d | 0d | servente [400%]; pedreiro [400%] | 352h | 10,101.74 | 1. Casa 1 | 1. Pav. Superior | 3. Alvenarias 1 | Própria |  |  |  |
| 31 | 1.3.1.2.3 | 5. Ref. Inter. Arg (Parede) | 4d | 2024-05-16 | 2024-05-21 | 11 | -2d | 0d | pedreiro [600%]; servente [600%] | 422.4h | 5,398.69 | 1. Casa 1 | 1. Pav. Superior | 5. Ref. Inter. Arg (Parede) 1 | Própria |  |  |  |
| 32 | 1.3.1.2.4 | 6. Revest. Gesso (Parede + Teto) | 4d | 2024-06-04 | 2024-06-10 | 59SF | 319d | 0d | aux. gesseiro [200%]; gesseiro [400%] | 211.2h | 2,119.41 | 1. Casa 1 | 1. Pav. Superior | 6. Revest. Gesso (Parede + Teto) 1 | Própria |  |  |  |
| 33 | 1.3.1.2.5 | 7. Impermeabilização | 1d | 2024-06-27 | 2024-06-28 | 50SF | 305d | 0d | aplicador de manta | 8.8h | 2,046.85 | 1. Casa 1 | 1. Pav. Superior | 7. Impermeabilização 1 | Própria |  |  |  |
| 34 | 1.3.1.2.6 | 8. Contrapiso | 2d | 2024-07-01 | 2024-07-03 | 14SF | 302d |  | pedreiro [200%]; servente | 52.8h | 2,476.11 | 1. Casa 1 | 1. Pav. Superior | 8. Contrapiso 1 | Própria |  |  |  |
| 35 | 1.3.1.2.7 | 9.1. Chapisco | 0.5d | 2024-09-25 | 2024-09-25 | 15 | 84.5d | 0d | pedreiro [600%]; servente [400%] | 44h | 5,131.51 | 1. Casa 1 | 1. Pav. Superior | 9. Fachada 1 | Própria |  |  |  |
| 36 | 1.3.1.2.8 | 9.2. Emboço | 1.5d | 2024-10-17 | 2024-10-18 | 740 | 84.5d | 0d | pedreiro [600%]; servente [400%] | 132h | 7,697.26 | 1. Casa 1 | 1. Pav. Superior | 9. Fachada 1 | Própria |  |  |  |
| 37 | 1.3.1.2.9 | 9.3. Pint. 1 Demão | 1d | 2024-12-23 | 2024-12-24 | 741 | 84.5d | 0d | pintor [400%]; aux.pintor [200%] | 52.8h | 1,135.92 | 1. Casa 1 | 1. Pav. Superior | 9. Fachada 1 | Própria |  |  |  |
| 38 | 1.3.1.2.10 | 9.4. Pint. 2 Demão | 2d | 2025-02-06 | 2025-02-10 | 742 | 84.5d | 0d | pintor [400%]; aux.pintor [200%] | 105.6h | 757.28 | 1. Casa 1 | 1. Pav. Superior | 9. Fachada 1 | Própria |  |  |  |
| 39 | 1.3.1.2.11 | 10. Cer. Piso | 4d | 2024-09-13 | 2024-09-18 | 19 | 0d |  | servente [200%]; pedreiro [400%] | 211.2h | 19,807.17 | 1. Casa 1 | 1. Pav. Superior | 10. Cer. Piso 1 | Própria | 10 | 10 | 10 |
| 40 | 1.3.1.2.12 | 11. Cer. Parede | 2d | 2024-12-12 | 2024-12-13 | 20 | 0d |  | pedreiro [400%]; servente [200%] | 105.6h | 4,238.82 | 1. Casa 1 | 1. Pav. Superior | 11. Cer. Parede 1 | Própria | 11 | 11 | 11 |
| 41 | 1.3.1.2.13 | 12. Forro (WC's e cozinha) | 1d | 2025-01-15 | 2025-01-16 | 68SF | 0d |  | aux. gesseiro; gesseiro | 17.6h | 895 | 1. Casa 1 | 1. Pav. Superior | 12. Forro (WC's e cozinha) 1 | Própria | 12 | 12 | 12 |
| 42 | 1.3.1.2.14 | 13. Esq. Alumínio | 2d | 2025-01-20 | 2025-01-21 | 22 | 100d | 0d | montador esquadrias | 17.6h | 8,489.61 | 1. Casa 1 | 1. Pav. Superior | 13. Esq. Alumínio 1 | Própria | 13 | 13 | 13 |
| 43 | 1.3.1.2.15 | 14. Portas | 2d | 2025-01-22 | 2025-01-23 | 23 | 0d |  | marceneiro [200%] | 35.2h | 1,858.35 | 1. Casa 1 | 1. Pav. Superior | 14. Portas 1 | Própria | 14 | 14 | 14 |
| 44 | 1.3.1.2.16 | 15. Pintura (1ª Demão) | 4d | 2025-03-14 | 2025-03-20 | 24 | 0d |  | pintor [600%]; aux.pintor [300%] | 316.8h | 3,764.82 | 1. Casa 1 | 1. Pav. Superior | 15. Pintura (1ª Demão) 1 | Própria | 15 | 15 | 15 |
| 45 | 1.3.1.2.17 | 16. Bancadas | 1d | 2025-05-26 | 2025-05-27 | 72SF | 79d | 0d | servente; pedreiro [200%] | 26.4h | 6,972.08 | 1. Casa 1 | 1. Pav. Superior | 16. Bancadas 1 | Própria | 16 | 16 | 16 |
| 46 | 1.3.1.2.18 | 17. Pintura (2ª Demão) | 3d | 2025-06-18 | 2025-06-24 | 26 | 0d |  | aux.pintor [300%]; pintor [600%] | 237.6h | 1,563.98 | 1. Casa 1 | 1. Pav. Superior | 17. Pintura (2ª Demão) 1 | Própria | 17 | 17 | 17 |
| 47 | 1.3.1.2.19 | 18. Limp. Interna | 1d | 2025-08-05 | 2025-08-06 | 74SF | 30d | 0d | Diarista [200%] | 17.6h | 418.75 | 1. Casa 1 | 1. Pav. Superior | 18. Limp. Interna 1 | Própria | 18 | 18 | 18 |
| 48 | 1.3.1.3 | **2. Coberta** | 139d | 2023-11-28 | 2024-07-01 |  | -2d | 0d |  | 536.8h | 58,163.18 |  |  |  |  |  |  |  |
| 49 | 1.3.1.3.1 | 1. Alvenarias | 3d | 2023-11-28 | 2023-11-30 | 30 | -2d | 0d | pedreiro [400%]; servente [400%] | 211.2h | 9,834.12 | 1. Casa 1 | 2. Coberta | 3. Alvenarias 1 | Própria |  |  |  |
| 50 | 1.3.1.3.2 | 2. Impermeabilização | 1d | 2024-06-28 | 2024-07-01 | 60SF | 304d | 0d | aplicador de manta | 8.8h | 24,164.53 | 1. Casa 1 | 2. Coberta | 7. Impermeabilização 1 | Própria |  |  |  |
| 51 | 1.3.1.3.3 | 3. Coberta | 6d | 2024-02-21 | 2024-02-29 | 98SF | 385d |  | carpinteiro [400%]; aux. Carpinteiro [200%] | 316.8h | 24,164.53 | 1. Casa 1 | 2. Coberta | 4. Coberta 1 | Própria |  |  |  |

| ID | WBS | Task | Duration | Start | Finish | Predecessors | Total slack | Free slack | Resources | Work | Cost | Casa | Pav | Equipe | Empresa | Pacote | Cor | LB |
| --- | --- | --- | --- | --- | --- | --- | --- | --- | --- | --- | --- | --- | --- | --- | --- | --- | --- | --- |
| 52 | 1.3.2 | **2. Casa 2** | 495d | 2023-08-02 | 2025-08-08 |  | -1d | 0d |  | 7568h | 338,293.15 |  |  |  |  |  |  |  |
| 53 | 1.3.2.1 | **0. Térreo** | 494d | 2023-08-02 | 2025-08-07 |  | -1d | 0d |  | 3801.6h | 165,509.25 |  |  |  |  |  |  |  |
| 54 | 1.3.2.1.1 | 0. Locação | 2d | 2023-08-02 | 2023-08-03 | 7 | -1d | 0d | carpinteiro; aux. Carpinteiro | 35.2h | 456.99 | 2. Casa 2 | 0. Térreo | 0. Locação 1 | Própria |  |  |  |
| 55 | 1.3.2.1.2 | 1. Fundação | 9d | 2023-09-06 | 2023-09-19 | 8 | 747d | 0d | servente estrutura [300%]; aux. Carpinteiro; aux. ferreiro; ferreiro; carpinteiro [200%] | 633.6h | 19,882.86 | 2. Casa 2 | 0. Térreo | 1. Fundação 1 | Própria |  |  |  |
| 56 | 1.3.2.1.3 | 2. Estrutura | 7d | 2023-10-25 | 2023-11-03 | 29 | 367d | 0d | servente estrutura [300%]; aux. Carpinteiro [200%]; aux. ferreiro [200%]; ferreiro [500%]; carpinteiro [200%] | 862.4h | 46,439.03 | 2. Casa 2 | 0. Térreo | 2. Estrutura 1 | Própria |  |  |  |
| 57 | 1.3.2.1.4 | 3. Alvenarias | 5d | 2023-12-01 | 2023-12-07 | 49 | -2d | 0d | pedreiro [400%]; servente [400%] | 352h | 8,388.41 | 2. Casa 2 | 0. Térreo | 3. Alvenarias 1 | Própria |  |  |  |
| 58 | 1.3.2.1.5 | 5. Ref. Inter. Arg (Parede) | 3d | 2024-05-22 | 2024-05-24 | 31 | -2d | 0d | pedreiro [600%]; servente [600%] | 316.8h | 5,776 | 2. Casa 2 | 0. Térreo | 5. Ref. Inter. Arg (Parede) 1 | Própria |  |  |  |
| 59 | 1.3.2.1.6 | 6. Revest. Gesso (Parede + Teto) | 3d | 2024-06-10 | 2024-06-13 | 79SF | 316d | 0d | gesseiro [400%]; aux. gesseiro [200%] | 158.4h | 2,119.41 | 2. Casa 2 | 0. Térreo | 6. Revest. Gesso (Parede + Teto) 1 | Própria |  |  |  |
| 60 | 1.3.2.1.7 | 7. Impermeabilização | 2d | 2024-07-01 | 2024-07-03 | 80SF | 302d | 0d | aplicador de manta | 17.6h | 3,288.15 | 2. Casa 2 | 0. Térreo | 7. Impermeabilização 1 | Própria |  |  |  |
| 61 | 1.3.2.1.8 | 8. Contrapiso | 2d | 2024-07-09 | 2024-07-11 | 128SF | 296d | 0d | pedreiro [200%]; servente | 52.8h | 3,735.07 | 2. Casa 2 | 0. Térreo | 8. Contrapiso 1 | Própria |  |  |  |
| 62 | 1.3.2.1.9 | 9.1. Chapisco | 0.5d | 2024-09-26 | 2024-09-26 | 35 | 84.5d | 0d | pedreiro [600%]; servente [400%] | 44h | 5,131.51 | 2. Casa 2 | 0. Térreo | 9. Fachada 1 | Própria |  |  |  |
| 63 | 1.3.2.1.10 | 9.2. Emboço | 1.5d | 2024-10-23 | 2024-10-24 | 83 | 84.5d | 0d | pedreiro [600%]; servente [400%] | 132h | 7,697.26 | 2. Casa 2 | 0. Térreo | 9. Fachada 1 | Própria |  |  |  |
| 64 | 1.3.2.1.11 | 9.3. Pint. 1 Demão | 1d | 2024-12-27 | 2024-12-30 | 84 | 84.5d | 0d | pintor [400%]; aux.pintor [200%] | 52.8h | 1,135.92 | 2. Casa 2 | 0. Térreo | 9. Fachada 1 | Própria |  |  |  |
| 65 | 1.3.2.1.12 | 9.4. Pint. 2 Demão | 2d | 2025-02-14 | 2025-02-18 | 85 | 84.5d | 0d | pintor [400%]; aux.pintor [200%] | 105.6h | 757.28 | 2. Casa 2 | 0. Térreo | 9. Fachada 1 | Própria |  |  |  |
| 66 | 1.3.2.1.13 | 10. Cer. Piso | 4d | 2024-09-19 | 2024-09-24 | 39 | 0d |  | pedreiro [400%]; servente [200%] | 211.2h | 25,485.98 | 2. Casa 2 | 0. Térreo | 10. Cer. Piso 1 | Própria | 10 | 10 | 10 |
| 67 | 1.3.2.1.14 | 11. Cer. Parede | 3d | 2024-12-16 | 2024-12-18 | 40 | 0d |  | pedreiro [400%]; servente [200%] | 158.4h | 4,238.82 | 2. Casa 2 | 0. Térreo | 11. Cer. Parede 1 | Própria | 11 | 11 | 11 |
| 68 | 1.3.2.1.15 | 12. Forro (WC's e cozinha) | 1d | 2025-01-16 | 2025-01-17 | 88SF | 0d |  | gesseiro; aux. gesseiro | 17.6h | 635.82 | 2. Casa 2 | 0. Térreo | 12. Forro (WC's e cozinha) 1 | Própria | 12 | 12 | 12 |
| 69 | 1.3.2.1.16 | 13. Esq. Alumínio | 2d | 2025-01-22 | 2025-01-23 | 42 | 100d | 0d | montador esquadrias | 17.6h | 11,307.22 | 2. Casa 2 | 0. Térreo | 13. Esq. Alumínio 1 | Própria | 13 | 13 | 13 |
| 70 | 1.3.2.1.17 | 14. Portas | 2d | 2025-01-24 | 2025-01-27 | 43 | 0d |  | marceneiro [200%] | 35.2h | 2,827.85 | 2. Casa 2 | 0. Térreo | 14. Portas 1 | Própria | 14 | 14 | 14 |
| 71 | 1.3.2.1.18 | 15. Pintura (1ª Demão) | 4d | 2025-03-21 | 2025-03-27 | 44 | 0d |  | pintor [600%]; aux.pintor [300%] | 316.8h | 3,764.82 | 2. Casa 2 | 0. Térreo | 15. Pintura (1ª Demão) 1 | Própria | 15 | 15 | 15 |
| 72 | 1.3.2.1.19 | 16. Bancadas | 1d | 2025-05-27 | 2025-05-28 | 92SF | 78d | 0d | pedreiro [200%]; servente | 26.4h | 10,458.12 | 2. Casa 2 | 0. Térreo | 16. Bancadas 1 | Própria | 16 | 16 | 16 |
| 73 | 1.3.2.1.20 | 17. Pintura (2ª Demão) | 3d | 2025-06-25 | 2025-06-27 | 46 | 0d |  | pintor [600%]; aux.pintor [300%] | 237.6h | 1,563.98 | 2. Casa 2 | 0. Térreo | 17. Pintura (2ª Demão) 1 | Própria | 17 | 17 | 17 |
| 74 | 1.3.2.1.21 | 18. Limp. Interna | 1d | 2025-08-06 | 2025-08-07 | 94SF | 29d | 0d | Diarista [200%] | 17.6h | 418.75 | 2. Casa 2 | 0. Térreo | 18. Limp. Interna 1 | Própria | 18 | 18 | 18 |
| 75 | 1.3.2.2 | **1. Pav. Superior** | 430d | 2023-11-06 | 2025-08-08 |  | 21d |  |  | 3229.6h | 114,620.72 |  |  |  |  |  |  |  |
| 76 | 1.3.2.2.1 | 2. Estrutura | 7d | 2023-11-06 | 2023-11-14 | 56 | 367d | 0d | servente estrutura [300%]; aux. Carpinteiro [200%]; aux. ferreiro [200%]; ferreiro [500%]; carpinteiro [200%] | 862.4h | 30,006.55 | 2. Casa 2 | 1. Pav. Superior | 2. Estrutura 1 | Própria |  |  |  |
| 77 | 1.3.2.2.2 | 3. Alvenarias | 5d | 2023-12-08 | 2023-12-14 | 57 | -2d | 0d | servente [400%]; pedreiro [400%] | 352h | 10,101.74 | 2. Casa 2 | 1. Pav. Superior | 3. Alvenarias 1 | Própria |  |  |  |
| 78 | 1.3.2.2.3 | 5. Ref. Inter. Arg (Parede) | 4d | 2024-05-27 | 2024-06-03 | 58 | -2d | 0d | pedreiro [600%]; servente [600%] | 422.4h | 5,398.69 | 2. Casa 2 | 1. Pav. Superior | 5. Ref. Inter. Arg (Parede) 1 | Própria |  |  |  |
| 79 | 1.3.2.2.4 | 6. Revest. Gesso (Parede + Teto) | 4d | 2024-06-13 | 2024-06-19 | 106SF | 312d | 0d | aux. gesseiro [200%]; gesseiro [400%] | 211.2h | 2,119.41 | 2. Casa 2 | 1. Pav. Superior | 6. Revest. Gesso (Parede + Teto) 1 | Própria |  |  |  |
| 80 | 1.3.2.2.5 | 7. Impermeabilização | 1d | 2024-07-03 | 2024-07-04 | 97SF | 301d | 0d | aplicador de manta | 8.8h | 2,046.85 | 2. Casa 2 | 1. Pav. Superior | 7. Impermeabilização 1 | Própria |  |  |  |
| 81 | 1.3.2.2.6 | 8. Contrapiso | 2d | 2024-07-05 | 2024-07-09 | 61SF | 298d | 0d | pedreiro [200%]; servente | 52.8h | 2,476.11 | 2. Casa 2 | 1. Pav. Superior | 8. Contrapiso 1 | Própria |  |  |  |
| 82 | 1.3.2.2.7 | 9.1. Chapisco | 0.5d | 2024-09-26 | 2024-09-26 | 62 | 84.5d | 0d | pedreiro [600%]; servente [400%] | 44h | 5,131.51 | 2. Casa 2 | 1. Pav. Superior | 9. Fachada 1 | Própria |  |  |  |
| 83 | 1.3.2.2.8 | 9.2. Emboço | 1.5d | 2024-10-22 | 2024-10-23 | 16 | 84.5d | 0d | pedreiro [600%]; servente [400%] | 132h | 7,697.26 | 2. Casa 2 | 1. Pav. Superior | 9. Fachada 1 | Própria |  |  |  |
| 84 | 1.3.2.2.9 | 9.3. Pint. 1 Demão | 1d | 2024-12-26 | 2024-12-27 | 17 | 84.5d | 0d | pintor [400%]; aux.pintor [200%] | 52.8h | 1,135.92 | 2. Casa 2 | 1. Pav. Superior | 9. Fachada 1 | Própria |  |  |  |
| 85 | 1.3.2.2.10 | 9.4. Pint. 2 Demão | 2d | 2025-02-12 | 2025-02-14 | 18 | 84.5d | 0d | pintor [400%]; aux.pintor [200%] | 105.6h | 757.28 | 2. Casa 2 | 1. Pav. Superior | 9. Fachada 1 | Própria |  |  |  |
| 86 | 1.3.2.2.11 | 10. Cer. Piso | 4d | 2024-09-25 | 2024-09-30 | 66 | 0d |  | pedreiro [400%]; servente [200%] | 211.2h | 19,807.17 | 2. Casa 2 | 1. Pav. Superior | 10. Cer. Piso 1 | Própria | 10 | 10 | 10 |
| 87 | 1.3.2.2.12 | 11. Cer. Parede | 2d | 2024-12-19 | 2024-12-20 | 67 | 0d |  | pedreiro [400%]; servente [200%] | 105.6h | 4,238.82 | 2. Casa 2 | 1. Pav. Superior | 11. Cer. Parede 1 | Própria | 11 | 11 | 11 |
| 88 | 1.3.2.2.13 | 12. Forro (WC's e cozinha) | 1d | 2025-01-17 | 2025-01-20 | 115SF | 0d |  | gesseiro; aux. gesseiro | 17.6h | 635.82 | 2. Casa 2 | 1. Pav. Superior | 12. Forro (WC's e cozinha) 1 | Própria | 12 | 12 | 12 |
| 89 | 1.3.2.2.14 | 13. Esq. Alumínio | 2d | 2025-01-24 | 2025-01-27 | 69 | 100d | 0d | montador esquadrias | 17.6h | 8,489.61 | 2. Casa 2 | 1. Pav. Superior | 13. Esq. Alumínio 1 | Própria | 13 | 13 | 13 |
| 90 | 1.3.2.2.15 | 14. Portas | 2d | 2025-01-28 | 2025-01-29 | 70 | 0d |  | marceneiro [200%] | 35.2h | 1,858.35 | 2. Casa 2 | 1. Pav. Superior | 14. Portas 1 | Própria | 14 | 14 | 14 |
| 91 | 1.3.2.2.16 | 15. Pintura (1ª Demão) | 4d | 2025-03-28 | 2025-04-02 | 71 | 0d |  | pintor [600%]; aux.pintor [300%] | 316.8h | 3,764.82 | 2. Casa 2 | 1. Pav. Superior | 15. Pintura (1ª Demão) 1 | Própria | 15 | 15 | 15 |
| 92 | 1.3.2.2.17 | 16. Bancadas | 1d | 2025-05-28 | 2025-05-29 | 119SF | 77d | 0d | servente; pedreiro [200%] | 26.4h | 6,972.08 | 2. Casa 2 | 1. Pav. Superior | 16. Bancadas 1 | Própria | 16 | 16 | 16 |
| 93 | 1.3.2.2.18 | 17. Pintura (2ª Demão) | 3d | 2025-06-30 | 2025-07-02 | 73 | 0d |  | aux.pintor [300%]; pintor [600%] | 237.6h | 1,563.98 | 2. Casa 2 | 1. Pav. Superior | 17. Pintura (2ª Demão) 1 | Própria | 17 | 17 | 17 |
| 94 | 1.3.2.2.19 | 18. Limp. Interna | 1d | 2025-08-07 | 2025-08-08 | 121SF | 28d | 0d | Diarista [200%] | 17.6h | 418.75 | 2. Casa 2 | 1. Pav. Superior | 18. Limp. Interna 1 | Própria | 18 | 18 | 18 |

| ID | WBS | Task | Duration | Start | Finish | Predecessors | Total slack | Free slack | Resources | Work | Cost | Casa | Pav | Equipe | Empresa | Pacote | Cor | LB |
| --- | --- | --- | --- | --- | --- | --- | --- | --- | --- | --- | --- | --- | --- | --- | --- | --- | --- | --- |
| 95 | 1.3.2.3 | **2. Coberta** | 130d | 2023-12-15 | 2024-07-05 |  | -2d | 0d |  | 536.8h | 58,163.18 |  |  |  |  |  |  |  |
| 96 | 1.3.2.3.1 | 1. Alvenarias | 3d | 2023-12-15 | 2023-12-19 | 77 | -2d | 0d | pedreiro [400%]; servente [400%] | 211.2h | 9,834.12 | 2. Casa 2 | 2. Coberta | 3. Alvenarias 1 | Própria |  |  |  |
| 97 | 1.3.2.3.2 | 2. Impermeabilização | 1d | 2024-07-04 | 2024-07-05 | 107SF | 300d | 0d | aplicador de manta | 8.8h | 24,164.53 | 2. Casa 2 | 2. Coberta | 7. Impermeabilização 1 | Própria |  |  |  |
| 98 | 1.3.2.3.3 | 3. Coberta | 6d | 2024-02-29 | 2024-03-08 | 145SF | 379d | 0d | carpinteiro [400%]; aux. Carpinteiro [200%] | 316.8h | 24,164.53 | 2. Casa 2 | 2. Coberta | 4. Coberta 1 | Própria |  |  |  |
| 99 | 1.3.3 | **3. Casa 3** | 495d | 2023-08-04 | 2025-08-12 |  | -1d | 0d |  | 7568h | 338,552.33 |  |  |  |  |  |  |  |
| 100 | 1.3.3.1 | **0. Térreo** | 494d | 2023-08-04 | 2025-08-11 |  | -1d | 0d |  | 3801.6h | 165,768.43 |  |  |  |  |  |  |  |
| 101 | 1.3.3.1.1 | 0. Locação | 2d | 2023-08-04 | 2023-08-07 | 54 | -1d | 0d | carpinteiro; aux. Carpinteiro | 35.2h | 456.99 | 3. Casa 3 | 0. Térreo | 0. Locação 1 | Própria |  |  |  |
| 102 | 1.3.3.1.2 | 1. Fundação | 9d | 2023-09-20 | 2023-10-02 | 55 | 747d | 0d | servente estrutura [300%]; aux. Carpinteiro; aux. ferreiro; ferreiro; carpinteiro [200%] | 633.6h | 19,882.86 | 3. Casa 3 | 0. Térreo | 1. Fundação 1 | Própria |  |  |  |
| 103 | 1.3.3.1.3 | 2. Estrutura | 7d | 2023-11-16 | 2023-11-24 | 76 | 367d | 0d | servente estrutura [300%]; aux. Carpinteiro [200%]; aux. ferreiro [200%]; ferreiro [500%]; carpinteiro [200%] | 862.4h | 46,439.03 | 3. Casa 3 | 0. Térreo | 2. Estrutura 1 | Própria |  |  |  |
| 104 | 1.3.3.1.4 | 3. Alvenarias | 5d | 2023-12-20 | 2024-01-03 | 96 | -2d | 0d | pedreiro [400%]; servente [400%] | 352h | 8,388.41 | 3. Casa 3 | 0. Térreo | 3. Alvenarias 1 | Própria |  |  |  |
| 105 | 1.3.3.1.5 | 5. Ref. Inter. Arg (Parede) | 3d | 2024-06-04 | 2024-06-06 | 78 | -2d | 0d | pedreiro [600%]; servente [600%] | 316.8h | 5,776 | 3. Casa 3 | 0. Térreo | 5. Ref. Inter. Arg (Parede) 1 | Própria |  |  |  |
| 106 | 1.3.3.1.6 | 6. Revest. Gesso (Parede + Teto) | 3d | 2024-06-19 | 2024-06-24 | 126SF | 309d | 0d | gesseiro [400%]; aux. gesseiro [200%] | 158.4h | 2,119.41 | 3. Casa 3 | 0. Térreo | 6. Revest. Gesso (Parede + Teto) 1 | Própria |  |  |  |
| 107 | 1.3.3.1.7 | 7. Impermeabilização | 2d | 2024-07-05 | 2024-07-09 | 127SF | 298d | 0d | aplicador de manta | 17.6h | 3,288.15 | 3. Casa 3 | 0. Térreo | 7. Impermeabilização 1 | Própria |  |  |  |
| 108 | 1.3.3.1.8 | 8. Contrapiso | 2d | 2024-07-15 | 2024-07-17 | 175SF | 292d | 0d | pedreiro [200%]; servente | 52.8h | 3,735.07 | 3. Casa 3 | 0. Térreo | 8. Contrapiso 1 | Própria |  |  |  |
| 109 | 1.3.3.1.9 | 9.1. Chapisco | 0.5d | 2024-09-27 | 2024-09-27 | 82 | 84.5d | 0d | pedreiro [600%]; servente [400%] | 44h | 5,131.51 | 3. Casa 3 | 0. Térreo | 9. Fachada 1 | Própria |  |  |  |
| 110 | 1.3.3.1.10 | 9.2. Emboço | 1.5d | 2024-10-28 | 2024-10-29 | 130 | 84.5d | 0d | pedreiro [600%]; servente [400%] | 132h | 7,697.26 | 3. Casa 3 | 0. Térreo | 9. Fachada 1 | Própria |  |  |  |
| 111 | 1.3.3.1.11 | 9.3. Pint. 1 Demão | 1d | 2024-12-31 | 2025-01-02 | 131 | 84.5d | 0d | pintor [400%]; aux.pintor [200%] | 52.8h | 1,135.92 | 3. Casa 3 | 0. Térreo | 9. Fachada 1 | Própria |  |  |  |
| 112 | 1.3.3.1.12 | 9.4. Pint. 2 Demão | 2d | 2025-02-20 | 2025-02-24 | 132 | 84.5d | 0d | pintor [400%]; aux.pintor [200%] | 105.6h | 757.28 | 3. Casa 3 | 0. Térreo | 9. Fachada 1 | Própria |  |  |  |
| 113 | 1.3.3.1.13 | 10. Cer. Piso | 4d | 2024-10-01 | 2024-10-04 | 86 | 0d |  | pedreiro [400%]; servente [200%] | 211.2h | 25,485.98 | 3. Casa 3 | 0. Térreo | 10. Cer. Piso 1 | Própria | 10 | 10 | 10 |
| 114 | 1.3.3.1.14 | 11. Cer. Parede | 3d | 2024-12-23 | 2024-12-26 | 87 | 0d |  | pedreiro [400%]; servente [200%] | 158.4h | 4,238.82 | 3. Casa 3 | 0. Térreo | 11. Cer. Parede 1 | Própria | 11 | 11 | 11 |
| 115 | 1.3.3.1.15 | 12. Forro (WC's e cozinha) | 1d | 2025-01-20 | 2025-01-21 | 135SF | 0d |  | gesseiro; aux. gesseiro | 17.6h | 895 | 3. Casa 3 | 0. Térreo | 12. Forro (WC's e cozinha) 1 | Própria | 12 | 12 | 12 |
| 116 | 1.3.3.1.16 | 13. Esq. Alumínio | 2d | 2025-01-28 | 2025-01-29 | 89 | 100d | 0d | montador esquadrias | 17.6h | 11,307.22 | 3. Casa 3 | 0. Térreo | 13. Esq. Alumínio 1 | Própria | 13 | 13 | 13 |
| 117 | 1.3.3.1.17 | 14. Portas | 2d | 2025-01-30 | 2025-01-31 | 90 | 0d |  | marceneiro [200%] | 35.2h | 2,827.85 | 3. Casa 3 | 0. Térreo | 14. Portas 1 | Própria | 14 | 14 | 14 |
| 118 | 1.3.3.1.18 | 15. Pintura (1ª Demão) | 4d | 2025-04-03 | 2025-04-08 | 91 | 0d |  | pintor [600%]; aux.pintor [300%] | 316.8h | 3,764.82 | 3. Casa 3 | 0. Térreo | 15. Pintura (1ª Demão) 1 | Própria | 15 | 15 | 15 |
| 119 | 1.3.3.1.19 | 16. Bancadas | 1d | 2025-05-29 | 2025-05-30 | 139SF | 76d | 0d | pedreiro [200%]; servente | 26.4h | 10,458.12 | 3. Casa 3 | 0. Térreo | 16. Bancadas 1 | Própria | 16 | 16 | 16 |
| 120 | 1.3.3.1.20 | 17. Pintura (2ª Demão) | 3d | 2025-07-03 | 2025-07-07 | 93 | 0d |  | pintor [600%]; aux.pintor [300%] | 237.6h | 1,563.98 | 3. Casa 3 | 0. Térreo | 17. Pintura (2ª Demão) 1 | Própria | 17 | 17 | 17 |
| 121 | 1.3.3.1.21 | 18. Limp. Interna | 1d | 2025-08-08 | 2025-08-11 | 141SF | 27d | 0d | Diarista [200%] | 17.6h | 418.75 | 3. Casa 3 | 0. Térreo | 18. Limp. Interna 1 | Própria | 18 | 18 | 18 |

| ID | WBS | Task | Duration | Start | Finish | Predecessors | Total slack | Free slack | Resources | Work | Cost | Casa | Pav | Equipe | Empresa | Pacote | Cor | LB |
| --- | --- | --- | --- | --- | --- | --- | --- | --- | --- | --- | --- | --- | --- | --- | --- | --- | --- | --- |
| 122 | 1.3.3.2 | **1. Pav. Superior** | 418d | 2023-11-27 | 2025-08-12 |  | 20d |  |  | 3229.6h | 114,620.72 |  |  |  |  |  |  |  |
| 123 | 1.3.3.2.1 | 2. Estrutura | 7d | 2023-11-27 | 2023-12-05 | 103 | 367d | 0d | servente estrutura [300%]; aux. Carpinteiro [200%]; aux. ferreiro [200%]; ferreiro [500%]; carpinteiro [200%] | 862.4h | 30,006.55 | 3. Casa 3 | 1. Pav. Superior | 2. Estrutura 1 | Própria |  |  |  |
| 124 | 1.3.3.2.2 | 3. Alvenarias | 5d | 2024-01-04 | 2024-01-10 | 104 | -2d | 0d | servente [400%]; pedreiro [400%] | 352h | 10,101.74 | 3. Casa 3 | 1. Pav. Superior | 3. Alvenarias 1 | Própria |  |  |  |
| 125 | 1.3.3.2.3 | 5. Ref. Inter. Arg (Parede) | 4d | 2024-06-07 | 2024-06-12 | 105 | -2d | 0d | pedreiro [600%]; servente [600%] | 422.4h | 5,398.69 | 3. Casa 3 | 1. Pav. Superior | 5. Ref. Inter. Arg (Parede) 1 | Própria |  |  |  |
| 126 | 1.3.3.2.4 | 6. Revest. Gesso (Parede + Teto) | 4d | 2024-06-24 | 2024-06-28 | 153SF | 305d | 0d | aux. gesseiro [200%]; gesseiro [400%] | 211.2h | 2,119.41 | 3. Casa 3 | 1. Pav. Superior | 6. Revest. Gesso (Parede + Teto) 1 | Própria |  |  |  |
| 127 | 1.3.3.2.5 | 7. Impermeabilização | 1d | 2024-07-09 | 2024-07-10 | 144SF | 297d | 0d | aplicador de manta | 8.8h | 2,046.85 | 3. Casa 3 | 1. Pav. Superior | 7. Impermeabilização 1 | Própria |  |  |  |
| 128 | 1.3.3.2.6 | 8. Contrapiso | 2d | 2024-07-11 | 2024-07-15 | 108SF | 294d | 0d | pedreiro [200%]; servente | 52.8h | 2,476.11 | 3. Casa 3 | 1. Pav. Superior | 8. Contrapiso 1 | Própria |  |  |  |
| 129 | 1.3.3.2.7 | 9.1. Chapisco | 0.5d | 2024-09-27 | 2024-09-27 | 109 | 84.5d | 0d | pedreiro [600%]; servente [400%] | 44h | 5,131.51 | 3. Casa 3 | 1. Pav. Superior | 9. Fachada 1 | Própria |  |  |  |
| 130 | 1.3.3.2.8 | 9.2. Emboço | 1.5d | 2024-10-25 | 2024-10-28 | 63 | 84.5d | 0d | pedreiro [600%]; servente [400%] | 132h | 7,697.26 | 3. Casa 3 | 1. Pav. Superior | 9. Fachada 1 | Própria |  |  |  |
| 131 | 1.3.3.2.9 | 9.3. Pint. 1 Demão | 1d | 2024-12-30 | 2024-12-31 | 64 | 84.5d | 0d | pintor [400%]; aux.pintor [200%] | 52.8h | 1,135.92 | 3. Casa 3 | 1. Pav. Superior | 9. Fachada 1 | Própria |  |  |  |
| 132 | 1.3.3.2.10 | 9.4. Pint. 2 Demão | 2d | 2025-02-18 | 2025-02-20 | 65 | 84.5d | 0d | pintor [400%]; aux.pintor [200%] | 105.6h | 757.28 | 3. Casa 3 | 1. Pav. Superior | 9. Fachada 1 | Própria |  |  |  |
| 133 | 1.3.3.2.11 | 10. Cer. Piso | 4d | 2024-10-07 | 2024-10-10 | 113 | 0d |  | servente [200%]; pedreiro [400%] | 211.2h | 19,807.17 | 3. Casa 3 | 1. Pav. Superior | 10. Cer. Piso 1 | Própria | 10 | 10 | 10 |
| 134 | 1.3.3.2.12 | 11. Cer. Parede | 2d | 2024-12-27 | 2024-12-30 | 114 | 0d |  | pedreiro [400%]; servente [200%] | 105.6h | 4,238.82 | 3. Casa 3 | 1. Pav. Superior | 11. Cer. Parede 1 | Própria | 11 | 11 | 11 |
| 135 | 1.3.3.2.13 | 12. Forro (WC's e cozinha) | 1d | 2025-01-21 | 2025-01-22 | 162SF | 0d |  | aux. gesseiro; gesseiro | 17.6h | 635.82 | 3. Casa 3 | 1. Pav. Superior | 12. Forro (WC's e cozinha) 1 | Própria | 12 | 12 | 12 |
| 136 | 1.3.3.2.14 | 13. Esq. Alumínio | 2d | 2025-01-30 | 2025-01-31 | 116 | 100d | 0d | montador esquadrias | 17.6h | 8,489.61 | 3. Casa 3 | 1. Pav. Superior | 13. Esq. Alumínio 1 | Própria | 13 | 13 | 13 |
| 137 | 1.3.3.2.15 | 14. Portas | 2d | 2025-02-03 | 2025-02-04 | 117 | 0d |  | marceneiro [200%] | 35.2h | 1,858.35 | 3. Casa 3 | 1. Pav. Superior | 14. Portas 1 | Própria | 14 | 14 | 14 |
| 138 | 1.3.3.2.16 | 15. Pintura (1ª Demão) | 4d | 2025-04-09 | 2025-04-14 | 118 | 0d |  | pintor [600%]; aux.pintor [300%] | 316.8h | 3,764.82 | 3. Casa 3 | 1. Pav. Superior | 15. Pintura (1ª Demão) 1 | Própria | 15 | 15 | 15 |
| 139 | 1.3.3.2.17 | 16. Bancadas | 1d | 2025-05-30 | 2025-06-02 | 166SF | 75d | 0d | servente; pedreiro [200%] | 26.4h | 6,972.08 | 3. Casa 3 | 1. Pav. Superior | 16. Bancadas 1 | Própria | 16 | 16 | 16 |
| 140 | 1.3.3.2.18 | 17. Pintura (2ª Demão) | 3d | 2025-07-08 | 2025-07-10 | 120 | 0d |  | aux.pintor [300%]; pintor [600%] | 237.6h | 1,563.98 | 3. Casa 3 | 1. Pav. Superior | 17. Pintura (2ª Demão) 1 | Própria | 17 | 17 | 17 |
| 141 | 1.3.3.2.19 | 18. Limp. Interna | 1d | 2025-08-11 | 2025-08-12 | 168SF | 26d | 0d | Diarista [200%] | 17.6h | 418.75 | 3. Casa 3 | 1. Pav. Superior | 18. Limp. Interna 1 | Própria | 18 | 18 | 18 |
| 142 | 1.3.3.3 | **2. Coberta** | 121d | 2024-01-11 | 2024-07-11 |  | -2d | 0d |  | 536.8h | 58,163.18 |  |  |  |  |  |  |  |
| 143 | 1.3.3.3.1 | 1. Alvenarias | 3d | 2024-01-11 | 2024-01-15 | 124 | -2d | 0d | pedreiro [400%]; servente [400%] | 211.2h | 9,834.12 | 3. Casa 3 | 2. Coberta | 3. Alvenarias 1 | Própria |  |  |  |
| 144 | 1.3.3.3.2 | 2. Impermeabilização | 1d | 2024-07-10 | 2024-07-11 | 154SF | 296d | 0d | aplicador de manta | 8.8h | 24,164.53 | 3. Casa 3 | 2. Coberta | 7. Impermeabilização 1 | Própria |  |  |  |
| 145 | 1.3.3.3.3 | 3. Coberta | 6d | 2024-03-08 | 2024-03-18 | 192SF | 373d | 0d | carpinteiro [400%]; aux. Carpinteiro [200%] | 316.8h | 24,164.53 | 3. Casa 3 | 2. Coberta | 4. Coberta 1 | Própria |  |  |  |

| ID | WBS | Task | Duration | Start | Finish | Predecessors | Total slack | Free slack | Resources | Work | Cost | Casa | Pav | Equipe | Empresa | Pacote | Cor | LB |
| --- | --- | --- | --- | --- | --- | --- | --- | --- | --- | --- | --- | --- | --- | --- | --- | --- | --- | --- |
| 146 | 1.3.4 | **4. Casa 4** | 495d | 2023-08-08 | 2025-08-14 |  | -1d | 0d |  | 7568h | 338,552.33 |  |  |  |  |  |  |  |
| 147 | 1.3.4.1 | **0. Térreo** | 494d | 2023-08-08 | 2025-08-13 |  | -1d | 0d |  | 3801.6h | 165,768.43 |  |  |  |  |  |  |  |
| 148 | 1.3.4.1.1 | 0. Locação | 2d | 2023-08-08 | 2023-08-09 | 101 | -1d | 0d | carpinteiro; aux. Carpinteiro | 35.2h | 456.99 | 4. Casa 4 | 0. Térreo | 0. Locação 1 | Própria |  |  |  |
| 149 | 1.3.4.1.2 | 1. Fundação | 9d | 2023-10-03 | 2023-10-16 | 102 | 747d | 0d | servente estrutura [300%]; aux. Carpinteiro; aux. ferreiro; ferreiro; carpinteiro [200%] | 633.6h | 19,882.86 | 4. Casa 4 | 0. Térreo | 1. Fundação 1 | Própria |  |  |  |
| 150 | 1.3.4.1.3 | 2. Estrutura | 7d | 2023-12-06 | 2023-12-14 | 123 | 367d | 0d | servente estrutura [300%]; aux. Carpinteiro [200%]; aux. ferreiro [200%]; ferreiro [500%]; carpinteiro [200%] | 862.4h | 46,439.03 | 4. Casa 4 | 0. Térreo | 2. Estrutura 1 | Própria |  |  |  |
| 151 | 1.3.4.1.4 | 3. Alvenarias | 5d | 2024-01-16 | 2024-01-22 | 143 | -2d | 0d | pedreiro [400%]; servente [400%] | 352h | 8,388.41 | 4. Casa 4 | 0. Térreo | 3. Alvenarias 1 | Própria |  |  |  |
| 152 | 1.3.4.1.5 | 5. Ref. Inter. Arg (Parede) | 3d | 2024-06-13 | 2024-06-17 | 125 | -2d | 0d | pedreiro [600%]; servente [600%] | 316.8h | 5,776 | 4. Casa 4 | 0. Térreo | 5. Ref. Inter. Arg (Parede) 1 | Própria |  |  |  |
| 153 | 1.3.4.1.6 | 6. Revest. Gesso (Parede + Teto) | 3d | 2024-06-28 | 2024-07-03 | 173SF | 302d | 0d | gesseiro [400%]; aux. gesseiro [200%] | 158.4h | 2,119.41 | 4. Casa 4 | 0. Térreo | 6. Revest. Gesso (Parede + Teto) 1 | Própria |  |  |  |
| 154 | 1.3.4.1.7 | 7. Impermeabilização | 2d | 2024-07-11 | 2024-07-15 | 174SF | 294d | 0d | aplicador de manta | 17.6h | 3,288.15 | 4. Casa 4 | 0. Térreo | 7. Impermeabilização 1 | Própria |  |  |  |
| 155 | 1.3.4.1.8 | 8. Contrapiso | 2d | 2024-07-19 | 2024-07-23 | 222SF | 288d | 0d | pedreiro [200%]; servente | 52.8h | 3,735.07 | 4. Casa 4 | 0. Térreo | 8. Contrapiso 1 | Própria |  |  |  |
| 156 | 1.3.4.1.9 | 9.1. Chapisco | 0.5d | 2024-09-30 | 2024-09-30 | 129 | 84.5d | 0d | pedreiro [600%]; servente [400%] | 44h | 5,131.51 | 4. Casa 4 | 0. Térreo | 9. Fachada 1 | Própria |  |  |  |
| 157 | 1.3.4.1.10 | 9.2. Emboço | 1.5d | 2024-10-31 | 2024-11-01 | 177 | 84.5d | 0d | pedreiro [600%]; servente [400%] | 132h | 7,697.26 | 4. Casa 4 | 0. Térreo | 9. Fachada 1 | Própria |  |  |  |
| 158 | 1.3.4.1.11 | 9.3. Pint. 1 Demão | 1d | 2025-01-03 | 2025-01-06 | 178 | 84.5d | 0d | pintor [400%]; aux.pintor [200%] | 52.8h | 1,135.92 | 4. Casa 4 | 0. Térreo | 9. Fachada 1 | Própria |  |  |  |
| 159 | 1.3.4.1.12 | 9.4. Pint. 2 Demão | 2d | 2025-02-26 | 2025-02-28 | 179 | 84.5d | 0d | pintor [400%]; aux.pintor [200%] | 105.6h | 757.28 | 4. Casa 4 | 0. Térreo | 9. Fachada 1 | Própria |  |  |  |
| 160 | 1.3.4.1.13 | 10. Cer. Piso | 4d | 2024-10-11 | 2024-10-16 | 133 | 0d |  | pedreiro [400%]; servente [200%] | 211.2h | 25,485.98 | 4. Casa 4 | 0. Térreo | 10. Cer. Piso 1 | Própria | 10 | 10 | 10 |
| 161 | 1.3.4.1.14 | 11. Cer. Parede | 3d | 2024-12-31 | 2025-01-03 | 134 | 0d |  | pedreiro [400%]; servente [200%] | 158.4h | 4,238.82 | 4. Casa 4 | 0. Térreo | 11. Cer. Parede 1 | Própria | 11 | 11 | 11 |
| 162 | 1.3.4.1.15 | 12. Forro (WC's e cozinha) | 1d | 2025-01-22 | 2025-01-23 | 182SF | 0d |  | gesseiro; aux. gesseiro | 17.6h | 895 | 4. Casa 4 | 0. Térreo | 12. Forro (WC's e cozinha) 1 | Própria | 12 | 12 | 12 |
| 163 | 1.3.4.1.16 | 13. Esq. Alumínio | 2d | 2025-02-03 | 2025-02-04 | 136 | 100d | 0d | montador esquadrias | 17.6h | 11,307.22 | 4. Casa 4 | 0. Térreo | 13. Esq. Alumínio 1 | Própria | 13 | 13 | 13 |
| 164 | 1.3.4.1.17 | 14. Portas | 2d | 2025-02-05 | 2025-02-06 | 137 | 0d |  | marceneiro [200%] | 35.2h | 2,827.85 | 4. Casa 4 | 0. Térreo | 14. Portas 1 | Própria | 14 | 14 | 14 |
| 165 | 1.3.4.1.18 | 15. Pintura (1ª Demão) | 4d | 2025-04-15 | 2025-04-22 | 138 | 0d |  | pintor [600%]; aux.pintor [300%] | 316.8h | 3,764.82 | 4. Casa 4 | 0. Térreo | 15. Pintura (1ª Demão) 1 | Própria | 15 | 15 | 15 |
| 166 | 1.3.4.1.19 | 16. Bancadas | 1d | 2025-06-02 | 2025-06-03 | 186SF | 74d | 0d | pedreiro [200%]; servente | 26.4h | 10,458.12 | 4. Casa 4 | 0. Térreo | 16. Bancadas 1 | Própria | 16 | 16 | 16 |
| 167 | 1.3.4.1.20 | 17. Pintura (2ª Demão) | 3d | 2025-07-11 | 2025-07-15 | 140 | 0d |  | pintor [600%]; aux.pintor [300%] | 237.6h | 1,563.98 | 4. Casa 4 | 0. Térreo | 17. Pintura (2ª Demão) 1 | Própria | 17 | 17 | 17 |
| 168 | 1.3.4.1.21 | 18. Limp. Interna | 1d | 2025-08-12 | 2025-08-13 | 188SF | 25d | 0d | Diarista [200%] | 17.6h | 418.75 | 4. Casa 4 | 0. Térreo | 18. Limp. Interna 1 | Própria | 18 | 18 | 18 |
| 169 | 1.3.4.2 | **1. Pav. Superior** | 406d | 2023-12-15 | 2025-08-14 |  | 19d |  |  | 3229.6h | 114,620.72 |  |  |  |  |  |  |  |
| 170 | 1.3.4.2.1 | 2. Estrutura | 7d | 2023-12-15 | 2024-01-02 | 150 | 367d | 0d | servente estrutura [300%]; aux. Carpinteiro [200%]; aux. ferreiro [200%]; ferreiro [500%]; carpinteiro [200%] | 862.4h | 30,006.55 | 4. Casa 4 | 1. Pav. Superior | 2. Estrutura 1 | Própria |  |  |  |
| 171 | 1.3.4.2.2 | 3. Alvenarias | 5d | 2024-01-23 | 2024-01-29 | 151 | -2d | 0d | servente [400%]; pedreiro [400%] | 352h | 10,101.74 | 4. Casa 4 | 1. Pav. Superior | 3. Alvenarias 1 | Própria |  |  |  |
| 172 | 1.3.4.2.3 | 5. Ref. Inter. Arg (Parede) | 4d | 2024-06-18 | 2024-06-21 | 152 | -2d | 0d | pedreiro [600%]; servente [600%] | 422.4h | 5,398.69 | 4. Casa 4 | 1. Pav. Superior | 5. Ref. Inter. Arg (Parede) 1 | Própria |  |  |  |
| 173 | 1.3.4.2.4 | 6. Revest. Gesso (Parede + Teto) | 4d | 2024-07-03 | 2024-07-09 | 200SF | 298d | 0d | aux. gesseiro [200%]; gesseiro [400%] | 211.2h | 2,119.41 | 4. Casa 4 | 1. Pav. Superior | 6. Revest. Gesso (Parede + Teto) 1 | Própria |  |  |  |
| 174 | 1.3.4.2.5 | 7. Impermeabilização | 1d | 2024-07-15 | 2024-07-16 | 191SF | 293d | 0d | aplicador de manta | 8.8h | 2,046.85 | 4. Casa 4 | 1. Pav. Superior | 7. Impermeabilização 1 | Própria |  |  |  |
| 175 | 1.3.4.2.6 | 8. Contrapiso | 2d | 2024-07-17 | 2024-07-19 | 155SF | 290d | 0d | pedreiro [200%]; servente | 52.8h | 2,476.11 | 4. Casa 4 | 1. Pav. Superior | 8. Contrapiso 1 | Própria |  |  |  |
| 176 | 1.3.4.2.7 | 9.1. Chapisco | 0.5d | 2024-09-30 | 2024-09-30 | 156 | 84.5d | 0d | pedreiro [600%]; servente [400%] | 44h | 5,131.51 | 4. Casa 4 | 1. Pav. Superior | 9. Fachada 1 | Própria |  |  |  |
| 177 | 1.3.4.2.8 | 9.2. Emboço | 1.5d | 2024-10-30 | 2024-10-31 | 110 | 84.5d | 0d | pedreiro [600%]; servente [400%] | 132h | 7,697.26 | 4. Casa 4 | 1. Pav. Superior | 9. Fachada 1 | Própria |  |  |  |
| 178 | 1.3.4.2.9 | 9.3. Pint. 1 Demão | 1d | 2025-01-02 | 2025-01-03 | 111 | 84.5d | 0d | pintor [400%]; aux.pintor [200%] | 52.8h | 1,135.92 | 4. Casa 4 | 1. Pav. Superior | 9. Fachada 1 | Própria |  |  |  |
| 179 | 1.3.4.2.10 | 9.4. Pint. 2 Demão | 2d | 2025-02-24 | 2025-02-26 | 112 | 84.5d | 0d | pintor [400%]; aux.pintor [200%] | 105.6h | 757.28 | 4. Casa 4 | 1. Pav. Superior | 9. Fachada 1 | Própria |  |  |  |
| 180 | 1.3.4.2.11 | 10. Cer. Piso | 4d | 2024-10-17 | 2024-10-22 | 160 | 0d |  | pedreiro [400%]; servente [200%] | 211.2h | 19,807.17 | 4. Casa 4 | 1. Pav. Superior | 10. Cer. Piso 1 | Própria | 10 | 10 | 10 |
| 181 | 1.3.4.2.12 | 11. Cer. Parede | 2d | 2025-01-06 | 2025-01-07 | 161 | 0d |  | pedreiro [400%]; servente [200%] | 105.6h | 4,238.82 | 4. Casa 4 | 1. Pav. Superior | 11. Cer. Parede 1 | Própria | 11 | 11 | 11 |
| 182 | 1.3.4.2.13 | 12. Forro (WC's e cozinha) | 1d | 2025-01-23 | 2025-01-24 | 209SF | 0d |  | aux. gesseiro; gesseiro | 17.6h | 635.82 | 4. Casa 4 | 1. Pav. Superior | 12. Forro (WC's e cozinha) 1 | Própria | 12 | 12 | 12 |
| 183 | 1.3.4.2.14 | 13. Esq. Alumínio | 2d | 2025-02-05 | 2025-02-06 | 163 | 100d | 0d | montador esquadrias | 17.6h | 8,489.61 | 4. Casa 4 | 1. Pav. Superior | 13. Esq. Alumínio 1 | Própria | 13 | 13 | 13 |
| 184 | 1.3.4.2.15 | 14. Portas | 2d | 2025-02-07 | 2025-02-10 | 164 | 0d |  | marceneiro [200%] | 35.2h | 1,858.35 | 4. Casa 4 | 1. Pav. Superior | 14. Portas 1 | Própria | 14 | 14 | 14 |
| 185 | 1.3.4.2.16 | 15. Pintura (1ª Demão) | 4d | 2025-04-23 | 2025-04-28 | 165 | 0d |  | pintor [600%]; aux.pintor [300%] | 316.8h | 3,764.82 | 4. Casa 4 | 1. Pav. Superior | 15. Pintura (1ª Demão) 1 | Própria | 15 | 15 | 15 |
| 186 | 1.3.4.2.17 | 16. Bancadas | 1d | 2025-06-03 | 2025-06-04 | 213SF | 73d | 0d | servente; pedreiro [200%] | 26.4h | 6,972.08 | 4. Casa 4 | 1. Pav. Superior | 16. Bancadas 1 | Própria | 16 | 16 | 16 |
| 187 | 1.3.4.2.18 | 17. Pintura (2ª Demão) | 3d | 2025-07-16 | 2025-07-18 | 167 | 0d |  | aux.pintor [300%]; pintor [600%] | 237.6h | 1,563.98 | 4. Casa 4 | 1. Pav. Superior | 17. Pintura (2ª Demão) 1 | Própria | 17 | 17 | 17 |
| 188 | 1.3.4.2.19 | 18. Limp. Interna | 1d | 2025-08-13 | 2025-08-14 | 215SF | 24d | 0d | Diarista [200%] | 17.6h | 418.75 | 4. Casa 4 | 1. Pav. Superior | 18. Limp. Interna 1 | Própria | 18 | 18 | 18 |

| ID | WBS | Task | Duration | Start | Finish | Predecessors | Total slack | Free slack | Resources | Work | Cost | Casa | Pav | Equipe | Empresa | Pacote | Cor | LB |
| --- | --- | --- | --- | --- | --- | --- | --- | --- | --- | --- | --- | --- | --- | --- | --- | --- | --- | --- |
| 189 | 1.3.4.3 | **2. Coberta** | 112d | 2024-01-30 | 2024-07-17 |  | -2d | 0d |  | 536.8h | 58,163.18 |  |  |  |  |  |  |  |
| 190 | 1.3.4.3.1 | 1. Alvenarias | 3d | 2024-01-30 | 2024-02-01 | 171 | -2d | 0d | pedreiro [400%]; servente [400%] | 211.2h | 9,834.12 | 4. Casa 4 | 2. Coberta | 3. Alvenarias 1 | Própria |  |  |  |
| 191 | 1.3.4.3.2 | 2. Impermeabilização | 1d | 2024-07-16 | 2024-07-17 | 201SF | 292d | 0d | aplicador de manta | 8.8h | 24,164.53 | 4. Casa 4 | 2. Coberta | 7. Impermeabilização 1 | Própria |  |  |  |
| 192 | 1.3.4.3.3 | 3. Coberta | 6d | 2024-03-18 | 2024-03-28 | 239SF | 367d | 0d | carpinteiro [400%]; aux. Carpinteiro [200%] | 316.8h | 24,164.53 | 4. Casa 4 | 2. Coberta | 4. Coberta 1 | Própria |  |  |  |
| 193 | 1.3.5 | **5. Casa 5** | 495d | 2023-08-10 | 2025-08-18 |  | -1d | 0d |  | 7568h | 338,552.33 |  |  |  |  |  |  |  |
| 194 | 1.3.5.1 | **0. Térreo** | 494d | 2023-08-10 | 2025-08-15 |  | -1d | 0d |  | 3801.6h | 165,768.43 |  |  |  |  |  |  |  |
| 195 | 1.3.5.1.1 | 0. Locação | 2d | 2023-08-10 | 2023-08-11 | 148 | -1d | 0d | carpinteiro; aux. Carpinteiro | 35.2h | 456.99 | 5. Casa 5 | 0. Térreo | 0. Locação 1 | Própria |  |  |  |
| 196 | 1.3.5.1.2 | 1. Fundação | 9d | 2023-10-17 | 2023-10-27 | 149 | 747d | 0d | servente estrutura [300%]; aux. Carpinteiro; aux. ferreiro; ferreiro; carpinteiro [200%] | 633.6h | 19,882.86 | 5. Casa 5 | 0. Térreo | 1. Fundação 1 | Própria |  |  |  |
| 197 | 1.3.5.1.3 | 2. Estrutura | 7d | 2024-01-03 | 2024-01-11 | 170 | 367d | 0d | servente estrutura [300%]; aux. Carpinteiro [200%]; aux. ferreiro [200%]; ferreiro [500%]; carpinteiro [200%] | 862.4h | 46,439.03 | 5. Casa 5 | 0. Térreo | 2. Estrutura 1 | Própria |  |  |  |
| 198 | 1.3.5.1.4 | 3. Alvenarias | 5d | 2024-02-02 | 2024-02-08 | 190 | -2d | 0d | pedreiro [400%]; servente [400%] | 352h | 8,388.41 | 5. Casa 5 | 0. Térreo | 3. Alvenarias 1 | Própria |  |  |  |
| 199 | 1.3.5.1.5 | 5. Ref. Inter. Arg (Parede) | 3d | 2024-06-24 | 2024-06-26 | 172 | -2d | 0d | pedreiro [600%]; servente [600%] | 316.8h | 5,776 | 5. Casa 5 | 0. Térreo | 5. Ref. Inter. Arg (Parede) 1 | Própria |  |  |  |
| 200 | 1.3.5.1.6 | 6. Revest. Gesso (Parede + Teto) | 3d | 2024-07-09 | 2024-07-12 | 220SF | 295d | 0d | gesseiro [400%]; aux. gesseiro [200%] | 158.4h | 2,119.41 | 5. Casa 5 | 0. Térreo | 6. Revest. Gesso (Parede + Teto) 1 | Própria |  |  |  |
| 201 | 1.3.5.1.7 | 7. Impermeabilização | 2d | 2024-07-17 | 2024-07-19 | 221SF | 290d | 0d | aplicador de manta | 17.6h | 3,288.15 | 5. Casa 5 | 0. Térreo | 7. Impermeabilização 1 | Própria |  |  |  |
| 202 | 1.3.5.1.8 | 8. Contrapiso | 2d | 2024-07-25 | 2024-07-29 | 269SF | 284d | 0d | pedreiro [200%]; servente | 52.8h | 3,735.07 | 5. Casa 5 | 0. Térreo | 8. Contrapiso 1 | Própria |  |  |  |
| 203 | 1.3.5.1.9 | 9.1. Chapisco | 0.5d | 2024-10-01 | 2024-10-01 | 176 | 84.5d | 0d | pedreiro [600%]; servente [400%] | 44h | 5,131.51 | 5. Casa 5 | 0. Térreo | 9. Fachada 1 | Própria |  |  |  |
| 204 | 1.3.5.1.10 | 9.2. Emboço | 1.5d | 2024-11-05 | 2024-11-06 | 224 | 84.5d | 0d | pedreiro [600%]; servente [400%] | 132h | 7,697.26 | 5. Casa 5 | 0. Térreo | 9. Fachada 1 | Própria |  |  |  |
| 205 | 1.3.5.1.11 | 9.3. Pint. 1 Demão | 1d | 2025-01-07 | 2025-01-08 | 225 | 84.5d | 0d | pintor [400%]; aux.pintor [200%] | 52.8h | 1,135.92 | 5. Casa 5 | 0. Térreo | 9. Fachada 1 | Própria |  |  |  |
| 206 | 1.3.5.1.12 | 9.4. Pint. 2 Demão | 2d | 2025-03-07 | 2025-03-11 | 226 | 84.5d | 0d | pintor [400%]; aux.pintor [200%] | 105.6h | 757.28 | 5. Casa 5 | 0. Térreo | 9. Fachada 1 | Própria |  |  |  |
| 207 | 1.3.5.1.13 | 10. Cer. Piso | 4d | 2024-10-23 | 2024-10-28 | 180 | 0d |  | pedreiro [400%]; servente [200%] | 211.2h | 25,485.98 | 5. Casa 5 | 0. Térreo | 10. Cer. Piso 1 | Própria | 10 | 10 | 10 |
| 208 | 1.3.5.1.14 | 11. Cer. Parede | 3d | 2025-01-08 | 2025-01-10 | 181 | 0d |  | pedreiro [400%]; servente [200%] | 158.4h | 4,238.82 | 5. Casa 5 | 0. Térreo | 11. Cer. Parede 1 | Própria | 11 | 11 | 11 |
| 209 | 1.3.5.1.15 | 12. Forro (WC's e cozinha) | 1d | 2025-01-24 | 2025-01-27 | 229SF | 0d |  | gesseiro; aux. gesseiro | 17.6h | 895 | 5. Casa 5 | 0. Térreo | 12. Forro (WC's e cozinha) 1 | Própria | 12 | 12 | 12 |
| 210 | 1.3.5.1.16 | 13. Esq. Alumínio | 2d | 2025-02-07 | 2025-02-10 | 183 | 100d | 0d | montador esquadrias | 17.6h | 11,307.22 | 5. Casa 5 | 0. Térreo | 13. Esq. Alumínio 1 | Própria | 13 | 13 | 13 |
| 211 | 1.3.5.1.17 | 14. Portas | 2d | 2025-02-11 | 2025-02-12 | 184 | 0d |  | marceneiro [200%] | 35.2h | 2,827.85 | 5. Casa 5 | 0. Térreo | 14. Portas 1 | Própria | 14 | 14 | 14 |
| 212 | 1.3.5.1.18 | 15. Pintura (1ª Demão) | 4d | 2025-04-29 | 2025-05-05 | 185 | 0d |  | pintor [600%]; aux.pintor [300%] | 316.8h | 3,764.82 | 5. Casa 5 | 0. Térreo | 15. Pintura (1ª Demão) 1 | Própria | 15 | 15 | 15 |
| 213 | 1.3.5.1.19 | 16. Bancadas | 1d | 2025-06-04 | 2025-06-05 | 233SF | 72d | 0d | pedreiro [200%]; servente | 26.4h | 10,458.12 | 5. Casa 5 | 0. Térreo | 16. Bancadas 1 | Própria | 16 | 16 | 16 |
| 214 | 1.3.5.1.20 | 17. Pintura (2ª Demão) | 3d | 2025-07-21 | 2025-07-23 | 187 | 0d |  | pintor [600%]; aux.pintor [300%] | 237.6h | 1,563.98 | 5. Casa 5 | 0. Térreo | 17. Pintura (2ª Demão) 1 | Própria | 17 | 17 | 17 |
| 215 | 1.3.5.1.21 | 18. Limp. Interna | 1d | 2025-08-14 | 2025-08-15 | 235SF | 23d | 0d | Diarista [200%] | 17.6h | 418.75 | 5. Casa 5 | 0. Térreo | 18. Limp. Interna 1 | Própria | 18 | 18 | 18 |

| ID | WBS | Task | Duration | Start | Finish | Predecessors | Total slack | Free slack | Resources | Work | Cost | Casa | Pav | Equipe | Empresa | Pacote | Cor | LB |
| --- | --- | --- | --- | --- | --- | --- | --- | --- | --- | --- | --- | --- | --- | --- | --- | --- | --- | --- |
| 216 | 1.3.5.2 | **1. Pav. Superior** | 394d | 2024-01-12 | 2025-08-18 |  | 18d |  |  | 3229.6h | 114,620.72 |  |  |  |  |  |  |  |
| 217 | 1.3.5.2.1 | 2. Estrutura | 7d | 2024-01-12 | 2024-01-22 | 197 | 367d | 0d | servente estrutura [300%]; aux. Carpinteiro [200%]; aux. ferreiro [200%]; ferreiro [500%]; carpinteiro [200%] | 862.4h | 30,006.55 | 5. Casa 5 | 1. Pav. Superior | 2. Estrutura 1 | Própria |  |  |  |
| 218 | 1.3.5.2.2 | 3. Alvenarias | 5d | 2024-02-09 | 2024-02-20 | 198 | -2d | 0d | servente [400%]; pedreiro [400%] | 352h | 10,101.74 | 5. Casa 5 | 1. Pav. Superior | 3. Alvenarias 1 | Própria |  |  |  |
| 219 | 1.3.5.2.3 | 5. Ref. Inter. Arg (Parede) | 4d | 2024-06-27 | 2024-07-02 | 199 | -2d | 0d | pedreiro [600%]; servente [600%] | 422.4h | 5,398.69 | 5. Casa 5 | 1. Pav. Superior | 5. Ref. Inter. Arg (Parede) 1 | Própria |  |  |  |
| 220 | 1.3.5.2.4 | 6. Revest. Gesso (Parede + Teto) | 4d | 2024-07-12 | 2024-07-18 | 247SF | 291d | 0d | aux. gesseiro [200%]; gesseiro [400%] | 211.2h | 2,119.41 | 5. Casa 5 | 1. Pav. Superior | 6. Revest. Gesso (Parede + Teto) 1 | Própria |  |  |  |
| 221 | 1.3.5.2.5 | 7. Impermeabilização | 1d | 2024-07-19 | 2024-07-22 | 238SF | 289d | 0d | aplicador de manta | 8.8h | 2,046.85 | 5. Casa 5 | 1. Pav. Superior | 7. Impermeabilização 1 | Própria |  |  |  |
| 222 | 1.3.5.2.6 | 8. Contrapiso | 2d | 2024-07-23 | 2024-07-25 | 202SF | 286d | 0d | pedreiro [200%]; servente | 52.8h | 2,476.11 | 5. Casa 5 | 1. Pav. Superior | 8. Contrapiso 1 | Própria |  |  |  |
| 223 | 1.3.5.2.7 | 9.1. Chapisco | 0.5d | 2024-10-01 | 2024-10-01 | 203 | 84.5d | 0d | pedreiro [600%]; servente [400%] | 44h | 5,131.51 | 5. Casa 5 | 1. Pav. Superior | 9. Fachada 1 | Própria |  |  |  |
| 224 | 1.3.5.2.8 | 9.2. Emboço | 1.5d | 2024-11-04 | 2024-11-05 | 157 | 84.5d | 0d | pedreiro [600%]; servente [400%] | 132h | 7,697.26 | 5. Casa 5 | 1. Pav. Superior | 9. Fachada 1 | Própria |  |  |  |
| 225 | 1.3.5.2.9 | 9.3. Pint. 1 Demão | 1d | 2025-01-06 | 2025-01-07 | 158 | 84.5d | 0d | pintor [400%]; aux.pintor [200%] | 52.8h | 1,135.92 | 5. Casa 5 | 1. Pav. Superior | 9. Fachada 1 | Própria |  |  |  |
| 226 | 1.3.5.2.10 | 9.4. Pint. 2 Demão | 2d | 2025-02-28 | 2025-03-07 | 159 | 84.5d | 0d | pintor [400%]; aux.pintor [200%] | 105.6h | 757.28 | 5. Casa 5 | 1. Pav. Superior | 9. Fachada 1 | Própria |  |  |  |
| 227 | 1.3.5.2.11 | 10. Cer. Piso | 4d | 2024-10-29 | 2024-11-01 | 207 | 0d |  | servente [200%]; pedreiro [400%] | 211.2h | 19,807.17 | 5. Casa 5 | 1. Pav. Superior | 10. Cer. Piso 1 | Própria | 10 | 10 | 10 |
| 228 | 1.3.5.2.12 | 11. Cer. Parede | 2d | 2025-01-13 | 2025-01-14 | 208 | 0d |  | pedreiro [400%]; servente [200%] | 105.6h | 4,238.82 | 5. Casa 5 | 1. Pav. Superior | 11. Cer. Parede 1 | Própria | 11 | 11 | 11 |
| 229 | 1.3.5.2.13 | 12. Forro (WC's e cozinha) | 1d | 2025-01-27 | 2025-01-28 | 256SF | 0d |  | aux. gesseiro; gesseiro | 17.6h | 635.82 | 5. Casa 5 | 1. Pav. Superior | 12. Forro (WC's e cozinha) 1 | Própria | 12 | 12 | 12 |
| 230 | 1.3.5.2.14 | 13. Esq. Alumínio | 2d | 2025-02-11 | 2025-02-12 | 210 | 100d | 0d | montador esquadrias | 17.6h | 8,489.61 | 5. Casa 5 | 1. Pav. Superior | 13. Esq. Alumínio 1 | Própria | 13 | 13 | 13 |
| 231 | 1.3.5.2.15 | 14. Portas | 2d | 2025-02-13 | 2025-02-14 | 211 | 0d |  | marceneiro [200%] | 35.2h | 1,858.35 | 5. Casa 5 | 1. Pav. Superior | 14. Portas 1 | Própria | 14 | 14 | 14 |
| 232 | 1.3.5.2.16 | 15. Pintura (1ª Demão) | 4d | 2025-05-06 | 2025-05-09 | 212 | 0d |  | pintor [600%]; aux.pintor [300%] | 316.8h | 3,764.82 | 5. Casa 5 | 1. Pav. Superior | 15. Pintura (1ª Demão) 1 | Própria | 15 | 15 | 15 |
| 233 | 1.3.5.2.17 | 16. Bancadas | 1d | 2025-06-05 | 2025-06-06 | 260SF | 71d | 0d | servente; pedreiro [200%] | 26.4h | 6,972.08 | 5. Casa 5 | 1. Pav. Superior | 16. Bancadas 1 | Própria | 16 | 16 | 16 |
| 234 | 1.3.5.2.18 | 17. Pintura (2ª Demão) | 3d | 2025-07-24 | 2025-07-28 | 214 | 0d |  | aux.pintor [300%]; pintor [600%] | 237.6h | 1,563.98 | 5. Casa 5 | 1. Pav. Superior | 17. Pintura (2ª Demão) 1 | Própria | 17 | 17 | 17 |
| 235 | 1.3.5.2.19 | 18. Limp. Interna | 1d | 2025-08-15 | 2025-08-18 | 262SF | 22d | 0d | Diarista [200%] | 17.6h | 418.75 | 5. Casa 5 | 1. Pav. Superior | 18. Limp. Interna 1 | Própria | 18 | 18 | 18 |
| 236 | 1.3.5.3 | **2. Coberta** | 103d | 2024-02-21 | 2024-07-23 |  | -2d | 0d |  | 536.8h | 58,163.18 |  |  |  |  |  |  |  |
| 237 | 1.3.5.3.1 | 1. Alvenarias | 3d | 2024-02-21 | 2024-02-23 | 218 | -2d | 0d | pedreiro [400%]; servente [400%] | 211.2h | 9,834.12 | 5. Casa 5 | 2. Coberta | 3. Alvenarias 1 | Própria |  |  |  |
| 238 | 1.3.5.3.2 | 2. Impermeabilização | 1d | 2024-07-22 | 2024-07-23 | 248SF | 288d | 0d | aplicador de manta | 8.8h | 24,164.53 | 5. Casa 5 | 2. Coberta | 7. Impermeabilização 1 | Própria |  |  |  |
| 239 | 1.3.5.3.3 | 3. Coberta | 6d | 2024-03-28 | 2024-04-08 | 286SF | 361d | 0d | carpinteiro [400%]; aux. Carpinteiro [200%] | 316.8h | 24,164.53 | 5. Casa 5 | 2. Coberta | 4. Coberta 1 | Própria |  |  |  |

| ID | WBS | Task | Duration | Start | Finish | Predecessors | Total slack | Free slack | Resources | Work | Cost | Casa | Pav | Equipe | Empresa | Pacote | Cor | LB |
| --- | --- | --- | --- | --- | --- | --- | --- | --- | --- | --- | --- | --- | --- | --- | --- | --- | --- | --- |
| 240 | 1.3.6 | **6. Casa 6** | 495d | 2023-08-14 | 2025-08-20 |  | -1d | 0d |  | 7568h | 338,552.33 |  |  |  |  |  |  |  |
| 241 | 1.3.6.1 | **0. Térreo** | 494d | 2023-08-14 | 2025-08-19 |  | -1d | 0d |  | 3801.6h | 165,509.25 |  |  |  |  |  |  |  |
| 242 | 1.3.6.1.1 | 0. Locação | 2d | 2023-08-14 | 2023-08-15 | 195 | -1d | 0d | carpinteiro; aux. Carpinteiro | 35.2h | 456.99 | 6. Casa 6 | 0. Térreo | 0. Locação 1 | Própria |  |  |  |
| 243 | 1.3.6.1.2 | 1. Fundação | 9d | 2023-10-30 | 2023-11-10 | 196 | 747d | 0d | servente estrutura [300%]; aux. Carpinteiro; aux. ferreiro; ferreiro; carpinteiro [200%] | 633.6h | 19,882.86 | 6. Casa 6 | 0. Térreo | 1. Fundação 1 | Própria |  |  |  |
| 244 | 1.3.6.1.3 | 2. Estrutura | 7d | 2024-01-23 | 2024-01-31 | 217 | 367d | 0d | servente estrutura [300%]; aux. Carpinteiro [200%]; aux. ferreiro [200%]; ferreiro [500%]; carpinteiro [200%] | 862.4h | 46,439.03 | 6. Casa 6 | 0. Térreo | 2. Estrutura 1 | Própria |  |  |  |
| 245 | 1.3.6.1.4 | 3. Alvenarias | 5d | 2024-02-26 | 2024-03-01 | 237 | -2d | 0d | pedreiro [400%]; servente [400%] | 352h | 8,388.41 | 6. Casa 6 | 0. Térreo | 3. Alvenarias 1 | Própria |  |  |  |
| 246 | 1.3.6.1.5 | 5. Ref. Inter. Arg (Parede) | 3d | 2024-07-03 | 2024-07-05 | 219 | -2d | 0d | pedreiro [600%]; servente [600%] | 316.8h | 5,776 | 6. Casa 6 | 0. Térreo | 5. Ref. Inter. Arg (Parede) 1 | Própria |  |  |  |
| 247 | 1.3.6.1.6 | 6. Revest. Gesso (Parede + Teto) | 3d | 2024-07-18 | 2024-07-23 | 267SF | 288d | 0d | gesseiro [400%]; aux. gesseiro [200%] | 158.4h | 2,119.41 | 6. Casa 6 | 0. Térreo | 6. Revest. Gesso (Parede + Teto) 1 | Própria |  |  |  |
| 248 | 1.3.6.1.7 | 7. Impermeabilização | 2d | 2024-07-23 | 2024-07-25 | 268SF | 286d | 0d | aplicador de manta | 17.6h | 3,288.15 | 6. Casa 6 | 0. Térreo | 7. Impermeabilização 1 | Própria |  |  |  |
| 249 | 1.3.6.1.8 | 8. Contrapiso | 2d | 2024-07-31 | 2024-08-02 | 316SF | 280d | 0d | pedreiro [200%]; servente | 52.8h | 3,735.07 | 6. Casa 6 | 0. Térreo | 8. Contrapiso 1 | Própria |  |  |  |
| 250 | 1.3.6.1.9 | 9.1. Chapisco | 0.5d | 2024-10-02 | 2024-10-02 | 223 | 84.5d | 0d | pedreiro [600%]; servente [400%] | 44h | 5,131.51 | 6. Casa 6 | 0. Térreo | 9. Fachada 1 | Própria |  |  |  |
| 251 | 1.3.6.1.10 | 9.2. Emboço | 1.5d | 2024-11-08 | 2024-11-11 | 271 | 84.5d | 0d | pedreiro [600%]; servente [400%] | 132h | 7,697.26 | 6. Casa 6 | 0. Térreo | 9. Fachada 1 | Própria |  |  |  |
| 252 | 1.3.6.1.11 | 9.3. Pint. 1 Demão | 1d | 2025-01-09 | 2025-01-10 | 272 | 84.5d | 0d | pintor [400%]; aux.pintor [200%] | 52.8h | 1,135.92 | 6. Casa 6 | 0. Térreo | 9. Fachada 1 | Própria |  |  |  |
| 253 | 1.3.6.1.12 | 9.4. Pint. 2 Demão | 2d | 2025-03-13 | 2025-03-17 | 273 | 84.5d | 0d | pintor [400%]; aux.pintor [200%] | 105.6h | 757.28 | 6. Casa 6 | 0. Térreo | 9. Fachada 1 | Própria |  |  |  |
| 254 | 1.3.6.1.13 | 10. Cer. Piso | 4d | 2024-11-04 | 2024-11-07 | 227 | 0d |  | pedreiro [400%]; servente [200%] | 211.2h | 25,485.98 | 6. Casa 6 | 0. Térreo | 10. Cer. Piso 1 | Própria | 10 | 10 | 10 |
| 255 | 1.3.6.1.14 | 11. Cer. Parede | 3d | 2025-01-15 | 2025-01-17 | 228 | 0d |  | pedreiro [400%]; servente [200%] | 158.4h | 4,238.82 | 6. Casa 6 | 0. Térreo | 11. Cer. Parede 1 | Própria | 11 | 11 | 11 |
| 256 | 1.3.6.1.15 | 12. Forro (WC's e cozinha) | 1d | 2025-01-28 | 2025-01-29 | 276SF | 0d |  | gesseiro; aux. gesseiro | 17.6h | 635.82 | 6. Casa 6 | 0. Térreo | 12. Forro (WC's e cozinha) 1 | Própria | 12 | 12 | 12 |
| 257 | 1.3.6.1.16 | 13. Esq. Alumínio | 2d | 2025-02-13 | 2025-02-14 | 230 | 100d | 0d | montador esquadrias | 17.6h | 11,307.22 | 6. Casa 6 | 0. Térreo | 13. Esq. Alumínio 1 | Própria | 13 | 13 | 13 |
| 258 | 1.3.6.1.17 | 14. Portas | 2d | 2025-02-17 | 2025-02-18 | 231 | 0d |  | marceneiro [200%] | 35.2h | 2,827.85 | 6. Casa 6 | 0. Térreo | 14. Portas 1 | Própria | 14 | 14 | 14 |
| 259 | 1.3.6.1.18 | 15. Pintura (1ª Demão) | 4d | 2025-05-12 | 2025-05-15 | 232 | 0d |  | pintor [600%]; aux.pintor [300%] | 316.8h | 3,764.82 | 6. Casa 6 | 0. Térreo | 15. Pintura (1ª Demão) 1 | Própria | 15 | 15 | 15 |
| 260 | 1.3.6.1.19 | 16. Bancadas | 1d | 2025-06-06 | 2025-06-09 | 280SF | 70d | 0d | pedreiro [200%]; servente | 26.4h | 10,458.12 | 6. Casa 6 | 0. Térreo | 16. Bancadas 1 | Própria | 16 | 16 | 16 |
| 261 | 1.3.6.1.20 | 17. Pintura (2ª Demão) | 3d | 2025-07-29 | 2025-07-31 | 234 | 0d |  | pintor [600%]; aux.pintor [300%] | 237.6h | 1,563.98 | 6. Casa 6 | 0. Térreo | 17. Pintura (2ª Demão) 1 | Própria | 17 | 17 | 17 |
| 262 | 1.3.6.1.21 | 18. Limp. Interna | 1d | 2025-08-18 | 2025-08-19 | 282SF | 21d | 0d | Diarista [200%] | 17.6h | 418.75 | 6. Casa 6 | 0. Térreo | 18. Limp. Interna 1 | Própria | 18 | 18 | 18 |
| 263 | 1.3.6.2 | **1. Pav. Superior** | 382d | 2024-02-01 | 2025-08-20 |  | 17d |  |  | 3229.6h | 114,879.9 |  |  |  |  |  |  |  |
| 264 | 1.3.6.2.1 | 2. Estrutura | 7d | 2024-02-01 | 2024-02-09 | 244 | 367d | 0d | servente estrutura [300%]; aux. Carpinteiro [200%]; aux. ferreiro [200%]; ferreiro [500%]; carpinteiro [200%] | 862.4h | 30,006.55 | 6. Casa 6 | 1. Pav. Superior | 2. Estrutura 1 | Própria |  |  |  |
| 265 | 1.3.6.2.2 | 3. Alvenarias | 5d | 2024-03-04 | 2024-03-08 | 245 | -2d | 0d | servente [400%]; pedreiro [400%] | 352h | 10,101.74 | 6. Casa 6 | 1. Pav. Superior | 3. Alvenarias 1 | Própria |  |  |  |
| 266 | 1.3.6.2.3 | 5. Ref. Inter. Arg (Parede) | 4d | 2024-07-08 | 2024-07-11 | 246 | -2d | 0d | pedreiro [600%]; servente [600%] | 422.4h | 5,398.69 | 6. Casa 6 | 1. Pav. Superior | 5. Ref. Inter. Arg (Parede) 1 | Própria |  |  |  |
| 267 | 1.3.6.2.4 | 6. Revest. Gesso (Parede + Teto) | 4d | 2024-07-23 | 2024-07-29 | 294SF | 284d | 0d | aux. gesseiro [200%]; gesseiro [400%] | 211.2h | 2,119.41 | 6. Casa 6 | 1. Pav. Superior | 6. Revest. Gesso (Parede + Teto) 1 | Própria |  |  |  |
| 268 | 1.3.6.2.5 | 7. Impermeabilização | 1d | 2024-07-25 | 2024-07-26 | 285SF | 285d | 0d | aplicador de manta | 8.8h | 2,046.85 | 6. Casa 6 | 1. Pav. Superior | 7. Impermeabilização 1 | Própria |  |  |  |
| 269 | 1.3.6.2.6 | 8. Contrapiso | 2d | 2024-07-29 | 2024-07-31 | 249SF | 282d | 0d | pedreiro [200%]; servente | 52.8h | 2,476.11 | 6. Casa 6 | 1. Pav. Superior | 8. Contrapiso 1 | Própria |  |  |  |
| 270 | 1.3.6.2.7 | 9.1. Chapisco | 0.5d | 2024-10-02 | 2024-10-02 | 250 | 84.5d | 0d | pedreiro [600%]; servente [400%] | 44h | 5,131.51 | 6. Casa 6 | 1. Pav. Superior | 9. Fachada 1 | Própria |  |  |  |
| 271 | 1.3.6.2.8 | 9.2. Emboço | 1.5d | 2024-11-07 | 2024-11-08 | 204 | 84.5d | 0d | pedreiro [600%]; servente [400%] | 132h | 7,697.26 | 6. Casa 6 | 1. Pav. Superior | 9. Fachada 1 | Própria |  |  |  |
| 272 | 1.3.6.2.9 | 9.3. Pint. 1 Demão | 1d | 2025-01-08 | 2025-01-09 | 205 | 84.5d | 0d | pintor [400%]; aux.pintor [200%] | 52.8h | 1,135.92 | 6. Casa 6 | 1. Pav. Superior | 9. Fachada 1 | Própria |  |  |  |
| 273 | 1.3.6.2.10 | 9.4. Pint. 2 Demão | 2d | 2025-03-11 | 2025-03-13 | 206 | 84.5d | 0d | pintor [400%]; aux.pintor [200%] | 105.6h | 757.28 | 6. Casa 6 | 1. Pav. Superior | 9. Fachada 1 | Própria |  |  |  |
| 274 | 1.3.6.2.11 | 10. Cer. Piso | 4d | 2024-11-08 | 2024-11-13 | 254 | 0d |  | pedreiro [400%]; servente [200%] | 211.2h | 19,807.17 | 6. Casa 6 | 1. Pav. Superior | 10. Cer. Piso 1 | Própria | 10 | 10 | 10 |
| 275 | 1.3.6.2.12 | 11. Cer. Parede | 2d | 2025-01-20 | 2025-01-21 | 255 | 0d |  | pedreiro [400%]; servente [200%] | 105.6h | 4,238.82 | 6. Casa 6 | 1. Pav. Superior | 11. Cer. Parede 1 | Própria | 11 | 11 | 11 |
| 276 | 1.3.6.2.13 | 12. Forro (WC's e cozinha) | 1d | 2025-01-29 | 2025-01-30 | 303SF | 0d |  | aux. gesseiro; gesseiro | 17.6h | 895 | 6. Casa 6 | 1. Pav. Superior | 12. Forro (WC's e cozinha) 1 | Própria | 12 | 12 | 12 |
| 277 | 1.3.6.2.14 | 13. Esq. Alumínio | 2d | 2025-02-17 | 2025-02-18 | 257 | 100d | 0d | montador esquadrias | 17.6h | 8,489.61 | 6. Casa 6 | 1. Pav. Superior | 13. Esq. Alumínio 1 | Própria | 13 | 13 | 13 |
| 278 | 1.3.6.2.15 | 14. Portas | 2d | 2025-02-19 | 2025-02-20 | 258 | 0d |  | marceneiro [200%] | 35.2h | 1,858.35 | 6. Casa 6 | 1. Pav. Superior | 14. Portas 1 | Própria | 14 | 14 | 14 |
| 279 | 1.3.6.2.16 | 15. Pintura (1ª Demão) | 4d | 2025-05-16 | 2025-05-21 | 259 | 0d |  | pintor [600%]; aux.pintor [300%] | 316.8h | 3,764.82 | 6. Casa 6 | 1. Pav. Superior | 15. Pintura (1ª Demão) 1 | Própria | 15 | 15 | 15 |
| 280 | 1.3.6.2.17 | 16. Bancadas | 1d | 2025-06-09 | 2025-06-10 | 307SF | 69d | 0d | servente; pedreiro [200%] | 26.4h | 6,972.08 | 6. Casa 6 | 1. Pav. Superior | 16. Bancadas 1 | Própria | 16 | 16 | 16 |
| 281 | 1.3.6.2.18 | 17. Pintura (2ª Demão) | 3d | 2025-08-01 | 2025-08-05 | 261 | 0d |  | aux.pintor [300%]; pintor [600%] | 237.6h | 1,563.98 | 6. Casa 6 | 1. Pav. Superior | 17. Pintura (2ª Demão) 1 | Própria | 17 | 17 | 17 |
| 282 | 1.3.6.2.19 | 18. Limp. Interna | 1d | 2025-08-19 | 2025-08-20 | 309SF | 20d | 0d | Diarista [200%] | 17.6h | 418.75 | 6. Casa 6 | 1. Pav. Superior | 18. Limp. Interna 1 | Própria | 18 | 18 | 18 |

| ID | WBS | Task | Duration | Start | Finish | Predecessors | Total slack | Free slack | Resources | Work | Cost | Casa | Pav | Equipe | Empresa | Pacote | Cor | LB |
| --- | --- | --- | --- | --- | --- | --- | --- | --- | --- | --- | --- | --- | --- | --- | --- | --- | --- | --- |
| 283 | 1.3.6.3 | **2. Coberta** | 94d | 2024-03-11 | 2024-07-29 |  | -2d | 0d |  | 536.8h | 58,163.18 |  |  |  |  |  |  |  |
| 284 | 1.3.6.3.1 | 1. Alvenarias | 3d | 2024-03-11 | 2024-03-13 | 265 | -2d | 0d | pedreiro [400%]; servente [400%] | 211.2h | 9,834.12 | 6. Casa 6 | 2. Coberta | 3. Alvenarias 1 | Própria |  |  |  |
| 285 | 1.3.6.3.2 | 2. Impermeabilização | 1d | 2024-07-26 | 2024-07-29 | 295SF | 284d | 0d | aplicador de manta | 8.8h | 24,164.53 | 6. Casa 6 | 2. Coberta | 7. Impermeabilização 1 | Própria |  |  |  |
| 286 | 1.3.6.3.3 | 3. Coberta | 6d | 2024-04-08 | 2024-04-16 | 333SF | 355d | 0d | carpinteiro [400%]; aux. Carpinteiro [200%] | 316.8h | 24,164.53 | 6. Casa 6 | 2. Coberta | 4. Coberta 1 | Própria |  |  |  |
| 287 | 1.3.7 | **7. Casa 7** | 495d | 2023-08-16 | 2025-08-22 |  | -1d | 0d |  | 7568h | 338,552.33 |  |  |  |  |  |  |  |
| 288 | 1.3.7.1 | **0. Térreo** | 494d | 2023-08-16 | 2025-08-21 |  | -1d | 0d |  | 3801.6h | 165,509.25 |  |  |  |  |  |  |  |
| 289 | 1.3.7.1.1 | 0. Locação | 2d | 2023-08-16 | 2023-08-17 | 242 | -1d | 0d | carpinteiro; aux. Carpinteiro | 35.2h | 456.99 | 7. Casa 7 | 0. Térreo | 0. Locação 1 | Própria |  |  |  |
| 290 | 1.3.7.1.2 | 1. Fundação | 9d | 2023-11-13 | 2023-11-24 | 243 | 747d | 0d | servente estrutura [300%]; aux. Carpinteiro; aux. ferreiro; ferreiro; carpinteiro [200%] | 633.6h | 19,882.86 | 7. Casa 7 | 0. Térreo | 1. Fundação 1 | Própria |  |  |  |
| 291 | 1.3.7.1.3 | 2. Estrutura | 7d | 2024-02-15 | 2024-02-23 | 264 | 367d | 0d | servente estrutura [300%]; aux. Carpinteiro [200%]; aux. ferreiro [200%]; ferreiro [500%]; carpinteiro [200%] | 862.4h | 46,439.03 | 7. Casa 7 | 0. Térreo | 2. Estrutura 1 | Própria |  |  |  |
| 292 | 1.3.7.1.4 | 3. Alvenarias | 5d | 2024-03-14 | 2024-03-21 | 284 | -2d | 0d | pedreiro [400%]; servente [400%] | 352h | 8,388.41 | 7. Casa 7 | 0. Térreo | 3. Alvenarias 1 | Própria |  |  |  |
| 293 | 1.3.7.1.5 | 5. Ref. Inter. Arg (Parede) | 3d | 2024-07-12 | 2024-07-16 | 266 | -2d | 0d | pedreiro [600%]; servente [600%] | 316.8h | 5,776 | 7. Casa 7 | 0. Térreo | 5. Ref. Inter. Arg (Parede) 1 | Própria |  |  |  |
| 294 | 1.3.7.1.6 | 6. Revest. Gesso (Parede + Teto) | 3d | 2024-07-29 | 2024-08-01 | 314SF | 281d | 0d | gesseiro [400%]; aux. gesseiro [200%] | 158.4h | 2,119.41 | 7. Casa 7 | 0. Térreo | 6. Revest. Gesso (Parede + Teto) 1 | Própria |  |  |  |
| 295 | 1.3.7.1.7 | 7. Impermeabilização | 2d | 2024-07-29 | 2024-07-31 | 315SF | 282d | 0d | aplicador de manta | 17.6h | 3,288.15 | 7. Casa 7 | 0. Térreo | 7. Impermeabilização 1 | Própria |  |  |  |
| 296 | 1.3.7.1.8 | 8. Contrapiso | 2d | 2024-08-06 | 2024-08-08 | 363SF | 276d | 0d | pedreiro [200%]; servente | 52.8h | 3,735.07 | 7. Casa 7 | 0. Térreo | 8. Contrapiso 1 | Própria |  |  |  |
| 297 | 1.3.7.1.9 | 9.1. Chapisco | 0.5d | 2024-10-03 | 2024-10-03 | 270 | 84.5d | 0d | pedreiro [600%]; servente [400%] | 44h | 5,131.51 | 7. Casa 7 | 0. Térreo | 9. Fachada 1 | Própria |  |  |  |
| 298 | 1.3.7.1.10 | 9.2. Emboço | 1.5d | 2024-11-13 | 2024-11-14 | 318 | 84.5d | 0d | pedreiro [600%]; servente [400%] | 132h | 7,697.26 | 7. Casa 7 | 0. Térreo | 9. Fachada 1 | Própria |  |  |  |
| 299 | 1.3.7.1.11 | 9.3. Pint. 1 Demão | 1d | 2025-01-13 | 2025-01-14 | 319 | 84.5d | 0d | pintor [400%]; aux.pintor [200%] | 52.8h | 1,135.92 | 7. Casa 7 | 0. Térreo | 9. Fachada 1 | Própria |  |  |  |
| 300 | 1.3.7.1.12 | 9.4. Pint. 2 Demão | 2d | 2025-03-20 | 2025-03-24 | 320 | 84.5d | 0d | pintor [400%]; aux.pintor [200%] | 105.6h | 757.28 | 7. Casa 7 | 0. Térreo | 9. Fachada 1 | Própria |  |  |  |
| 301 | 1.3.7.1.13 | 10. Cer. Piso | 4d | 2024-11-14 | 2024-11-20 | 274 | 0d |  | pedreiro [400%]; servente [200%] | 211.2h | 25,485.98 | 7. Casa 7 | 0. Térreo | 10. Cer. Piso 1 | Própria | 10 | 10 | 10 |
| 302 | 1.3.7.1.14 | 11. Cer. Parede | 3d | 2025-01-22 | 2025-01-24 | 275 | 0d |  | pedreiro [400%]; servente [200%] | 158.4h | 4,238.82 | 7. Casa 7 | 0. Térreo | 11. Cer. Parede 1 | Própria | 11 | 11 | 11 |
| 303 | 1.3.7.1.15 | 12. Forro (WC's e cozinha) | 1d | 2025-01-30 | 2025-01-31 | 323SF | 0d |  | gesseiro; aux. gesseiro | 17.6h | 635.82 | 7. Casa 7 | 0. Térreo | 12. Forro (WC's e cozinha) 1 | Própria | 12 | 12 | 12 |
| 304 | 1.3.7.1.16 | 13. Esq. Alumínio | 2d | 2025-02-19 | 2025-02-20 | 277 | 100d | 0d | montador esquadrias | 17.6h | 11,307.22 | 7. Casa 7 | 0. Térreo | 13. Esq. Alumínio 1 | Própria | 13 | 13 | 13 |
| 305 | 1.3.7.1.17 | 14. Portas | 2d | 2025-02-21 | 2025-02-24 | 278 | 0d |  | marceneiro [200%] | 35.2h | 2,827.85 | 7. Casa 7 | 0. Térreo | 14. Portas 1 | Própria | 14 | 14 | 14 |
| 306 | 1.3.7.1.18 | 15. Pintura (1ª Demão) | 4d | 2025-05-22 | 2025-05-27 | 279 | 0d |  | pintor [600%]; aux.pintor [300%] | 316.8h | 3,764.82 | 7. Casa 7 | 0. Térreo | 15. Pintura (1ª Demão) 1 | Própria | 15 | 15 | 15 |
| 307 | 1.3.7.1.19 | 16. Bancadas | 1d | 2025-06-10 | 2025-06-11 | 327SF | 68d | 0d | pedreiro [200%]; servente | 26.4h | 10,458.12 | 7. Casa 7 | 0. Térreo | 16. Bancadas 1 | Própria | 16 | 16 | 16 |
| 308 | 1.3.7.1.20 | 17. Pintura (2ª Demão) | 3d | 2025-08-06 | 2025-08-08 | 281 | 0d |  | pintor [600%]; aux.pintor [300%] | 237.6h | 1,563.98 | 7. Casa 7 | 0. Térreo | 17. Pintura (2ª Demão) 1 | Própria | 17 | 17 | 17 |
| 309 | 1.3.7.1.21 | 18. Limp. Interna | 1d | 2025-08-20 | 2025-08-21 | 329SF | 19d | 0d | Diarista [200%] | 17.6h | 418.75 | 7. Casa 7 | 0. Térreo | 18. Limp. Interna 1 | Própria | 18 | 18 | 18 |

| ID | WBS | Task | Duration | Start | Finish | Predecessors | Total slack | Free slack | Resources | Work | Cost | Casa | Pav | Equipe | Empresa | Pacote | Cor | LB |
| --- | --- | --- | --- | --- | --- | --- | --- | --- | --- | --- | --- | --- | --- | --- | --- | --- | --- | --- |
| 310 | 1.3.7.2 | **1. Pav. Superior** | 370d | 2024-02-26 | 2025-08-22 |  | 16d |  |  | 3229.6h | 114,879.9 |  |  |  |  |  |  |  |
| 311 | 1.3.7.2.1 | 2. Estrutura | 7d | 2024-02-26 | 2024-03-05 | 291 | 367d | 0d | servente estrutura [300%]; aux. Carpinteiro [200%]; aux. ferreiro [200%]; ferreiro [500%]; carpinteiro [200%] | 862.4h | 30,006.55 | 7. Casa 7 | 1. Pav. Superior | 2. Estrutura 1 | Própria |  |  |  |
| 312 | 1.3.7.2.2 | 3. Alvenarias | 5d | 2024-03-22 | 2024-04-01 | 292 | -2d | 0d | servente [400%]; pedreiro [400%] | 352h | 10,101.74 | 7. Casa 7 | 1. Pav. Superior | 3. Alvenarias 1 | Própria |  |  |  |
| 313 | 1.3.7.2.3 | 5. Ref. Inter. Arg (Parede) | 4d | 2024-07-17 | 2024-07-22 | 293 | -2d | 0d | pedreiro [600%]; servente [600%] | 422.4h | 5,398.69 | 7. Casa 7 | 1. Pav. Superior | 5. Ref. Inter. Arg (Parede) 1 | Própria |  |  |  |
| 314 | 1.3.7.2.4 | 6. Revest. Gesso (Parede + Teto) | 4d | 2024-08-01 | 2024-08-07 | 341SF | 277d | 0d | aux. gesseiro [200%]; gesseiro [400%] | 211.2h | 2,119.41 | 7. Casa 7 | 1. Pav. Superior | 6. Revest. Gesso (Parede + Teto) 1 | Própria |  |  |  |
| 315 | 1.3.7.2.5 | 7. Impermeabilização | 1d | 2024-07-31 | 2024-08-01 | 332SF | 281d | 0d | aplicador de manta | 8.8h | 2,046.85 | 7. Casa 7 | 1. Pav. Superior | 7. Impermeabilização 1 | Própria |  |  |  |
| 316 | 1.3.7.2.6 | 8. Contrapiso | 2d | 2024-08-02 | 2024-08-06 | 296SF | 278d | 0d | pedreiro [200%]; servente | 52.8h | 2,476.11 | 7. Casa 7 | 1. Pav. Superior | 8. Contrapiso 1 | Própria |  |  |  |
| 317 | 1.3.7.2.7 | 9.1. Chapisco | 0.5d | 2024-10-03 | 2024-10-03 | 297 | 84.5d | 0d | pedreiro [600%]; servente [400%] | 44h | 5,131.51 | 7. Casa 7 | 1. Pav. Superior | 9. Fachada 1 | Própria |  |  |  |
| 318 | 1.3.7.2.8 | 9.2. Emboço | 1.5d | 2024-11-12 | 2024-11-13 | 251 | 84.5d | 0d | pedreiro [600%]; servente [400%] | 132h | 7,697.26 | 7. Casa 7 | 1. Pav. Superior | 9. Fachada 1 | Própria |  |  |  |
| 319 | 1.3.7.2.9 | 9.3. Pint. 1 Demão | 1d | 2025-01-10 | 2025-01-13 | 252 | 84.5d | 0d | pintor [400%]; aux.pintor [200%] | 52.8h | 1,135.92 | 7. Casa 7 | 1. Pav. Superior | 9. Fachada 1 | Própria |  |  |  |
| 320 | 1.3.7.2.10 | 9.4. Pint. 2 Demão | 2d | 2025-03-17 | 2025-03-20 | 253 | 84.5d | 0d | pintor [400%]; aux.pintor [200%] | 105.6h | 757.28 | 7. Casa 7 | 1. Pav. Superior | 9. Fachada 1 | Própria |  |  |  |
| 321 | 1.3.7.2.11 | 10. Cer. Piso | 4d | 2024-11-21 | 2024-11-26 | 301 | 0d |  | servente [200%]; pedreiro [400%] | 211.2h | 19,807.17 | 7. Casa 7 | 1. Pav. Superior | 10. Cer. Piso 1 | Própria | 10 | 10 | 10 |
| 322 | 1.3.7.2.12 | 11. Cer. Parede | 2d | 2025-01-27 | 2025-01-28 | 302 | 0d |  | pedreiro [400%]; servente [200%] | 105.6h | 4,238.82 | 7. Casa 7 | 1. Pav. Superior | 11. Cer. Parede 1 | Própria | 11 | 11 | 11 |
| 323 | 1.3.7.2.13 | 12. Forro (WC's e cozinha) | 1d | 2025-01-31 | 2025-02-03 | 350SF | 0d |  | aux. gesseiro; gesseiro | 17.6h | 895 | 7. Casa 7 | 1. Pav. Superior | 12. Forro (WC's e cozinha) 1 | Própria | 12 | 12 | 12 |
| 324 | 1.3.7.2.14 | 13. Esq. Alumínio | 2d | 2025-02-21 | 2025-02-24 | 304 | 100d | 0d | montador esquadrias | 17.6h | 8,489.61 | 7. Casa 7 | 1. Pav. Superior | 13. Esq. Alumínio 1 | Própria | 13 | 13 | 13 |
| 325 | 1.3.7.2.15 | 14. Portas | 2d | 2025-02-25 | 2025-02-26 | 305 | 0d |  | marceneiro [200%] | 35.2h | 1,858.35 | 7. Casa 7 | 1. Pav. Superior | 14. Portas 1 | Própria | 14 | 14 | 14 |
| 326 | 1.3.7.2.16 | 15. Pintura (1ª Demão) | 4d | 2025-05-28 | 2025-06-02 | 306 | 0d |  | pintor [600%]; aux.pintor [300%] | 316.8h | 3,764.82 | 7. Casa 7 | 1. Pav. Superior | 15. Pintura (1ª Demão) 1 | Própria | 15 | 15 | 15 |
| 327 | 1.3.7.2.17 | 16. Bancadas | 1d | 2025-06-11 | 2025-06-12 | 354SF | 67d | 0d | servente; pedreiro [200%] | 26.4h | 6,972.08 | 7. Casa 7 | 1. Pav. Superior | 16. Bancadas 1 | Própria | 16 | 16 | 16 |
| 328 | 1.3.7.2.18 | 17. Pintura (2ª Demão) | 3d | 2025-08-11 | 2025-08-13 | 308 | 0d |  | aux.pintor [300%]; pintor [600%] | 237.6h | 1,563.98 | 7. Casa 7 | 1. Pav. Superior | 17. Pintura (2ª Demão) 1 | Própria | 17 | 17 | 17 |
| 329 | 1.3.7.2.19 | 18. Limp. Interna | 1d | 2025-08-21 | 2025-08-22 | 356SF | 18d | 0d | Diarista [200%] | 17.6h | 418.75 | 7. Casa 7 | 1. Pav. Superior | 18. Limp. Interna 1 | Própria | 18 | 18 | 18 |
| 330 | 1.3.7.3 | **2. Coberta** | 85d | 2024-04-02 | 2024-08-02 |  | -2d | 0d |  | 536.8h | 58,163.18 |  |  |  |  |  |  |  |
| 331 | 1.3.7.3.1 | 1. Alvenarias | 3d | 2024-04-02 | 2024-04-04 | 312 | -2d | 0d | pedreiro [400%]; servente [400%] | 211.2h | 9,834.12 | 7. Casa 7 | 2. Coberta | 3. Alvenarias 1 | Própria |  |  |  |
| 332 | 1.3.7.3.2 | 2. Impermeabilização | 1d | 2024-08-01 | 2024-08-02 | 342SF | 280d | 0d | aplicador de manta | 8.8h | 24,164.53 | 7. Casa 7 | 2. Coberta | 7. Impermeabilização 1 | Própria |  |  |  |
| 333 | 1.3.7.3.3 | 3. Coberta | 6d | 2024-04-16 | 2024-04-24 | 380SF | 349d | 0d | carpinteiro [400%]; aux. Carpinteiro [200%] | 316.8h | 24,164.53 | 7. Casa 7 | 2. Coberta | 4. Coberta 1 | Própria |  |  |  |

| ID | WBS | Task | Duration | Start | Finish | Predecessors | Total slack | Free slack | Resources | Work | Cost | Casa | Pav | Equipe | Empresa | Pacote | Cor | LB |
| --- | --- | --- | --- | --- | --- | --- | --- | --- | --- | --- | --- | --- | --- | --- | --- | --- | --- | --- |
| 334 | 1.3.8 | **8. Casa 8** | 495d | 2023-08-18 | 2025-08-25 |  | -1d | 0d |  | 7568h | 338,552.33 |  |  |  |  |  |  |  |
| 335 | 1.3.8.1 | **0. Térreo** | 494d | 2023-08-18 | 2025-08-22 |  | -1d | 0d |  | 3801.6h | 165,509.25 |  |  |  |  |  |  |  |
| 336 | 1.3.8.1.1 | 0. Locação | 2d | 2023-08-18 | 2023-08-21 | 289 | -1d | 0d | carpinteiro; aux. Carpinteiro | 35.2h | 456.99 | 8. Casa 8 | 0. Térreo | 0. Locação 1 | Própria |  |  |  |
| 337 | 1.3.8.1.2 | 1. Fundação | 9d | 2023-11-27 | 2023-12-07 | 290 | 435d |  | servente estrutura [300%]; aux. Carpinteiro; aux. ferreiro; ferreiro; carpinteiro [200%] | 633.6h | 19,882.86 | 8. Casa 8 | 0. Térreo | 1. Fundação 1 | Própria |  |  |  |
| 338 | 1.3.8.1.3 | 2. Estrutura | 7d | 2024-03-06 | 2024-03-14 | 311 | 367d | 0d | servente estrutura [300%]; aux. Carpinteiro [200%]; aux. ferreiro [200%]; ferreiro [500%]; carpinteiro [200%] | 862.4h | 46,439.03 | 8. Casa 8 | 0. Térreo | 2. Estrutura 1 | Própria |  |  |  |
| 339 | 1.3.8.1.4 | 3. Alvenarias | 5d | 2024-04-05 | 2024-04-11 | 331 | -2d | 0d | pedreiro [400%]; servente [400%] | 352h | 8,388.41 | 8. Casa 8 | 0. Térreo | 3. Alvenarias 1 | Própria |  |  |  |
| 340 | 1.3.8.1.5 | 5. Ref. Inter. Arg (Parede) | 3d | 2024-07-23 | 2024-07-25 | 313 | -2d | 0d | pedreiro [600%]; servente [600%] | 316.8h | 5,776 | 8. Casa 8 | 0. Térreo | 5. Ref. Inter. Arg (Parede) 1 | Própria |  |  |  |
| 341 | 1.3.8.1.6 | 6. Revest. Gesso (Parede + Teto) | 3d | 2024-08-07 | 2024-08-09 | 361 | 274d | 0d | gesseiro [400%]; aux. gesseiro [200%] | 158.4h | 2,119.41 | 8. Casa 8 | 0. Térreo | 6. Revest. Gesso (Parede + Teto) 1 | Própria |  |  |  |
| 342 | 1.3.8.1.7 | 7. Impermeabilização | 2d | 2024-08-02 | 2024-08-06 | 362SF | 278d | 0d | aplicador de manta | 17.6h | 3,288.15 | 8. Casa 8 | 0. Térreo | 7. Impermeabilização 1 | Própria |  |  |  |
| 343 | 1.3.8.1.8 | 8. Contrapiso | 2d | 2024-08-12 | 2024-08-14 | 410SF | 0d |  | pedreiro [200%]; servente | 52.8h | 3,735.07 | 8. Casa 8 | 0. Térreo | 8. Contrapiso 1 | Própria |  |  |  |
| 344 | 1.3.8.1.9 | 9.1. Chapisco | 0.5d | 2024-10-04 | 2024-10-04 | 317 | 84.5d | 0d | pedreiro [600%]; servente [400%] | 44h | 5,131.51 | 8. Casa 8 | 0. Térreo | 9. Fachada 1 | Própria |  |  |  |
| 345 | 1.3.8.1.10 | 9.2. Emboço | 1.5d | 2024-11-19 | 2024-11-20 | 365 | 84.5d | 0d | pedreiro [600%]; servente [400%] | 132h | 7,697.26 | 8. Casa 8 | 0. Térreo | 9. Fachada 1 | Própria |  |  |  |
| 346 | 1.3.8.1.11 | 9.3. Pint. 1 Demão | 1d | 2025-01-15 | 2025-01-16 | 366 | 84.5d | 0d | pintor [400%]; aux.pintor [200%] | 52.8h | 1,135.92 | 8. Casa 8 | 0. Térreo | 9. Fachada 1 | Própria |  |  |  |
| 347 | 1.3.8.1.12 | 9.4. Pint. 2 Demão | 2d | 2025-03-27 | 2025-03-31 | 367 | 84.5d | 0d | pintor [400%]; aux.pintor [200%] | 105.6h | 757.28 | 8. Casa 8 | 0. Térreo | 9. Fachada 1 | Própria |  |  |  |
| 348 | 1.3.8.1.13 | 10. Cer. Piso | 4d | 2024-11-27 | 2024-12-02 | 321 | 0d |  | pedreiro [400%]; servente [200%] | 211.2h | 25,485.98 | 8. Casa 8 | 0. Térreo | 10. Cer. Piso 1 | Própria | 10 | 10 | 10 |
| 349 | 1.3.8.1.14 | 11. Cer. Parede | 3d | 2025-01-29 | 2025-01-31 | 322 | 0d |  | pedreiro [400%]; servente [200%] | 158.4h | 4,238.82 | 8. Casa 8 | 0. Térreo | 11. Cer. Parede 1 | Própria | 11 | 11 | 11 |
| 350 | 1.3.8.1.15 | 12. Forro (WC's e cozinha) | 1d | 2025-02-03 | 2025-02-04 | 370SF | 0d |  | gesseiro; aux. gesseiro | 17.6h | 635.82 | 8. Casa 8 | 0. Térreo | 12. Forro (WC's e cozinha) 1 | Própria | 12 | 12 | 12 |
| 351 | 1.3.8.1.16 | 13. Esq. Alumínio | 2d | 2025-02-25 | 2025-02-26 | 324 | 100d | 0d | montador esquadrias | 17.6h | 11,307.22 | 8. Casa 8 | 0. Térreo | 13. Esq. Alumínio 1 | Própria | 13 | 13 | 13 |
| 352 | 1.3.8.1.17 | 14. Portas | 2d | 2025-02-27 | 2025-02-28 | 325 | 0d |  | marceneiro [200%] | 35.2h | 2,827.85 | 8. Casa 8 | 0. Térreo | 14. Portas 1 | Própria | 14 | 14 | 14 |
| 353 | 1.3.8.1.18 | 15. Pintura (1ª Demão) | 4d | 2025-06-03 | 2025-06-06 | 326 | 0d |  | pintor [600%]; aux.pintor [300%] | 316.8h | 3,764.82 | 8. Casa 8 | 0. Térreo | 15. Pintura (1ª Demão) 1 | Própria | 15 | 15 | 15 |
| 354 | 1.3.8.1.19 | 16. Bancadas | 1d | 2025-06-12 | 2025-06-13 | 374SF | 66d | 0d | pedreiro [200%]; servente | 26.4h | 10,458.12 | 8. Casa 8 | 0. Térreo | 16. Bancadas 1 | Própria | 16 | 16 | 16 |
| 355 | 1.3.8.1.20 | 17. Pintura (2ª Demão) | 3d | 2025-08-14 | 2025-08-18 | 328 | 0d |  | pintor [600%]; aux.pintor [300%] | 237.6h | 1,563.98 | 8. Casa 8 | 0. Térreo | 17. Pintura (2ª Demão) 1 | Própria | 17 | 17 | 17 |
| 356 | 1.3.8.1.21 | 18. Limp. Interna | 1d | 2025-08-22 | 2025-08-22 | 375 | 0d |  | Diarista [200%] | 17.6h | 418.75 | 8. Casa 8 | 0. Térreo | 18. Limp. Interna 1 | Própria | 18 | 18 | 18 |
| 357 | 1.3.8.2 | **1. Pav. Superior** | 358d | 2024-03-15 | 2025-08-25 |  | 15d |  |  | 3229.6h | 114,879.9 |  |  |  |  |  |  |  |
| 358 | 1.3.8.2.1 | 2. Estrutura | 7d | 2024-03-15 | 2024-03-27 | 338 | 367d |  | servente estrutura [300%]; aux. Carpinteiro [200%]; aux. ferreiro [200%]; ferreiro [500%]; carpinteiro [200%] | 862.4h | 30,006.55 | 8. Casa 8 | 1. Pav. Superior | 2. Estrutura 1 | Própria |  |  |  |
| 359 | 1.3.8.2.2 | 3. Alvenarias | 5d | 2024-04-12 | 2024-04-18 | 339 | -2d | 0d | servente [400%]; pedreiro [400%] | 352h | 10,101.74 | 8. Casa 8 | 1. Pav. Superior | 3. Alvenarias 1 | Própria |  |  |  |
| 360 | 1.3.8.2.3 | 5. Ref. Inter. Arg (Parede) | 4d | 2024-07-26 | 2024-07-31 | 340 | -2d | 0d | pedreiro [600%]; servente [600%] | 422.4h | 5,398.69 | 8. Casa 8 | 1. Pav. Superior | 5. Ref. Inter. Arg (Parede) 1 | Própria |  |  |  |
| 361 | 1.3.8.2.4 | 6. Revest. Gesso (Parede + Teto) | 4d | 2024-08-01 | 2024-08-06 | 360 | -2d | 0d | aux. gesseiro [200%]; gesseiro [400%] | 211.2h | 2,119.41 | 8. Casa 8 | 1. Pav. Superior | 6. Revest. Gesso (Parede + Teto) 1 | Própria |  |  |  |
| 362 | 1.3.8.2.5 | 7. Impermeabilização | 1d | 2024-08-06 | 2024-08-07 | 379SF | 277d | 0d | aplicador de manta | 8.8h | 2,046.85 | 8. Casa 8 | 1. Pav. Superior | 7. Impermeabilização 1 | Própria |  |  |  |
| 363 | 1.3.8.2.6 | 8. Contrapiso | 2d | 2024-08-08 | 2024-08-12 | 343SF | 0d |  | pedreiro [200%]; servente | 52.8h | 2,476.11 | 8. Casa 8 | 1. Pav. Superior | 8. Contrapiso 1 | Própria |  |  |  |
| 364 | 1.3.8.2.7 | 9.1. Chapisco | 0.5d | 2024-10-04 | 2024-10-04 | 344 | 84.5d | 0d | pedreiro [600%]; servente [400%] | 44h | 5,131.51 | 8. Casa 8 | 1. Pav. Superior | 9. Fachada 1 | Própria |  |  |  |
| 365 | 1.3.8.2.8 | 9.2. Emboço | 1.5d | 2024-11-18 | 2024-11-19 | 298 | 84.5d | 0d | pedreiro [600%]; servente [400%] | 132h | 7,697.26 | 8. Casa 8 | 1. Pav. Superior | 9. Fachada 1 | Própria |  |  |  |
| 366 | 1.3.8.2.9 | 9.3. Pint. 1 Demão | 1d | 2025-01-14 | 2025-01-15 | 299 | 84.5d | 0d | pintor [400%]; aux.pintor [200%] | 52.8h | 1,135.92 | 8. Casa 8 | 1. Pav. Superior | 9. Fachada 1 | Própria |  |  |  |
| 367 | 1.3.8.2.10 | 9.4. Pint. 2 Demão | 2d | 2025-03-24 | 2025-03-27 | 300 | 84.5d | 0d | pintor [400%]; aux.pintor [200%] | 105.6h | 757.28 | 8. Casa 8 | 1. Pav. Superior | 9. Fachada 1 | Própria |  |  |  |
| 368 | 1.3.8.2.11 | 10. Cer. Piso | 4d | 2024-12-03 | 2024-12-06 | 348 | 0d |  | pedreiro [400%]; servente [200%] | 211.2h | 19,807.17 | 8. Casa 8 | 1. Pav. Superior | 10. Cer. Piso 1 | Própria | 10 | 10 | 10 |
| 369 | 1.3.8.2.12 | 11. Cer. Parede | 2d | 2025-02-03 | 2025-02-04 | 349 | 0d |  | pedreiro [400%]; servente [200%] | 105.6h | 4,238.82 | 8. Casa 8 | 1. Pav. Superior | 11. Cer. Parede 1 | Própria | 11 | 11 | 11 |
| 370 | 1.3.8.2.13 | 12. Forro (WC's e cozinha) | 1d | 2025-02-04 | 2025-02-05 | 397SF | 0d |  | gesseiro; aux. gesseiro | 17.6h | 895 | 8. Casa 8 | 1. Pav. Superior | 12. Forro (WC's e cozinha) 1 | Própria | 12 | 12 | 12 |
| 371 | 1.3.8.2.14 | 13. Esq. Alumínio | 2d | 2025-02-27 | 2025-02-28 | 351 | 100d | 0d | montador esquadrias | 17.6h | 8,489.61 | 8. Casa 8 | 1. Pav. Superior | 13. Esq. Alumínio 1 | Própria | 13 | 13 | 13 |
| 372 | 1.3.8.2.15 | 14. Portas | 2d | 2025-03-06 | 2025-03-07 | 352 | 0d |  | marceneiro [200%] | 35.2h | 1,858.35 | 8. Casa 8 | 1. Pav. Superior | 14. Portas 1 | Própria | 14 | 14 | 14 |
| 373 | 1.3.8.2.16 | 15. Pintura (1ª Demão) | 4d | 2025-06-09 | 2025-06-12 | 353 | 0d |  | pintor [600%]; aux.pintor [300%] | 316.8h | 3,764.82 | 8. Casa 8 | 1. Pav. Superior | 15. Pintura (1ª Demão) 1 | Própria | 15 | 15 | 15 |
| 374 | 1.3.8.2.17 | 16. Bancadas | 1d | 2025-06-13 | 2025-06-13 | 373 | 49d | 0d | servente; pedreiro [200%] | 26.4h | 6,972.08 | 8. Casa 8 | 1. Pav. Superior | 16. Bancadas 1 | Própria | 16 | 16 | 16 |
| 375 | 1.3.8.2.18 | 17. Pintura (2ª Demão) | 3d | 2025-08-19 | 2025-08-21 | 355 | 0d |  | aux.pintor [300%]; pintor [600%] | 237.6h | 1,563.98 | 8. Casa 8 | 1. Pav. Superior | 17. Pintura (2ª Demão) 1 | Própria | 17 | 17 | 17 |
| 376 | 1.3.8.2.19 | 18. Limp. Interna | 1d | 2025-08-25 | 2025-08-25 | 356 | 0d |  | Diarista [200%] | 17.6h | 418.75 | 8. Casa 8 | 1. Pav. Superior | 18. Limp. Interna 1 | Própria | 18 | 18 | 18 |

| ID | WBS | Task | Duration | Start | Finish | Predecessors | Total slack | Free slack | Resources | Work | Cost | Casa | Pav | Equipe | Empresa | Pacote | Cor | LB |
| --- | --- | --- | --- | --- | --- | --- | --- | --- | --- | --- | --- | --- | --- | --- | --- | --- | --- | --- |
| 377 | 1.3.8.3 | **2. Coberta** | 76d | 2024-04-19 | 2024-08-07 |  | -2d | 0d |  | 536.8h | 58,163.18 |  |  |  |  |  |  |  |
| 378 | 1.3.8.3.1 | 1. Alvenarias | 3d | 2024-04-19 | 2024-04-23 | 359 | -2d | 0d | pedreiro [400%]; servente [400%] | 211.2h | 9,834.12 | 8. Casa 8 | 2. Coberta | 3. Alvenarias 1 | Própria |  |  |  |
| 379 | 1.3.8.3.2 | 2. Impermeabilização | 1d | 2024-08-07 | 2024-08-07 | 361 | -2d | 0d | aplicador de manta | 8.8h | 24,164.53 | 8. Casa 8 | 2. Coberta | 7. Impermeabilização 1 | Própria |  |  |  |
| 380 | 1.3.8.3.3 | 3. Coberta | 6d | 2024-04-24 | 2024-05-02 | 378 | -2d | 0d | carpinteiro [400%]; aux. Carpinteiro [200%] | 316.8h | 24,164.53 | 8. Casa 8 | 2. Coberta | 4. Coberta 1 | Própria |  |  |  |
| 381 | 1.3.9 | **9. Casa 9** | 495d | 2023-08-22 | 2025-08-27 |  | -1d | 0d |  | 7568h | 338,293.15 |  |  |  |  |  |  |  |
| 382 | 1.3.9.1 | **0. Térreo** | 494d | 2023-08-22 | 2025-08-26 |  | -1d | 0d |  | 3801.6h | 165,509.25 |  |  |  |  |  |  |  |
| 383 | 1.3.9.1.1 | 0. Locação | 2d | 2023-08-22 | 2023-08-23 | 336 | -1d | 0d | carpinteiro; aux. Carpinteiro | 35.2h | 456.99 | 9. Casa 9 | 0. Térreo | 0. Locação 1 | Própria |  |  |  |
| 384 | 1.3.9.1.2 | 1. Fundação | 9d | 2023-08-24 | 2023-09-05 | 383 | 564d | 0d | servente estrutura [300%]; aux. Carpinteiro; aux. ferreiro; ferreiro; carpinteiro [200%] | 633.6h | 19,882.86 | 9. Casa 9 | 0. Térreo | 1. Fundação 1 | Própria |  |  |  |
| 385 | 1.3.9.1.3 | 2. Estrutura | 7d | 2023-10-04 | 2023-10-13 | 384FS+28ed | 349d | 0d | servente estrutura [300%]; aux. Carpinteiro [200%]; aux. ferreiro [200%]; ferreiro [500%]; carpinteiro [200%] | 862.4h | 46,439.03 | 9. Casa 9 | 0. Térreo | 2. Estrutura 1 | Própria |  |  |  |
| 386 | 1.3.9.1.4 | 3. Alvenarias | 5d | 2023-11-13 | 2023-11-20 | 385FS+28ed | 349d | 0d | pedreiro [400%]; servente [400%] | 352h | 8,388.41 | 9. Casa 9 | 0. Térreo | 3. Alvenarias 1 | Própria |  |  |  |
| 387 | 1.3.9.1.5 | 5. Ref. Inter. Arg (Parede) | 3d | 2024-05-13 | 2024-05-15 | 427 | 274d | 0d | pedreiro [600%]; servente [600%] | 316.8h | 5,776 | 9. Casa 9 | 0. Térreo | 5. Ref. Inter. Arg (Parede) 1 | Própria |  |  |  |
| 388 | 1.3.9.1.6 | 6. Revest. Gesso (Parede + Teto) | 3d | 2024-05-22 | 2024-05-27 | 408SF | 327d |  | gesseiro [400%]; aux. gesseiro [200%] | 158.4h | 2,119.41 | 9. Casa 9 | 0. Térreo | 6. Revest. Gesso (Parede + Teto) 1 | Própria |  |  |  |
| 389 | 1.3.9.1.7 | 7. Impermeabilização | 2d | 2024-08-08 | 2024-08-09 | 379 | -2d | 0d | aplicador de manta | 17.6h | 3,288.15 | 9. Casa 9 | 0. Térreo | 7. Impermeabilização 1 | Própria |  |  |  |
| 390 | 1.3.9.1.8 | 8. Contrapiso | 2d | 2024-08-16 | 2024-08-20 | 457SF | 0d |  | pedreiro [200%]; servente | 52.8h | 3,735.07 | 9. Casa 9 | 0. Térreo | 8. Contrapiso 1 | Própria |  |  |  |
| 391 | 1.3.9.1.9 | 9.1. Chapisco | 0.5d | 2024-10-07 | 2024-10-07 | 364 | 84.5d | 0d | pedreiro [600%]; servente [400%] | 44h | 5,131.51 | 9. Casa 9 | 0. Térreo | 9. Fachada 1 | Própria |  |  |  |
| 392 | 1.3.9.1.10 | 9.2. Emboço | 1.5d | 2024-11-22 | 2024-11-25 | 412 | 84.5d | 0d | pedreiro [600%]; servente [400%] | 132h | 7,697.26 | 9. Casa 9 | 0. Térreo | 9. Fachada 1 | Própria |  |  |  |
| 393 | 1.3.9.1.11 | 9.3. Pint. 1 Demão | 1d | 2025-01-17 | 2025-01-20 | 413 | 84.5d | 0d | pintor [400%]; aux.pintor [200%] | 52.8h | 1,135.92 | 9. Casa 9 | 0. Térreo | 9. Fachada 1 | Própria |  |  |  |
| 394 | 1.3.9.1.12 | 9.4. Pint. 2 Demão | 2d | 2025-04-02 | 2025-04-04 | 414 | 84.5d | 0d | pintor [400%]; aux.pintor [200%] | 105.6h | 757.28 | 9. Casa 9 | 0. Térreo | 9. Fachada 1 | Própria |  |  |  |
| 395 | 1.3.9.1.13 | 10. Cer. Piso | 4d | 2024-09-09 | 2024-09-12 | 363FS+28ed | 150d | 0d | pedreiro [400%]; servente [200%] | 211.2h | 25,485.98 | 9. Casa 9 | 0. Térreo | 10. Cer. Piso 1 | Própria | 10 | 10 | 10 |
| 396 | 1.3.9.1.14 | 11. Cer. Parede | 3d | 2024-12-09 | 2024-12-11 | 744 | 150d | 0d | pedreiro [400%]; servente [200%] | 158.4h | 4,238.82 | 9. Casa 9 | 0. Térreo | 11. Cer. Parede 1 | Própria | 11 | 11 | 11 |
| 397 | 1.3.9.1.15 | 12. Forro (WC's e cozinha) | 1d | 2025-02-05 | 2025-02-05 | 369 | 0d |  | gesseiro; aux. gesseiro | 17.6h | 635.82 | 9. Casa 9 | 0. Térreo | 12. Forro (WC's e cozinha) 1 | Própria | 12 | 12 | 12 |
| 398 | 1.3.9.1.16 | 13. Esq. Alumínio | 2d | 2025-03-06 | 2025-03-07 | 371 | 100d | 0d | montador esquadrias | 17.6h | 11,307.22 | 9. Casa 9 | 0. Térreo | 13. Esq. Alumínio 1 | Própria | 13 | 13 | 13 |
| 399 | 1.3.9.1.17 | 14. Portas | 2d | 2025-03-10 | 2025-03-11 | 372 | 98d | 0d | marceneiro [200%] | 35.2h | 2,827.85 | 9. Casa 9 | 0. Térreo | 14. Portas 1 | Própria | 14 | 14 | 14 |
| 400 | 1.3.9.1.18 | 15. Pintura (1ª Demão) | 4d | 2025-03-10 | 2025-03-13 | 372 | 18d | 0d | pintor [600%]; aux.pintor [300%] | 316.8h | 3,764.82 | 9. Casa 9 | 0. Térreo | 15. Pintura (1ª Demão) 1 | Própria | 15 | 15 | 15 |
| 401 | 1.3.9.1.19 | 16. Bancadas | 1d | 2025-06-16 | 2025-06-16 | 374 | 49d | 0d | pedreiro [200%]; servente | 26.4h | 10,458.12 | 9. Casa 9 | 0. Térreo | 16. Bancadas 1 | Própria | 16 | 16 | 16 |
| 402 | 1.3.9.1.20 | 17. Pintura (2ª Demão) | 3d | 2025-06-13 | 2025-06-17 | 749 | 18d | 0d | aux.pintor [300%]; pintor [600%] | 237.6h | 1,563.98 | 9. Casa 9 | 0. Térreo | 17. Pintura (2ª Demão) 1 | Própria | 17 | 17 | 17 |
| 403 | 1.3.9.1.21 | 18. Limp. Interna | 1d | 2025-08-26 | 2025-08-26 | 376 | 0d |  | Diarista [200%] | 17.6h | 418.75 | 9. Casa 9 | 0. Térreo | 18. Limp. Interna 1 | Própria | 18 | 18 | 18 |

| ID | WBS | Task | Duration | Start | Finish | Predecessors | Total slack | Free slack | Resources | Work | Cost | Casa | Pav | Equipe | Empresa | Pacote | Cor | LB |
| --- | --- | --- | --- | --- | --- | --- | --- | --- | --- | --- | --- | --- | --- | --- | --- | --- | --- | --- |
| 404 | 1.3.9.2 | **1. Pav. Superior** | 458d | 2023-10-16 | 2025-08-27 |  | 14d |  |  | 3229.6h | 114,620.72 |  |  |  |  |  |  |  |
| 405 | 1.3.9.2.1 | 2. Estrutura | 7d | 2023-10-16 | 2023-10-24 | 385 | 367d | 0d | servente estrutura [300%]; aux. Carpinteiro [200%]; aux. ferreiro [200%]; ferreiro [500%]; carpinteiro [200%] | 862.4h | 30,006.55 | 9. Casa 9 | 1. Pav. Superior | 2. Estrutura 1 | Própria |  |  |  |
| 406 | 1.3.9.2.2 | 3. Alvenarias | 5d | 2023-11-21 | 2023-11-27 | 386 | 349d | 0d | servente [400%]; pedreiro [400%] | 352h | 10,101.74 | 9. Casa 9 | 1. Pav. Superior | 3. Alvenarias 1 | Própria |  |  |  |
| 407 | 1.3.9.2.3 | 5. Ref. Inter. Arg (Parede) | 4d | 2024-05-16 | 2024-05-21 | 387 | 274d | 0d | pedreiro [600%]; servente [600%] | 422.4h | 5,398.69 | 9. Casa 9 | 1. Pav. Superior | 5. Ref. Inter. Arg (Parede) 1 | Própria |  |  |  |
| 408 | 1.3.9.2.4 | 6. Revest. Gesso (Parede + Teto) | 4d | 2024-05-27 | 2024-06-04 | 435SF | 323d | 0d | aux. gesseiro [200%]; gesseiro [400%] | 211.2h | 2,119.41 | 9. Casa 9 | 1. Pav. Superior | 6. Revest. Gesso (Parede + Teto) 1 | Própria |  |  |  |
| 409 | 1.3.9.2.5 | 7. Impermeabilização | 1d | 2024-08-12 | 2024-08-12 | 389 | -2d | 0d | aplicador de manta | 8.8h | 2,046.85 | 9. Casa 9 | 1. Pav. Superior | 7. Impermeabilização 1 | Própria |  |  |  |
| 410 | 1.3.9.2.6 | 8. Contrapiso | 2d | 2024-08-14 | 2024-08-16 | 390SF | 0d |  | pedreiro [200%]; servente | 52.8h | 2,476.11 | 9. Casa 9 | 1. Pav. Superior | 8. Contrapiso 1 | Própria |  |  |  |
| 411 | 1.3.9.2.7 | 9.1. Chapisco | 0.5d | 2024-10-07 | 2024-10-07 | 391 | 84.5d | 0d | pedreiro [600%]; servente [400%] | 44h | 5,131.51 | 9. Casa 9 | 1. Pav. Superior | 9. Fachada 1 | Própria |  |  |  |
| 412 | 1.3.9.2.8 | 9.2. Emboço | 1.5d | 2024-11-21 | 2024-11-22 | 345 | 84.5d | 0d | pedreiro [600%]; servente [400%] | 132h | 7,697.26 | 9. Casa 9 | 1. Pav. Superior | 9. Fachada 1 | Própria |  |  |  |
| 413 | 1.3.9.2.9 | 9.3. Pint. 1 Demão | 1d | 2025-01-16 | 2025-01-17 | 346 | 84.5d | 0d | pintor [400%]; aux.pintor [200%] | 52.8h | 1,135.92 | 9. Casa 9 | 1. Pav. Superior | 9. Fachada 1 | Própria |  |  |  |
| 414 | 1.3.9.2.10 | 9.4. Pint. 2 Demão | 2d | 2025-03-31 | 2025-04-02 | 347 | 84.5d | 0d | pintor [400%]; aux.pintor [200%] | 105.6h | 757.28 | 9. Casa 9 | 1. Pav. Superior | 9. Fachada 1 | Própria |  |  |  |
| 415 | 1.3.9.2.11 | 10. Cer. Piso | 4d | 2024-09-13 | 2024-09-18 | 395 | 150d | 0d | servente [200%]; pedreiro [400%] | 211.2h | 19,807.17 | 9. Casa 9 | 1. Pav. Superior | 10. Cer. Piso 1 | Própria | 10 | 10 | 10 |
| 416 | 1.3.9.2.12 | 11. Cer. Parede | 2d | 2024-12-12 | 2024-12-13 | 396 | 150d | 0d | pedreiro [400%]; servente [200%] | 105.6h | 4,238.82 | 9. Casa 9 | 1. Pav. Superior | 11. Cer. Parede 1 | Própria | 11 | 11 | 11 |
| 417 | 1.3.9.2.13 | 12. Forro (WC's e cozinha) | 1d | 2025-02-06 | 2025-02-06 | 397 | 134d | 0d | aux. gesseiro; gesseiro | 17.6h | 635.82 | 9. Casa 9 | 1. Pav. Superior | 12. Forro (WC's e cozinha) 1 | Própria | 12 | 12 | 12 |
| 418 | 1.3.9.2.14 | 13. Esq. Alumínio | 2d | 2025-03-10 | 2025-03-11 | 398 | 100d | 0d | montador esquadrias | 17.6h | 8,489.61 | 9. Casa 9 | 1. Pav. Superior | 13. Esq. Alumínio 1 | Própria | 13 | 13 | 13 |
| 419 | 1.3.9.2.15 | 14. Portas | 2d | 2025-03-12 | 2025-03-13 | 399 | 98d | 0d | marceneiro [200%] | 35.2h | 1,858.35 | 9. Casa 9 | 1. Pav. Superior | 14. Portas 1 | Própria | 14 | 14 | 14 |
| 420 | 1.3.9.2.16 | 15. Pintura (1ª Demão) | 4d | 2025-03-14 | 2025-03-20 | 400 | 18d | 0d | pintor [600%]; aux.pintor [300%] | 316.8h | 3,764.82 | 9. Casa 9 | 1. Pav. Superior | 15. Pintura (1ª Demão) 1 | Própria | 15 | 15 | 15 |
| 421 | 1.3.9.2.17 | 16. Bancadas | 1d | 2025-06-17 | 2025-06-17 | 401 | 49d | 0d | servente; pedreiro [200%] | 26.4h | 6,972.08 | 9. Casa 9 | 1. Pav. Superior | 16. Bancadas 1 | Própria | 16 | 16 | 16 |
| 422 | 1.3.9.2.18 | 17. Pintura (2ª Demão) | 3d | 2025-06-18 | 2025-06-24 | 402 | 18d | 0d | aux.pintor [300%]; pintor [600%] | 237.6h | 1,563.98 | 9. Casa 9 | 1. Pav. Superior | 17. Pintura (2ª Demão) 1 | Própria | 17 | 17 | 17 |
| 423 | 1.3.9.2.19 | 18. Limp. Interna | 1d | 2025-08-27 | 2025-08-27 | 403 | 0d |  | Diarista [200%] | 17.6h | 418.75 | 9. Casa 9 | 1. Pav. Superior | 18. Limp. Interna 1 | Própria | 18 | 18 | 18 |
| 424 | 1.3.9.3 | **2. Coberta** | 171d | 2023-11-28 | 2024-08-13 |  | 98d |  |  | 536.8h | 58,163.18 |  |  |  |  |  |  |  |
| 425 | 1.3.9.3.1 | 1. Alvenarias | 3d | 2023-11-28 | 2023-11-30 | 406 | 349d | 0d | pedreiro [400%]; servente [400%] | 211.2h | 9,834.12 | 9. Casa 9 | 2. Coberta | 3. Alvenarias 1 | Própria |  |  |  |
| 426 | 1.3.9.3.2 | 2. Impermeabilização | 1d | 2024-08-13 | 2024-08-13 | 409 | -2d | 0d | aplicador de manta | 8.8h | 24,164.53 | 9. Casa 9 | 2. Coberta | 7. Impermeabilização 1 | Própria |  |  |  |
| 427 | 1.3.9.3.3 | 3. Coberta | 6d | 2024-05-03 | 2024-05-10 | 380 | -2d | 0d | carpinteiro [400%]; aux. Carpinteiro [200%] | 316.8h | 24,164.53 | 9. Casa 9 | 2. Coberta | 4. Coberta 1 | Própria |  |  |  |

| ID | WBS | Task | Duration | Start | Finish | Predecessors | Total slack | Free slack | Resources | Work | Cost | Casa | Pav | Equipe | Empresa | Pacote | Cor | LB |
| --- | --- | --- | --- | --- | --- | --- | --- | --- | --- | --- | --- | --- | --- | --- | --- | --- | --- | --- |
| 428 | 1.3.10 | **10. Casa 10** | 495d | 2023-08-24 | 2025-08-29 |  | 12d |  |  | 7594.4h | 338,552.33 |  |  |  |  |  |  |  |
| 429 | 1.3.10.1 | **0. Térreo** | 494d | 2023-08-24 | 2025-08-28 |  | 13d |  |  | 3801.6h | 165,768.43 |  |  |  |  |  |  |  |
| 430 | 1.3.10.1.1 | 0. Locação | 2d | 2023-08-24 | 2023-08-25 | 383 | 805d | 0d | carpinteiro; aux. Carpinteiro | 35.2h | 456.99 | 10. Casa 10 | 0. Térreo | 0. Locação 1 | Própria |  |  |  |
| 431 | 1.3.10.1.2 | 1. Fundação | 9d | 2023-09-06 | 2023-09-19 | 384 | 747d | 0d | servente estrutura [300%]; aux. Carpinteiro; aux. ferreiro; ferreiro; carpinteiro [200%] | 633.6h | 19,882.86 | 10. Casa 10 | 0. Térreo | 1. Fundação 1 | Própria |  |  |  |
| 432 | 1.3.10.1.3 | 2. Estrutura | 7d | 2023-10-25 | 2023-11-03 | 405 | 367d | 0d | servente estrutura [300%]; aux. Carpinteiro [200%]; aux. ferreiro [200%]; ferreiro [500%]; carpinteiro [200%] | 862.4h | 46,439.03 | 10. Casa 10 | 0. Térreo | 2. Estrutura 1 | Própria |  |  |  |
| 433 | 1.3.10.1.4 | 3. Alvenarias | 5d | 2023-12-01 | 2023-12-07 | 425 | 349d | 0d | pedreiro [400%]; servente [400%] | 352h | 8,388.41 | 10. Casa 10 | 0. Térreo | 3. Alvenarias 1 | Própria |  |  |  |
| 434 | 1.3.10.1.5 | 5. Ref. Inter. Arg (Parede) | 3d | 2024-05-22 | 2024-05-24 | 407 | 274d | 0d | pedreiro [600%]; servente [600%] | 316.8h | 5,776 | 10. Casa 10 | 0. Térreo | 5. Ref. Inter. Arg (Parede) 1 | Própria |  |  |  |
| 435 | 1.3.10.1.6 | 6. Revest. Gesso (Parede + Teto) | 3d | 2024-06-04 | 2024-06-07 | 455SF | 320d | 0d | gesseiro [400%]; aux. gesseiro [200%] | 158.4h | 2,119.41 | 10. Casa 10 | 0. Térreo | 6. Revest. Gesso (Parede + Teto) 1 | Própria |  |  |  |
| 436 | 1.3.10.1.7 | 7. Impermeabilização | 2d | 2024-08-14 | 2024-08-15 | 426 | -2d | 0d | aplicador de manta | 17.6h | 3,288.15 | 10. Casa 10 | 0. Térreo | 7. Impermeabilização 1 | Própria |  |  |  |
| 437 | 1.3.10.1.8 | 8. Contrapiso | 2d | 2024-08-22 | 2024-08-26 | 504SF | 0d |  | pedreiro [200%]; servente | 52.8h | 3,735.07 | 10. Casa 10 | 0. Térreo | 8. Contrapiso 1 | Própria |  |  |  |
| 438 | 1.3.10.1.9 | 9.1. Chapisco | 0.5d | 2024-10-08 | 2024-10-08 | 411 | 84.5d | 0d | pedreiro [600%]; servente [400%] | 44h | 5,131.51 | 10. Casa 10 | 0. Térreo | 9. Fachada 1 | Própria |  |  |  |
| 439 | 1.3.10.1.10 | 9.2. Emboço | 1.5d | 2024-11-27 | 2024-11-28 | 459 | 84.5d | 0d | pedreiro [600%]; servente [400%] | 132h | 7,697.26 | 10. Casa 10 | 0. Térreo | 9. Fachada 1 | Própria |  |  |  |
| 440 | 1.3.10.1.11 | 9.3. Pint. 1 Demão | 1d | 2025-01-21 | 2025-01-22 | 460 | 84.5d | 0d | pintor [400%]; aux.pintor [200%] | 52.8h | 1,135.92 | 10. Casa 10 | 0. Térreo | 9. Fachada 1 | Própria |  |  |  |
| 441 | 1.3.10.1.12 | 9.4. Pint. 2 Demão | 2d | 2025-04-08 | 2025-04-10 | 461 | 84.5d | 0d | pintor [400%]; aux.pintor [200%] | 105.6h | 757.28 | 10. Casa 10 | 0. Térreo | 9. Fachada 1 | Própria |  |  |  |
| 442 | 1.3.10.1.13 | 10. Cer. Piso | 4d | 2024-09-19 | 2024-09-24 | 415 | 150d | 0d | pedreiro [400%]; servente [200%] | 211.2h | 25,485.98 | 10. Casa 10 | 0. Térreo | 10. Cer. Piso 1 | Própria | 10 | 10 | 10 |
| 443 | 1.3.10.1.14 | 11. Cer. Parede | 3d | 2024-12-16 | 2024-12-18 | 416 | 150d | 0d | pedreiro [400%]; servente [200%] | 158.4h | 4,238.82 | 10. Casa 10 | 0. Térreo | 11. Cer. Parede 1 | Própria | 11 | 11 | 11 |
| 444 | 1.3.10.1.15 | 12. Forro (WC's e cozinha) | 1d | 2025-02-07 | 2025-02-07 | 417 | 134d | 0d | gesseiro; aux. gesseiro | 17.6h | 895 | 10. Casa 10 | 0. Térreo | 12. Forro (WC's e cozinha) 1 | Própria | 12 | 12 | 12 |
| 445 | 1.3.10.1.16 | 13. Esq. Alumínio | 2d | 2025-03-12 | 2025-03-13 | 418 | 100d | 0d | montador esquadrias | 17.6h | 11,307.22 | 10. Casa 10 | 0. Térreo | 13. Esq. Alumínio 1 | Própria | 13 | 13 | 13 |
| 446 | 1.3.10.1.17 | 14. Portas | 2d | 2025-03-14 | 2025-03-17 | 419 | 98d | 0d | marceneiro [200%] | 35.2h | 2,827.85 | 10. Casa 10 | 0. Térreo | 14. Portas 1 | Própria | 14 | 14 | 14 |
| 447 | 1.3.10.1.18 | 15. Pintura (1ª Demão) | 4d | 2025-03-21 | 2025-03-27 | 420 | 18d | 0d | pintor [600%]; aux.pintor [300%] | 316.8h | 3,764.82 | 10. Casa 10 | 0. Térreo | 15. Pintura (1ª Demão) 1 | Própria | 15 | 15 | 15 |
| 448 | 1.3.10.1.19 | 16. Bancadas | 1d | 2025-06-18 | 2025-06-18 | 421 | 49d | 0d | pedreiro [200%]; servente | 26.4h | 10,458.12 | 10. Casa 10 | 0. Térreo | 16. Bancadas 1 | Própria | 16 | 16 | 16 |
| 449 | 1.3.10.1.20 | 17. Pintura (2ª Demão) | 3d | 2025-06-25 | 2025-06-27 | 422 | 18d | 0d | aux.pintor [300%]; pintor [600%] | 237.6h | 1,563.98 | 10. Casa 10 | 0. Térreo | 17. Pintura (2ª Demão) 1 | Própria | 17 | 17 | 17 |
| 450 | 1.3.10.1.21 | 18. Limp. Interna | 1d | 2025-08-28 | 2025-08-28 | 423 | 0d |  | Diarista [200%] | 17.6h | 418.75 | 10. Casa 10 | 0. Térreo | 18. Limp. Interna 1 | Própria | 18 | 18 | 18 |
| 451 | 1.3.10.2 | **1. Pav. Superior** | 446d | 2023-11-06 | 2025-08-29 |  | 12d |  |  | 3256h | 114,620.72 |  |  |  |  |  |  |  |
| 452 | 1.3.10.2.1 | 2. Estrutura | 7d | 2023-11-06 | 2023-11-14 | 432 | 367d | 0d | servente estrutura [300%]; aux. Carpinteiro [200%]; aux. ferreiro [200%]; ferreiro [500%]; carpinteiro [200%] | 862.4h | 30,006.55 | 10. Casa 10 | 1. Pav. Superior | 2. Estrutura 1 | Própria |  |  |  |
| 453 | 1.3.10.2.2 | 3. Alvenarias | 5d | 2023-12-08 | 2023-12-14 | 433 | 349d | 0d | servente [400%]; pedreiro [400%] | 352h | 10,101.74 | 10. Casa 10 | 1. Pav. Superior | 3. Alvenarias 1 | Própria |  |  |  |
| 454 | 1.3.10.2.3 | 5. Ref. Inter. Arg (Parede) | 4d | 2024-05-27 | 2024-06-03 | 434 | 274d | 0d | pedreiro [600%]; servente [600%] | 422.4h | 5,398.69 | 10. Casa 10 | 1. Pav. Superior | 5. Ref. Inter. Arg (Parede) 1 | Própria |  |  |  |
| 455 | 1.3.10.2.4 | 6. Revest. Gesso (Parede + Teto) | 4d | 2024-06-07 | 2024-06-13 | 482SF | 316d | 0d | aux. gesseiro [200%]; gesseiro [400%] | 211.2h | 2,119.41 | 10. Casa 10 | 1. Pav. Superior | 6. Revest. Gesso (Parede + Teto) 1 | Própria |  |  |  |
| 456 | 1.3.10.2.5 | 7. Impermeabilização | 1d | 2024-08-16 | 2024-08-16 | 436 | -2d | 0d | gesseiro [300%]; servente | 35.2h | 2,046.85 | 10. Casa 10 | 1. Pav. Superior | 7. Impermeabilização 1 | Própria |  |  |  |
| 457 | 1.3.10.2.6 | 8. Contrapiso | 2d | 2024-08-20 | 2024-08-22 | 437SF | 0d |  | pedreiro [200%]; servente | 52.8h | 2,476.11 | 10. Casa 10 | 1. Pav. Superior | 8. Contrapiso 1 | Própria |  |  |  |
| 458 | 1.3.10.2.7 | 9.1. Chapisco | 0.5d | 2024-10-08 | 2024-10-08 | 438 | 84.5d | 0d | pedreiro [600%]; servente [400%] | 44h | 5,131.51 | 10. Casa 10 | 1. Pav. Superior | 9. Fachada 1 | Própria |  |  |  |
| 459 | 1.3.10.2.8 | 9.2. Emboço | 1.5d | 2024-11-26 | 2024-11-27 | 392 | 84.5d | 0d | pedreiro [600%]; servente [400%] | 132h | 7,697.26 | 10. Casa 10 | 1. Pav. Superior | 9. Fachada 1 | Própria |  |  |  |
| 460 | 1.3.10.2.9 | 9.3. Pint. 1 Demão | 1d | 2025-01-20 | 2025-01-21 | 393 | 84.5d | 0d | pintor [400%]; aux.pintor [200%] | 52.8h | 1,135.92 | 10. Casa 10 | 1. Pav. Superior | 9. Fachada 1 | Própria |  |  |  |
| 461 | 1.3.10.2.10 | 9.4. Pint. 2 Demão | 2d | 2025-04-04 | 2025-04-08 | 394 | 84.5d | 0d | pintor [400%]; aux.pintor [200%] | 105.6h | 757.28 | 10. Casa 10 | 1. Pav. Superior | 9. Fachada 1 | Própria |  |  |  |
| 462 | 1.3.10.2.11 | 10. Cer. Piso | 4d | 2024-09-25 | 2024-09-30 | 442 | 150d | 0d | pedreiro [400%]; servente [200%] | 211.2h | 19,807.17 | 10. Casa 10 | 1. Pav. Superior | 10. Cer. Piso 1 | Própria | 10 | 10 | 10 |
| 463 | 1.3.10.2.12 | 11. Cer. Parede | 2d | 2024-12-19 | 2024-12-20 | 443 | 150d | 0d | pedreiro [400%]; servente [200%] | 105.6h | 4,238.82 | 10. Casa 10 | 1. Pav. Superior | 11. Cer. Parede 1 | Própria | 11 | 11 | 11 |
| 464 | 1.3.10.2.13 | 12. Forro (WC's e cozinha) | 1d | 2025-02-10 | 2025-02-10 | 444 | 134d | 0d | gesseiro; aux. gesseiro | 17.6h | 635.82 | 10. Casa 10 | 1. Pav. Superior | 12. Forro (WC's e cozinha) 1 | Própria | 12 | 12 | 12 |
| 465 | 1.3.10.2.14 | 13. Esq. Alumínio | 2d | 2025-03-14 | 2025-03-17 | 445 | 100d | 0d | montador esquadrias | 17.6h | 8,489.61 | 10. Casa 10 | 1. Pav. Superior | 13. Esq. Alumínio 1 | Própria | 13 | 13 | 13 |
| 466 | 1.3.10.2.15 | 14. Portas | 2d | 2025-03-18 | 2025-03-20 | 446 | 98d | 0d | marceneiro [200%] | 35.2h | 1,858.35 | 10. Casa 10 | 1. Pav. Superior | 14. Portas 1 | Própria | 14 | 14 | 14 |
| 467 | 1.3.10.2.16 | 15. Pintura (1ª Demão) | 4d | 2025-03-28 | 2025-04-02 | 447 | 18d | 0d | pintor [600%]; aux.pintor [300%] | 316.8h | 3,764.82 | 10. Casa 10 | 1. Pav. Superior | 15. Pintura (1ª Demão) 1 | Própria | 15 | 15 | 15 |
| 468 | 1.3.10.2.17 | 16. Bancadas | 1d | 2025-06-23 | 2025-06-23 | 448 | 49d | 0d | servente; pedreiro [200%] | 26.4h | 6,972.08 | 10. Casa 10 | 1. Pav. Superior | 16. Bancadas 1 | Própria | 16 | 16 | 16 |
| 469 | 1.3.10.2.18 | 17. Pintura (2ª Demão) | 3d | 2025-06-30 | 2025-07-02 | 449 | 18d | 0d | aux.pintor [300%]; pintor [600%] | 237.6h | 1,563.98 | 10. Casa 10 | 1. Pav. Superior | 17. Pintura (2ª Demão) 1 | Própria | 17 | 17 | 17 |
| 470 | 1.3.10.2.19 | 18. Limp. Interna | 1d | 2025-08-29 | 2025-08-29 | 450 | 0d |  | Diarista [200%] | 17.6h | 418.75 | 10. Casa 10 | 1. Pav. Superior | 18. Limp. Interna 1 | Própria | 18 | 18 | 18 |

| ID | WBS | Task | Duration | Start | Finish | Predecessors | Total slack | Free slack | Resources | Work | Cost | Casa | Pav | Equipe | Empresa | Pacote | Cor | LB |
| --- | --- | --- | --- | --- | --- | --- | --- | --- | --- | --- | --- | --- | --- | --- | --- | --- | --- | --- |
| 471 | 1.3.10.3 | **2. Coberta** | 162d | 2023-12-15 | 2024-08-19 |  | 159d |  |  | 536.8h | 58,163.18 |  |  |  |  |  |  |  |
| 472 | 1.3.10.3.1 | 1. Alvenarias | 3d | 2023-12-15 | 2023-12-19 | 453 | 349d | 0d | pedreiro [400%]; servente [400%] | 211.2h | 9,834.12 | 10. Casa 10 | 2. Coberta | 3. Alvenarias 1 | Própria |  |  |  |
| 473 | 1.3.10.3.2 | 2. Impermeabilização | 1d | 2024-08-19 | 2024-08-19 | 456 | -2d | 0d | aplicador de manta | 8.8h | 24,164.53 | 10. Casa 10 | 2. Coberta | 7. Impermeabilização 1 | Própria |  |  |  |
| 474 | 1.3.10.3.3 | 3. Coberta | 6d | 2024-05-13 | 2024-05-20 | 427 | 295d | 0d | carpinteiro [400%]; aux. Carpinteiro [200%] | 316.8h | 24,164.53 | 10. Casa 10 | 2. Coberta | 4. Coberta 1 | Própria |  |  |  |
| 475 | 1.3.11 | **11. Casa 11** | 495d | 2023-08-28 | 2025-09-02 |  | 10d |  |  | 7594.4h | 338,552.33 |  |  |  |  |  |  |  |
| 476 | 1.3.11.1 | **0. Térreo** | 494d | 2023-08-28 | 2025-09-01 |  | 11d |  |  | 3801.6h | 165,768.43 |  |  |  |  |  |  |  |
| 477 | 1.3.11.1.1 | 0. Locação | 2d | 2023-08-28 | 2023-08-29 | 430 | 805d | 0d | carpinteiro; aux. Carpinteiro | 35.2h | 456.99 | 11. Casa 11 | 0. Térreo | 0. Locação 1 | Própria |  |  |  |
| 478 | 1.3.11.1.2 | 1. Fundação | 9d | 2023-09-20 | 2023-10-02 | 431 | 747d | 0d | servente estrutura [300%]; aux. Carpinteiro; aux. ferreiro; ferreiro; carpinteiro [200%] | 633.6h | 19,882.86 | 11. Casa 11 | 0. Térreo | 1. Fundação 1 | Própria |  |  |  |
| 479 | 1.3.11.1.3 | 2. Estrutura | 7d | 2023-11-16 | 2023-11-24 | 452 | 367d | 0d | servente estrutura [300%]; aux. Carpinteiro [200%]; aux. ferreiro [200%]; ferreiro [500%]; carpinteiro [200%] | 862.4h | 46,439.03 | 11. Casa 11 | 0. Térreo | 2. Estrutura 1 | Própria |  |  |  |
| 480 | 1.3.11.1.4 | 3. Alvenarias | 5d | 2023-12-20 | 2024-01-03 | 472 | 349d | 0d | pedreiro [400%]; servente [400%] | 352h | 8,388.41 | 11. Casa 11 | 0. Térreo | 3. Alvenarias 1 | Própria |  |  |  |
| 481 | 1.3.11.1.5 | 5. Ref. Inter. Arg (Parede) | 3d | 2024-06-04 | 2024-06-06 | 454 | 274d | 0d | pedreiro [600%]; servente [600%] | 316.8h | 5,776 | 11. Casa 11 | 0. Térreo | 5. Ref. Inter. Arg (Parede) 1 | Própria |  |  |  |
| 482 | 1.3.11.1.6 | 6. Revest. Gesso (Parede + Teto) | 3d | 2024-06-13 | 2024-06-18 | 502SF | 313d | 0d | gesseiro [400%]; aux. gesseiro [200%] | 158.4h | 2,119.41 | 11. Casa 11 | 0. Térreo | 6. Revest. Gesso (Parede + Teto) 1 | Própria |  |  |  |
| 483 | 1.3.11.1.7 | 7. Impermeabilização | 2d | 2024-08-20 | 2024-08-21 | 473 | -2d | 0d | aplicador de manta | 17.6h | 3,288.15 | 11. Casa 11 | 0. Térreo | 7. Impermeabilização 1 | Própria |  |  |  |
| 484 | 1.3.11.1.8 | 8. Contrapiso | 2d | 2024-08-28 | 2024-08-30 | 551SF | 0d |  | pedreiro [200%]; servente | 52.8h | 3,735.07 | 11. Casa 11 | 0. Térreo | 8. Contrapiso 1 | Própria |  |  |  |
| 485 | 1.3.11.1.9 | 9.1. Chapisco | 0.5d | 2024-10-09 | 2024-10-09 | 458 | 84.5d | 0d | pedreiro [600%]; servente [400%] | 44h | 5,131.51 | 11. Casa 11 | 0. Térreo | 9. Fachada 1 | Própria |  |  |  |
| 486 | 1.3.11.1.10 | 9.2. Emboço | 1.5d | 2024-12-02 | 2024-12-03 | 506 | 84.5d | 0d | pedreiro [600%]; servente [400%] | 132h | 7,697.26 | 11. Casa 11 | 0. Térreo | 9. Fachada 1 | Própria |  |  |  |
| 487 | 1.3.11.1.11 | 9.3. Pint. 1 Demão | 1d | 2025-01-23 | 2025-01-24 | 507 | 84.5d | 0d | pintor [400%]; aux.pintor [200%] | 52.8h | 1,135.92 | 11. Casa 11 | 0. Térreo | 9. Fachada 1 | Própria |  |  |  |
| 488 | 1.3.11.1.12 | 9.4. Pint. 2 Demão | 2d | 2025-04-14 | 2025-04-16 | 508 | 84.5d | 0d | pintor [400%]; aux.pintor [200%] | 105.6h | 757.28 | 11. Casa 11 | 0. Térreo | 9. Fachada 1 | Própria |  |  |  |
| 489 | 1.3.11.1.13 | 10. Cer. Piso | 4d | 2024-10-01 | 2024-10-04 | 462 | 150d | 0d | pedreiro [400%]; servente [200%] | 211.2h | 25,485.98 | 11. Casa 11 | 0. Térreo | 10. Cer. Piso 1 | Própria | 10 | 10 | 10 |
| 490 | 1.3.11.1.14 | 11. Cer. Parede | 3d | 2024-12-23 | 2024-12-26 | 463 | 150d | 0d | pedreiro [400%]; servente [200%] | 158.4h | 4,238.82 | 11. Casa 11 | 0. Térreo | 11. Cer. Parede 1 | Própria | 11 | 11 | 11 |
| 491 | 1.3.11.1.15 | 12. Forro (WC's e cozinha) | 1d | 2025-02-11 | 2025-02-11 | 464 | 134d | 0d | gesseiro; aux. gesseiro | 17.6h | 895 | 11. Casa 11 | 0. Térreo | 12. Forro (WC's e cozinha) 1 | Própria | 12 | 12 | 12 |
| 492 | 1.3.11.1.16 | 13. Esq. Alumínio | 2d | 2025-03-18 | 2025-03-20 | 465 | 100d | 0d | montador esquadrias | 17.6h | 11,307.22 | 11. Casa 11 | 0. Térreo | 13. Esq. Alumínio 1 | Própria | 13 | 13 | 13 |
| 493 | 1.3.11.1.17 | 14. Portas | 2d | 2025-03-21 | 2025-03-24 | 466 | 98d | 0d | marceneiro [200%] | 35.2h | 2,827.85 | 11. Casa 11 | 0. Térreo | 14. Portas 1 | Própria | 14 | 14 | 14 |
| 494 | 1.3.11.1.18 | 15. Pintura (1ª Demão) | 4d | 2025-04-03 | 2025-04-08 | 467 | 18d | 0d | pintor [600%]; aux.pintor [300%] | 316.8h | 3,764.82 | 11. Casa 11 | 0. Térreo | 15. Pintura (1ª Demão) 1 | Própria | 15 | 15 | 15 |
| 495 | 1.3.11.1.19 | 16. Bancadas | 1d | 2025-06-24 | 2025-06-24 | 468 | 49d | 0d | pedreiro [200%]; servente | 26.4h | 10,458.12 | 11. Casa 11 | 0. Térreo | 16. Bancadas 1 | Própria | 16 | 16 | 16 |
| 496 | 1.3.11.1.20 | 17. Pintura (2ª Demão) | 3d | 2025-07-03 | 2025-07-07 | 469 | 18d | 0d | aux.pintor [300%]; pintor [600%] | 237.6h | 1,563.98 | 11. Casa 11 | 0. Térreo | 17. Pintura (2ª Demão) 1 | Própria | 17 | 17 | 17 |
| 497 | 1.3.11.1.21 | 18. Limp. Interna | 1d | 2025-09-01 | 2025-09-01 | 470 | 0d |  | Diarista [200%] | 17.6h | 418.75 | 11. Casa 11 | 0. Térreo | 18. Limp. Interna 1 | Própria | 18 | 18 | 18 |

| ID | WBS | Task | Duration | Start | Finish | Predecessors | Total slack | Free slack | Resources | Work | Cost | Casa | Pav | Equipe | Empresa | Pacote | Cor | LB |
| --- | --- | --- | --- | --- | --- | --- | --- | --- | --- | --- | --- | --- | --- | --- | --- | --- | --- | --- |
| 498 | 1.3.11.2 | **1. Pav. Superior** | 434d | 2023-11-27 | 2025-09-02 |  | 10d |  |  | 3256h | 114,620.72 |  |  |  |  |  |  |  |
| 499 | 1.3.11.2.1 | 2. Estrutura | 7d | 2023-11-27 | 2023-12-05 | 479 | 367d | 0d | servente estrutura [300%]; aux. Carpinteiro [200%]; aux. ferreiro [200%]; ferreiro [500%]; carpinteiro [200%] | 862.4h | 30,006.55 | 11. Casa 11 | 1. Pav. Superior | 2. Estrutura 1 | Própria |  |  |  |
| 500 | 1.3.11.2.2 | 3. Alvenarias | 5d | 2024-01-04 | 2024-01-10 | 480 | 349d | 0d | servente [400%]; pedreiro [400%] | 352h | 10,101.74 | 11. Casa 11 | 1. Pav. Superior | 3. Alvenarias 1 | Própria |  |  |  |
| 501 | 1.3.11.2.3 | 5. Ref. Inter. Arg (Parede) | 4d | 2024-06-07 | 2024-06-12 | 481 | 274d | 0d | pedreiro [600%]; servente [600%] | 422.4h | 5,398.69 | 11. Casa 11 | 1. Pav. Superior | 5. Ref. Inter. Arg (Parede) 1 | Própria |  |  |  |
| 502 | 1.3.11.2.4 | 6. Revest. Gesso (Parede + Teto) | 4d | 2024-06-18 | 2024-06-24 | 529SF | 309d | 0d | aux. gesseiro [200%]; gesseiro [400%] | 211.2h | 2,119.41 | 11. Casa 11 | 1. Pav. Superior | 6. Revest. Gesso (Parede + Teto) 1 | Própria |  |  |  |
| 503 | 1.3.11.2.5 | 7. Impermeabilização | 1d | 2024-08-22 | 2024-08-22 | 483 | -2d | 0d | gesseiro [300%]; servente | 35.2h | 2,046.85 | 11. Casa 11 | 1. Pav. Superior | 7. Impermeabilização 1 | Própria |  |  |  |
| 504 | 1.3.11.2.6 | 8. Contrapiso | 2d | 2024-08-26 | 2024-08-28 | 484SF | 0d |  | pedreiro [200%]; servente | 52.8h | 2,476.11 | 11. Casa 11 | 1. Pav. Superior | 8. Contrapiso 1 | Própria |  |  |  |
| 505 | 1.3.11.2.7 | 9.1. Chapisco | 0.5d | 2024-10-09 | 2024-10-09 | 485 | 84.5d | 0d | pedreiro [600%]; servente [400%] | 44h | 5,131.51 | 11. Casa 11 | 1. Pav. Superior | 9. Fachada 1 | Própria |  |  |  |
| 506 | 1.3.11.2.8 | 9.2. Emboço | 1.5d | 2024-11-29 | 2024-12-02 | 439 | 84.5d | 0d | pedreiro [600%]; servente [400%] | 132h | 7,697.26 | 11. Casa 11 | 1. Pav. Superior | 9. Fachada 1 | Própria |  |  |  |
| 507 | 1.3.11.2.9 | 9.3. Pint. 1 Demão | 1d | 2025-01-22 | 2025-01-23 | 440 | 84.5d | 0d | pintor [400%]; aux.pintor [200%] | 52.8h | 1,135.92 | 11. Casa 11 | 1. Pav. Superior | 9. Fachada 1 | Própria |  |  |  |
| 508 | 1.3.11.2.10 | 9.4. Pint. 2 Demão | 2d | 2025-04-10 | 2025-04-14 | 441 | 84.5d | 0d | pintor [400%]; aux.pintor [200%] | 105.6h | 757.28 | 11. Casa 11 | 1. Pav. Superior | 9. Fachada 1 | Própria |  |  |  |
| 509 | 1.3.11.2.11 | 10. Cer. Piso | 4d | 2024-10-07 | 2024-10-10 | 489 | 150d | 0d | servente [200%]; pedreiro [400%] | 211.2h | 19,807.17 | 11. Casa 11 | 1. Pav. Superior | 10. Cer. Piso 1 | Própria | 10 | 10 | 10 |
| 510 | 1.3.11.2.12 | 11. Cer. Parede | 2d | 2024-12-27 | 2024-12-30 | 490 | 150d | 0d | pedreiro [400%]; servente [200%] | 105.6h | 4,238.82 | 11. Casa 11 | 1. Pav. Superior | 11. Cer. Parede 1 | Própria | 11 | 11 | 11 |
| 511 | 1.3.11.2.13 | 12. Forro (WC's e cozinha) | 1d | 2025-02-12 | 2025-02-12 | 491 | 134d | 0d | aux. gesseiro; gesseiro | 17.6h | 635.82 | 11. Casa 11 | 1. Pav. Superior | 12. Forro (WC's e cozinha) 1 | Própria | 12 | 12 | 12 |
| 512 | 1.3.11.2.14 | 13. Esq. Alumínio | 2d | 2025-03-21 | 2025-03-24 | 492 | 100d | 0d | montador esquadrias | 17.6h | 8,489.61 | 11. Casa 11 | 1. Pav. Superior | 13. Esq. Alumínio 1 | Própria | 13 | 13 | 13 |
| 513 | 1.3.11.2.15 | 14. Portas | 2d | 2025-03-26 | 2025-03-27 | 493 | 98d | 0d | marceneiro [200%] | 35.2h | 1,858.35 | 11. Casa 11 | 1. Pav. Superior | 14. Portas 1 | Própria | 14 | 14 | 14 |
| 514 | 1.3.11.2.16 | 15. Pintura (1ª Demão) | 4d | 2025-04-09 | 2025-04-14 | 494 | 18d | 0d | pintor [600%]; aux.pintor [300%] | 316.8h | 3,764.82 | 11. Casa 11 | 1. Pav. Superior | 15. Pintura (1ª Demão) 1 | Própria | 15 | 15 | 15 |
| 515 | 1.3.11.2.17 | 16. Bancadas | 1d | 2025-06-25 | 2025-06-25 | 495 | 49d | 0d | servente; pedreiro [200%] | 26.4h | 6,972.08 | 11. Casa 11 | 1. Pav. Superior | 16. Bancadas 1 | Própria | 16 | 16 | 16 |
| 516 | 1.3.11.2.18 | 17. Pintura (2ª Demão) | 3d | 2025-07-08 | 2025-07-10 | 496 | 18d | 0d | aux.pintor [300%]; pintor [600%] | 237.6h | 1,563.98 | 11. Casa 11 | 1. Pav. Superior | 17. Pintura (2ª Demão) 1 | Própria | 17 | 17 | 17 |
| 517 | 1.3.11.2.19 | 18. Limp. Interna | 1d | 2025-09-02 | 2025-09-02 | 497 | 0d |  | Diarista [200%] | 17.6h | 418.75 | 11. Casa 11 | 1. Pav. Superior | 18. Limp. Interna 1 | Própria | 18 | 18 | 18 |
| 518 | 1.3.11.3 | **2. Coberta** | 153d | 2024-01-11 | 2024-08-23 |  | 150d |  |  | 536.8h | 58,163.18 |  |  |  |  |  |  |  |
| 519 | 1.3.11.3.1 | 1. Alvenarias | 3d | 2024-01-11 | 2024-01-15 | 500 | 349d | 0d | pedreiro [400%]; servente [400%] | 211.2h | 9,834.12 | 11. Casa 11 | 2. Coberta | 3. Alvenarias 1 | Própria |  |  |  |
| 520 | 1.3.11.3.2 | 2. Impermeabilização | 1d | 2024-08-23 | 2024-08-23 | 503 | -2d | 0d | aplicador de manta | 8.8h | 24,164.53 | 11. Casa 11 | 2. Coberta | 7. Impermeabilização 1 | Própria |  |  |  |
| 521 | 1.3.11.3.3 | 3. Coberta | 6d | 2024-05-21 | 2024-05-28 | 474 | 295d | 0d | carpinteiro [400%]; aux. Carpinteiro [200%] | 316.8h | 24,164.53 | 11. Casa 11 | 2. Coberta | 4. Coberta 1 | Própria |  |  |  |

| ID | WBS | Task | Duration | Start | Finish | Predecessors | Total slack | Free slack | Resources | Work | Cost | Casa | Pav | Equipe | Empresa | Pacote | Cor | LB |
| --- | --- | --- | --- | --- | --- | --- | --- | --- | --- | --- | --- | --- | --- | --- | --- | --- | --- | --- |
| 522 | 1.3.12 | **12. Casa 12** | 495d | 2023-08-30 | 2025-09-04 |  | 8d |  |  | 7594.4h | 338,552.33 |  |  |  |  |  |  |  |
| 523 | 1.3.12.1 | **0. Térreo** | 494d | 2023-08-30 | 2025-09-03 |  | 9d |  |  | 3801.6h | 165,768.43 |  |  |  |  |  |  |  |
| 524 | 1.3.12.1.1 | 0. Locação | 2d | 2023-08-30 | 2023-08-31 | 477 | 805d | 0d | carpinteiro; aux. Carpinteiro | 35.2h | 456.99 | 12. Casa 12 | 0. Térreo | 0. Locação 1 | Própria |  |  |  |
| 525 | 1.3.12.1.2 | 1. Fundação | 9d | 2023-10-03 | 2023-10-16 | 478 | 747d | 0d | servente estrutura [300%]; aux. Carpinteiro; aux. ferreiro; ferreiro; carpinteiro [200%] | 633.6h | 19,882.86 | 12. Casa 12 | 0. Térreo | 1. Fundação 1 | Própria |  |  |  |
| 526 | 1.3.12.1.3 | 2. Estrutura | 7d | 2023-12-06 | 2023-12-14 | 499 | 367d | 0d | servente estrutura [300%]; aux. Carpinteiro [200%]; aux. ferreiro [200%]; ferreiro [500%]; carpinteiro [200%] | 862.4h | 46,439.03 | 12. Casa 12 | 0. Térreo | 2. Estrutura 1 | Própria |  |  |  |
| 527 | 1.3.12.1.4 | 3. Alvenarias | 5d | 2024-01-16 | 2024-01-22 | 519 | 349d | 0d | pedreiro [400%]; servente [400%] | 352h | 8,388.41 | 12. Casa 12 | 0. Térreo | 3. Alvenarias 1 | Própria |  |  |  |
| 528 | 1.3.12.1.5 | 5. Ref. Inter. Arg (Parede) | 3d | 2024-06-13 | 2024-06-17 | 501 | 274d | 0d | pedreiro [600%]; servente [600%] | 316.8h | 5,776 | 12. Casa 12 | 0. Térreo | 5. Ref. Inter. Arg (Parede) 1 | Própria |  |  |  |
| 529 | 1.3.12.1.6 | 6. Revest. Gesso (Parede + Teto) | 3d | 2024-06-24 | 2024-06-27 | 549SF | 306d | 0d | gesseiro [400%]; aux. gesseiro [200%] | 158.4h | 2,119.41 | 12. Casa 12 | 0. Térreo | 6. Revest. Gesso (Parede + Teto) 1 | Própria |  |  |  |
| 530 | 1.3.12.1.7 | 7. Impermeabilização | 2d | 2024-08-26 | 2024-08-27 | 520 | -2d | 0d | aplicador de manta | 17.6h | 3,288.15 | 12. Casa 12 | 0. Térreo | 7. Impermeabilização 1 | Própria |  |  |  |
| 531 | 1.3.12.1.8 | 8. Contrapiso | 2d | 2024-09-03 | 2024-09-05 | 598SF | 0d |  | pedreiro [200%]; servente | 52.8h | 3,735.07 | 12. Casa 12 | 0. Térreo | 8. Contrapiso 1 | Própria |  |  |  |
| 532 | 1.3.12.1.9 | 9.1. Chapisco | 0.5d | 2024-10-10 | 2024-10-10 | 505 | 84.5d | 0d | pedreiro [600%]; servente [400%] | 44h | 5,131.51 | 12. Casa 12 | 0. Térreo | 9. Fachada 1 | Própria |  |  |  |
| 533 | 1.3.12.1.10 | 9.2. Emboço | 1.5d | 2024-12-05 | 2024-12-06 | 553 | 84.5d | 0d | pedreiro [600%]; servente [400%] | 132h | 7,697.26 | 12. Casa 12 | 0. Térreo | 9. Fachada 1 | Própria |  |  |  |
| 534 | 1.3.12.1.11 | 9.3. Pint. 1 Demão | 1d | 2025-01-27 | 2025-01-28 | 554 | 84.5d | 0d | pintor [400%]; aux.pintor [200%] | 52.8h | 1,135.92 | 12. Casa 12 | 0. Térreo | 9. Fachada 1 | Própria |  |  |  |
| 535 | 1.3.12.1.12 | 9.4. Pint. 2 Demão | 2d | 2025-04-22 | 2025-04-24 | 555 | 84.5d | 0d | pintor [400%]; aux.pintor [200%] | 105.6h | 757.28 | 12. Casa 12 | 0. Térreo | 9. Fachada 1 | Própria |  |  |  |
| 536 | 1.3.12.1.13 | 10. Cer. Piso | 4d | 2024-10-11 | 2024-10-16 | 509 | 150d | 0d | pedreiro [400%]; servente [200%] | 211.2h | 25,485.98 | 12. Casa 12 | 0. Térreo | 10. Cer. Piso 1 | Própria | 10 | 10 | 10 |
| 537 | 1.3.12.1.14 | 11. Cer. Parede | 3d | 2024-12-31 | 2025-01-03 | 510 | 150d | 0d | pedreiro [400%]; servente [200%] | 158.4h | 4,238.82 | 12. Casa 12 | 0. Térreo | 11. Cer. Parede 1 | Própria | 11 | 11 | 11 |
| 538 | 1.3.12.1.15 | 12. Forro (WC's e cozinha) | 1d | 2025-02-13 | 2025-02-13 | 511 | 134d | 0d | gesseiro; aux. gesseiro | 17.6h | 895 | 12. Casa 12 | 0. Térreo | 12. Forro (WC's e cozinha) 1 | Própria | 12 | 12 | 12 |
| 539 | 1.3.12.1.16 | 13. Esq. Alumínio | 2d | 2025-03-26 | 2025-03-27 | 512 | 100d | 0d | montador esquadrias | 17.6h | 11,307.22 | 12. Casa 12 | 0. Térreo | 13. Esq. Alumínio 1 | Própria | 13 | 13 | 13 |
| 540 | 1.3.12.1.17 | 14. Portas | 2d | 2025-03-28 | 2025-03-31 | 513 | 98d | 0d | marceneiro [200%] | 35.2h | 2,827.85 | 12. Casa 12 | 0. Térreo | 14. Portas 1 | Própria | 14 | 14 | 14 |
| 541 | 1.3.12.1.18 | 15. Pintura (1ª Demão) | 4d | 2025-04-15 | 2025-04-22 | 514 | 18d | 0d | pintor [600%]; aux.pintor [300%] | 316.8h | 3,764.82 | 12. Casa 12 | 0. Térreo | 15. Pintura (1ª Demão) 1 | Própria | 15 | 15 | 15 |
| 542 | 1.3.12.1.19 | 16. Bancadas | 1d | 2025-06-26 | 2025-06-26 | 515 | 49d | 0d | pedreiro [200%]; servente | 26.4h | 10,458.12 | 12. Casa 12 | 0. Térreo | 16. Bancadas 1 | Própria | 16 | 16 | 16 |
| 543 | 1.3.12.1.20 | 17. Pintura (2ª Demão) | 3d | 2025-07-11 | 2025-07-15 | 516 | 18d | 0d | aux.pintor [300%]; pintor [600%] | 237.6h | 1,563.98 | 12. Casa 12 | 0. Térreo | 17. Pintura (2ª Demão) 1 | Própria | 17 | 17 | 17 |
| 544 | 1.3.12.1.21 | 18. Limp. Interna | 1d | 2025-09-03 | 2025-09-03 | 517 | 0d |  | Diarista [200%] | 17.6h | 418.75 | 12. Casa 12 | 0. Térreo | 18. Limp. Interna 1 | Própria | 18 | 18 | 18 |
| 545 | 1.3.12.2 | **1. Pav. Superior** | 422d | 2023-12-15 | 2025-09-04 |  | 8d |  |  | 3256h | 114,620.72 |  |  |  |  |  |  |  |
| 546 | 1.3.12.2.1 | 2. Estrutura | 7d | 2023-12-15 | 2024-01-02 | 526 | 367d | 0d | servente estrutura [300%]; aux. Carpinteiro [200%]; aux. ferreiro [200%]; ferreiro [500%]; carpinteiro [200%] | 862.4h | 30,006.55 | 12. Casa 12 | 1. Pav. Superior | 2. Estrutura 1 | Própria |  |  |  |
| 547 | 1.3.12.2.2 | 3. Alvenarias | 5d | 2024-01-23 | 2024-01-29 | 527 | 349d | 0d | servente [400%]; pedreiro [400%] | 352h | 10,101.74 | 12. Casa 12 | 1. Pav. Superior | 3. Alvenarias 1 | Própria |  |  |  |
| 548 | 1.3.12.2.3 | 5. Ref. Inter. Arg (Parede) | 4d | 2024-06-18 | 2024-06-21 | 528 | 274d | 0d | pedreiro [600%]; servente [600%] | 422.4h | 5,398.69 | 12. Casa 12 | 1. Pav. Superior | 5. Ref. Inter. Arg (Parede) 1 | Própria |  |  |  |
| 549 | 1.3.12.2.4 | 6. Revest. Gesso (Parede + Teto) | 4d | 2024-06-27 | 2024-07-03 | 576SF | 302d | 0d | aux. gesseiro [200%]; gesseiro [400%] | 211.2h | 2,119.41 | 12. Casa 12 | 1. Pav. Superior | 6. Revest. Gesso (Parede + Teto) 1 | Própria |  |  |  |
| 550 | 1.3.12.2.5 | 7. Impermeabilização | 1d | 2024-08-28 | 2024-08-28 | 530 | -2d | 0d | gesseiro [300%]; servente | 35.2h | 2,046.85 | 12. Casa 12 | 1. Pav. Superior | 7. Impermeabilização 1 | Própria |  |  |  |
| 551 | 1.3.12.2.6 | 8. Contrapiso | 2d | 2024-08-30 | 2024-09-03 | 531SF | 0d |  | pedreiro [200%]; servente | 52.8h | 2,476.11 | 12. Casa 12 | 1. Pav. Superior | 8. Contrapiso 1 | Própria |  |  |  |
| 552 | 1.3.12.2.7 | 9.1. Chapisco | 0.5d | 2024-10-10 | 2024-10-10 | 532 | 84.5d | 0d | pedreiro [600%]; servente [400%] | 44h | 5,131.51 | 12. Casa 12 | 1. Pav. Superior | 9. Fachada 1 | Própria |  |  |  |
| 553 | 1.3.12.2.8 | 9.2. Emboço | 1.5d | 2024-12-04 | 2024-12-05 | 486 | 84.5d | 0d | pedreiro [600%]; servente [400%] | 132h | 7,697.26 | 12. Casa 12 | 1. Pav. Superior | 9. Fachada 1 | Própria |  |  |  |
| 554 | 1.3.12.2.9 | 9.3. Pint. 1 Demão | 1d | 2025-01-24 | 2025-01-27 | 487 | 84.5d | 0d | pintor [400%]; aux.pintor [200%] | 52.8h | 1,135.92 | 12. Casa 12 | 1. Pav. Superior | 9. Fachada 1 | Própria |  |  |  |
| 555 | 1.3.12.2.10 | 9.4. Pint. 2 Demão | 2d | 2025-04-16 | 2025-04-22 | 488 | 84.5d | 0d | pintor [400%]; aux.pintor [200%] | 105.6h | 757.28 | 12. Casa 12 | 1. Pav. Superior | 9. Fachada 1 | Própria |  |  |  |
| 556 | 1.3.12.2.11 | 10. Cer. Piso | 4d | 2024-10-17 | 2024-10-22 | 536 | 150d | 0d | pedreiro [400%]; servente [200%] | 211.2h | 19,807.17 | 12. Casa 12 | 1. Pav. Superior | 10. Cer. Piso 1 | Própria | 10 | 10 | 10 |
| 557 | 1.3.12.2.12 | 11. Cer. Parede | 2d | 2025-01-06 | 2025-01-07 | 537 | 150d | 0d | pedreiro [400%]; servente [200%] | 105.6h | 4,238.82 | 12. Casa 12 | 1. Pav. Superior | 11. Cer. Parede 1 | Própria | 11 | 11 | 11 |
| 558 | 1.3.12.2.13 | 12. Forro (WC's e cozinha) | 1d | 2025-02-14 | 2025-02-14 | 538 | 134d | 0d | aux. gesseiro; gesseiro | 17.6h | 635.82 | 12. Casa 12 | 1. Pav. Superior | 12. Forro (WC's e cozinha) 1 | Própria | 12 | 12 | 12 |
| 559 | 1.3.12.2.14 | 13. Esq. Alumínio | 2d | 2025-03-28 | 2025-03-31 | 539 | 100d | 0d | montador esquadrias | 17.6h | 8,489.61 | 12. Casa 12 | 1. Pav. Superior | 13. Esq. Alumínio 1 | Própria | 13 | 13 | 13 |
| 560 | 1.3.12.2.15 | 14. Portas | 2d | 2025-04-01 | 2025-04-02 | 540 | 98d | 0d | marceneiro [200%] | 35.2h | 1,858.35 | 12. Casa 12 | 1. Pav. Superior | 14. Portas 1 | Própria | 14 | 14 | 14 |
| 561 | 1.3.12.2.16 | 15. Pintura (1ª Demão) | 4d | 2025-04-23 | 2025-04-28 | 541 | 18d | 0d | pintor [600%]; aux.pintor [300%] | 316.8h | 3,764.82 | 12. Casa 12 | 1. Pav. Superior | 15. Pintura (1ª Demão) 1 | Própria | 15 | 15 | 15 |
| 562 | 1.3.12.2.17 | 16. Bancadas | 1d | 2025-06-27 | 2025-06-27 | 542 | 49d | 0d | servente; pedreiro [200%] | 26.4h | 6,972.08 | 12. Casa 12 | 1. Pav. Superior | 16. Bancadas 1 | Própria | 16 | 16 | 16 |
| 563 | 1.3.12.2.18 | 17. Pintura (2ª Demão) | 3d | 2025-07-16 | 2025-07-18 | 543 | 18d | 0d | aux.pintor [300%]; pintor [600%] | 237.6h | 1,563.98 | 12. Casa 12 | 1. Pav. Superior | 17. Pintura (2ª Demão) 1 | Própria | 17 | 17 | 17 |
| 564 | 1.3.12.2.19 | 18. Limp. Interna | 1d | 2025-09-04 | 2025-09-04 | 544 | 0d |  | Diarista [200%] | 17.6h | 418.75 | 12. Casa 12 | 1. Pav. Superior | 18. Limp. Interna 1 | Própria | 18 | 18 | 18 |

| ID | WBS | Task | Duration | Start | Finish | Predecessors | Total slack | Free slack | Resources | Work | Cost | Casa | Pav | Equipe | Empresa | Pacote | Cor | LB |
| --- | --- | --- | --- | --- | --- | --- | --- | --- | --- | --- | --- | --- | --- | --- | --- | --- | --- | --- |
| 565 | 1.3.12.3 | **2. Coberta** | 144d | 2024-01-30 | 2024-08-29 |  | 141d |  |  | 536.8h | 58,163.18 |  |  |  |  |  |  |  |
| 566 | 1.3.12.3.1 | 1. Alvenarias | 3d | 2024-01-30 | 2024-02-01 | 547 | 349d | 0d | pedreiro [400%]; servente [400%] | 211.2h | 9,834.12 | 12. Casa 12 | 2. Coberta | 3. Alvenarias 1 | Própria |  |  |  |
| 567 | 1.3.12.3.2 | 2. Impermeabilização | 1d | 2024-08-29 | 2024-08-29 | 550 | -2d | 0d | aplicador de manta | 8.8h | 24,164.53 | 12. Casa 12 | 2. Coberta | 7. Impermeabilização 1 | Própria |  |  |  |
| 568 | 1.3.12.3.3 | 3. Coberta | 6d | 2024-05-29 | 2024-06-07 | 521 | 295d | 0d | carpinteiro [400%]; aux. Carpinteiro [200%] | 316.8h | 24,164.53 | 12. Casa 12 | 2. Coberta | 4. Coberta 1 | Própria |  |  |  |
| 569 | 1.3.13 | **13. Casa 13** | 495d | 2023-09-01 | 2025-09-08 |  | 6d |  |  | 7594.4h | 338,552.33 |  |  |  |  |  |  |  |
| 570 | 1.3.13.1 | **0. Térreo** | 494d | 2023-09-01 | 2025-09-05 |  | 7d |  |  | 3801.6h | 165,509.25 |  |  |  |  |  |  |  |
| 571 | 1.3.13.1.1 | 0. Locação | 2d | 2023-09-01 | 2023-09-04 | 524 | 805d | 0d | carpinteiro; aux. Carpinteiro | 35.2h | 456.99 | 13. Casa 13 | 0. Térreo | 0. Locação 1 | Própria |  |  |  |
| 572 | 1.3.13.1.2 | 1. Fundação | 9d | 2023-10-17 | 2023-10-27 | 525 | 747d | 0d | servente estrutura [300%]; aux. Carpinteiro; aux. ferreiro; ferreiro; carpinteiro [200%] | 633.6h | 19,882.86 | 13. Casa 13 | 0. Térreo | 1. Fundação 1 | Própria |  |  |  |
| 573 | 1.3.13.1.3 | 2. Estrutura | 7d | 2024-01-03 | 2024-01-11 | 546 | 367d | 0d | servente estrutura [300%]; aux. Carpinteiro [200%]; aux. ferreiro [200%]; ferreiro [500%]; carpinteiro [200%] | 862.4h | 46,439.03 | 13. Casa 13 | 0. Térreo | 2. Estrutura 1 | Própria |  |  |  |
| 574 | 1.3.13.1.4 | 3. Alvenarias | 5d | 2024-02-02 | 2024-02-08 | 566 | 349d | 0d | pedreiro [400%]; servente [400%] | 352h | 8,388.41 | 13. Casa 13 | 0. Térreo | 3. Alvenarias 1 | Própria |  |  |  |
| 575 | 1.3.13.1.5 | 5. Ref. Inter. Arg (Parede) | 3d | 2024-06-24 | 2024-06-26 | 548 | 274d | 0d | pedreiro [600%]; servente [600%] | 316.8h | 5,776 | 13. Casa 13 | 0. Térreo | 5. Ref. Inter. Arg (Parede) 1 | Própria |  |  |  |
| 576 | 1.3.13.1.6 | 6. Revest. Gesso (Parede + Teto) | 3d | 2024-07-03 | 2024-07-08 | 596SF | 299d | 0d | gesseiro [400%]; aux. gesseiro [200%] | 158.4h | 2,119.41 | 13. Casa 13 | 0. Térreo | 6. Revest. Gesso (Parede + Teto) 1 | Própria |  |  |  |
| 577 | 1.3.13.1.7 | 7. Impermeabilização | 2d | 2024-08-30 | 2024-09-02 | 567 | -2d | 0d | aplicador de manta | 17.6h | 3,288.15 | 13. Casa 13 | 0. Térreo | 7. Impermeabilização 1 | Própria |  |  |  |
| 578 | 1.3.13.1.8 | 8. Contrapiso | 2d | 2024-09-09 | 2024-09-11 | 645SF | 0d |  | pedreiro [200%]; servente | 52.8h | 3,735.07 | 13. Casa 13 | 0. Térreo | 8. Contrapiso 1 | Própria |  |  |  |
| 579 | 1.3.13.1.9 | 9.1. Chapisco | 0.5d | 2024-10-11 | 2024-10-11 | 552 | 84.5d | 0d | pedreiro [600%]; servente [400%] | 44h | 5,131.51 | 13. Casa 13 | 0. Térreo | 9. Fachada 1 | Própria |  |  |  |
| 580 | 1.3.13.1.10 | 9.2. Emboço | 1.5d | 2024-12-10 | 2024-12-11 | 600 | 84.5d | 0d | pedreiro [600%]; servente [400%] | 132h | 7,697.26 | 13. Casa 13 | 0. Térreo | 9. Fachada 1 | Própria |  |  |  |
| 581 | 1.3.13.1.11 | 9.3. Pint. 1 Demão | 1d | 2025-01-29 | 2025-01-30 | 601 | 84.5d | 0d | pintor [400%]; aux.pintor [200%] | 52.8h | 1,135.92 | 13. Casa 13 | 0. Térreo | 9. Fachada 1 | Própria |  |  |  |
| 582 | 1.3.13.1.12 | 9.4. Pint. 2 Demão | 2d | 2025-04-28 | 2025-04-30 | 602 | 84.5d | 0d | pintor [400%]; aux.pintor [200%] | 105.6h | 757.28 | 13. Casa 13 | 0. Térreo | 9. Fachada 1 | Própria |  |  |  |
| 583 | 1.3.13.1.13 | 10. Cer. Piso | 4d | 2024-10-23 | 2024-10-28 | 556 | 150d | 0d | pedreiro [400%]; servente [200%] | 211.2h | 25,485.98 | 13. Casa 13 | 0. Térreo | 10. Cer. Piso 1 | Própria | 10 | 10 | 10 |
| 584 | 1.3.13.1.14 | 11. Cer. Parede | 3d | 2025-01-08 | 2025-01-10 | 557 | 150d | 0d | pedreiro [400%]; servente [200%] | 158.4h | 4,238.82 | 13. Casa 13 | 0. Térreo | 11. Cer. Parede 1 | Própria | 11 | 11 | 11 |
| 585 | 1.3.13.1.15 | 12. Forro (WC's e cozinha) | 1d | 2025-02-17 | 2025-02-17 | 558 | 134d | 0d | gesseiro; aux. gesseiro | 17.6h | 635.82 | 13. Casa 13 | 0. Térreo | 12. Forro (WC's e cozinha) 1 | Própria | 12 | 12 | 12 |
| 586 | 1.3.13.1.16 | 13. Esq. Alumínio | 2d | 2025-04-01 | 2025-04-02 | 559 | 100d | 0d | montador esquadrias | 17.6h | 11,307.22 | 13. Casa 13 | 0. Térreo | 13. Esq. Alumínio 1 | Própria | 13 | 13 | 13 |
| 587 | 1.3.13.1.17 | 14. Portas | 2d | 2025-04-03 | 2025-04-04 | 560 | 98d | 0d | marceneiro [200%] | 35.2h | 2,827.85 | 13. Casa 13 | 0. Térreo | 14. Portas 1 | Própria | 14 | 14 | 14 |
| 588 | 1.3.13.1.18 | 15. Pintura (1ª Demão) | 4d | 2025-04-29 | 2025-05-05 | 561 | 18d | 0d | pintor [600%]; aux.pintor [300%] | 316.8h | 3,764.82 | 13. Casa 13 | 0. Térreo | 15. Pintura (1ª Demão) 1 | Própria | 15 | 15 | 15 |
| 589 | 1.3.13.1.19 | 16. Bancadas | 1d | 2025-06-30 | 2025-06-30 | 562 | 49d | 0d | pedreiro [200%]; servente | 26.4h | 10,458.12 | 13. Casa 13 | 0. Térreo | 16. Bancadas 1 | Própria | 16 | 16 | 16 |
| 590 | 1.3.13.1.20 | 17. Pintura (2ª Demão) | 3d | 2025-07-21 | 2025-07-23 | 563 | 18d | 0d | aux.pintor [300%]; pintor [600%] | 237.6h | 1,563.98 | 13. Casa 13 | 0. Térreo | 17. Pintura (2ª Demão) 1 | Própria | 17 | 17 | 17 |
| 591 | 1.3.13.1.21 | 18. Limp. Interna | 1d | 2025-09-05 | 2025-09-05 | 564 | 0d |  | Diarista [200%] | 17.6h | 418.75 | 13. Casa 13 | 0. Térreo | 18. Limp. Interna 1 | Própria | 18 | 18 | 18 |

| ID | WBS | Task | Duration | Start | Finish | Predecessors | Total slack | Free slack | Resources | Work | Cost | Casa | Pav | Equipe | Empresa | Pacote | Cor | LB |
| --- | --- | --- | --- | --- | --- | --- | --- | --- | --- | --- | --- | --- | --- | --- | --- | --- | --- | --- |
| 592 | 1.3.13.2 | **1. Pav. Superior** | 410d | 2024-01-12 | 2025-09-08 |  | 6d |  |  | 3256h | 114,879.9 |  |  |  |  |  |  |  |
| 593 | 1.3.13.2.1 | 2. Estrutura | 7d | 2024-01-12 | 2024-01-22 | 573 | 367d | 0d | servente estrutura [300%]; aux. Carpinteiro [200%]; aux. ferreiro [200%]; ferreiro [500%]; carpinteiro [200%] | 862.4h | 30,006.55 | 13. Casa 13 | 1. Pav. Superior | 2. Estrutura 1 | Própria |  |  |  |
| 594 | 1.3.13.2.2 | 3. Alvenarias | 5d | 2024-02-09 | 2024-02-20 | 574 | 349d | 0d | servente [400%]; pedreiro [400%] | 352h | 10,101.74 | 13. Casa 13 | 1. Pav. Superior | 3. Alvenarias 1 | Própria |  |  |  |
| 595 | 1.3.13.2.3 | 5. Ref. Inter. Arg (Parede) | 4d | 2024-06-27 | 2024-07-02 | 575 | 274d | 0d | pedreiro [600%]; servente [600%] | 422.4h | 5,398.69 | 13. Casa 13 | 1. Pav. Superior | 5. Ref. Inter. Arg (Parede) 1 | Própria |  |  |  |
| 596 | 1.3.13.2.4 | 6. Revest. Gesso (Parede + Teto) | 4d | 2024-07-08 | 2024-07-12 | 623SF | 295d | 0d | aux. gesseiro [200%]; gesseiro [400%] | 211.2h | 2,119.41 | 13. Casa 13 | 1. Pav. Superior | 6. Revest. Gesso (Parede + Teto) 1 | Própria |  |  |  |
| 597 | 1.3.13.2.5 | 7. Impermeabilização | 1d | 2024-09-03 | 2024-09-03 | 577 | -2d | 0d | gesseiro [300%]; servente | 35.2h | 2,046.85 | 13. Casa 13 | 1. Pav. Superior | 7. Impermeabilização 1 | Própria |  |  |  |
| 598 | 1.3.13.2.6 | 8. Contrapiso | 2d | 2024-09-05 | 2024-09-09 | 578SF | 0d |  | pedreiro [200%]; servente | 52.8h | 2,476.11 | 13. Casa 13 | 1. Pav. Superior | 8. Contrapiso 1 | Própria |  |  |  |
| 599 | 1.3.13.2.7 | 9.1. Chapisco | 0.5d | 2024-10-11 | 2024-10-11 | 579 | 84.5d | 0d | pedreiro [600%]; servente [400%] | 44h | 5,131.51 | 13. Casa 13 | 1. Pav. Superior | 9. Fachada 1 | Própria |  |  |  |
| 600 | 1.3.13.2.8 | 9.2. Emboço | 1.5d | 2024-12-09 | 2024-12-10 | 533 | 84.5d | 0d | pedreiro [600%]; servente [400%] | 132h | 7,697.26 | 13. Casa 13 | 1. Pav. Superior | 9. Fachada 1 | Própria |  |  |  |
| 601 | 1.3.13.2.9 | 9.3. Pint. 1 Demão | 1d | 2025-01-28 | 2025-01-29 | 534 | 84.5d | 0d | pintor [400%]; aux.pintor [200%] | 52.8h | 1,135.92 | 13. Casa 13 | 1. Pav. Superior | 9. Fachada 1 | Própria |  |  |  |
| 602 | 1.3.13.2.10 | 9.4. Pint. 2 Demão | 2d | 2025-04-24 | 2025-04-28 | 535 | 84.5d | 0d | pintor [400%]; aux.pintor [200%] | 105.6h | 757.28 | 13. Casa 13 | 1. Pav. Superior | 9. Fachada 1 | Própria |  |  |  |
| 603 | 1.3.13.2.11 | 10. Cer. Piso | 4d | 2024-10-29 | 2024-11-01 | 583 | 150d | 0d | servente [200%]; pedreiro [400%] | 211.2h | 19,807.17 | 13. Casa 13 | 1. Pav. Superior | 10. Cer. Piso 1 | Própria | 10 | 10 | 10 |
| 604 | 1.3.13.2.12 | 11. Cer. Parede | 2d | 2025-01-13 | 2025-01-14 | 584 | 150d | 0d | pedreiro [400%]; servente [200%] | 105.6h | 4,238.82 | 13. Casa 13 | 1. Pav. Superior | 11. Cer. Parede 1 | Própria | 11 | 11 | 11 |
| 605 | 1.3.13.2.13 | 12. Forro (WC's e cozinha) | 1d | 2025-02-18 | 2025-02-18 | 585 | 134d | 0d | aux. gesseiro; gesseiro | 17.6h | 895 | 13. Casa 13 | 1. Pav. Superior | 12. Forro (WC's e cozinha) 1 | Própria | 12 | 12 | 12 |
| 606 | 1.3.13.2.14 | 13. Esq. Alumínio | 2d | 2025-04-03 | 2025-04-04 | 586 | 100d | 0d | montador esquadrias | 17.6h | 8,489.61 | 13. Casa 13 | 1. Pav. Superior | 13. Esq. Alumínio 1 | Própria | 13 | 13 | 13 |
| 607 | 1.3.13.2.15 | 14. Portas | 2d | 2025-04-07 | 2025-04-08 | 587 | 98d | 0d | marceneiro [200%] | 35.2h | 1,858.35 | 13. Casa 13 | 1. Pav. Superior | 14. Portas 1 | Própria | 14 | 14 | 14 |
| 608 | 1.3.13.2.16 | 15. Pintura (1ª Demão) | 4d | 2025-05-06 | 2025-05-09 | 588 | 18d | 0d | pintor [600%]; aux.pintor [300%] | 316.8h | 3,764.82 | 13. Casa 13 | 1. Pav. Superior | 15. Pintura (1ª Demão) 1 | Própria | 15 | 15 | 15 |
| 609 | 1.3.13.2.17 | 16. Bancadas | 1d | 2025-07-01 | 2025-07-01 | 589 | 49d | 0d | servente; pedreiro [200%] | 26.4h | 6,972.08 | 13. Casa 13 | 1. Pav. Superior | 16. Bancadas 1 | Própria | 16 | 16 | 16 |
| 610 | 1.3.13.2.18 | 17. Pintura (2ª Demão) | 3d | 2025-07-24 | 2025-07-28 | 590 | 18d | 0d | aux.pintor [300%]; pintor [600%] | 237.6h | 1,563.98 | 13. Casa 13 | 1. Pav. Superior | 17. Pintura (2ª Demão) 1 | Própria | 17 | 17 | 17 |
| 611 | 1.3.13.2.19 | 18. Limp. Interna | 1d | 2025-09-08 | 2025-09-08 | 591 | 0d |  | Diarista [200%] | 17.6h | 418.75 | 13. Casa 13 | 1. Pav. Superior | 18. Limp. Interna 1 | Própria | 18 | 18 | 18 |
| 612 | 1.3.13.3 | **2. Coberta** | 135d | 2024-02-21 | 2024-09-04 |  | 132d |  |  | 536.8h | 58,163.18 |  |  |  |  |  |  |  |
| 613 | 1.3.13.3.1 | 1. Alvenarias | 3d | 2024-02-21 | 2024-02-23 | 594 | 349d | 0d | pedreiro [400%]; servente [400%] | 211.2h | 9,834.12 | 13. Casa 13 | 2. Coberta | 3. Alvenarias 1 | Própria |  |  |  |
| 614 | 1.3.13.3.2 | 2. Impermeabilização | 1d | 2024-09-04 | 2024-09-04 | 597 | -2d | 0d | aplicador de manta | 8.8h | 24,164.53 | 13. Casa 13 | 2. Coberta | 7. Impermeabilização 1 | Própria |  |  |  |
| 615 | 1.3.13.3.3 | 3. Coberta | 6d | 2024-06-10 | 2024-06-17 | 568 | 295d | 0d | carpinteiro [400%]; aux. Carpinteiro [200%] | 316.8h | 24,164.53 | 13. Casa 13 | 2. Coberta | 4. Coberta 1 | Própria |  |  |  |

| ID | WBS | Task | Duration | Start | Finish | Predecessors | Total slack | Free slack | Resources | Work | Cost | Casa | Pav | Equipe | Empresa | Pacote | Cor | LB |
| --- | --- | --- | --- | --- | --- | --- | --- | --- | --- | --- | --- | --- | --- | --- | --- | --- | --- | --- |
| 616 | 1.3.14 | **14. Casa 14** | 495d | 2023-09-05 | 2025-09-10 |  | 4d |  |  | 7594.4h | 338,552.33 |  |  |  |  |  |  |  |
| 617 | 1.3.14.1 | **0. Térreo** | 494d | 2023-09-05 | 2025-09-09 |  | 5d |  |  | 3801.6h | 165,509.25 |  |  |  |  |  |  |  |
| 618 | 1.3.14.1.1 | 0. Locação | 2d | 2023-09-05 | 2023-09-06 | 571 | 805d | 0d | carpinteiro; aux. Carpinteiro | 35.2h | 456.99 | 14. Casa 14 | 0. Térreo | 0. Locação 1 | Própria |  |  |  |
| 619 | 1.3.14.1.2 | 1. Fundação | 9d | 2023-10-30 | 2023-11-10 | 572 | 747d | 0d | servente estrutura [300%]; aux. Carpinteiro; aux. ferreiro; ferreiro; carpinteiro [200%] | 633.6h | 19,882.86 | 14. Casa 14 | 0. Térreo | 1. Fundação 1 | Própria |  |  |  |
| 620 | 1.3.14.1.3 | 2. Estrutura | 7d | 2024-01-23 | 2024-01-31 | 593 | 367d | 0d | servente estrutura [300%]; aux. Carpinteiro [200%]; aux. ferreiro [200%]; ferreiro [500%]; carpinteiro [200%] | 862.4h | 46,439.03 | 14. Casa 14 | 0. Térreo | 2. Estrutura 1 | Própria |  |  |  |
| 621 | 1.3.14.1.4 | 3. Alvenarias | 5d | 2024-02-26 | 2024-03-01 | 613 | 349d | 0d | pedreiro [400%]; servente [400%] | 352h | 8,388.41 | 14. Casa 14 | 0. Térreo | 3. Alvenarias 1 | Própria |  |  |  |
| 622 | 1.3.14.1.5 | 5. Ref. Inter. Arg (Parede) | 3d | 2024-07-03 | 2024-07-05 | 595 | 274d | 0d | pedreiro [600%]; servente [600%] | 316.8h | 5,776 | 14. Casa 14 | 0. Térreo | 5. Ref. Inter. Arg (Parede) 1 | Própria |  |  |  |
| 623 | 1.3.14.1.6 | 6. Revest. Gesso (Parede + Teto) | 3d | 2024-07-12 | 2024-07-17 | 643SF | 292d | 0d | gesseiro [400%]; aux. gesseiro [200%] | 158.4h | 2,119.41 | 14. Casa 14 | 0. Térreo | 6. Revest. Gesso (Parede + Teto) 1 | Própria |  |  |  |
| 624 | 1.3.14.1.7 | 7. Impermeabilização | 2d | 2024-09-05 | 2024-09-06 | 614 | -2d | 0d | aplicador de manta | 17.6h | 3,288.15 | 14. Casa 14 | 0. Térreo | 7. Impermeabilização 1 | Própria |  |  |  |
| 625 | 1.3.14.1.8 | 8. Contrapiso | 2d | 2024-09-13 | 2024-09-17 | 692SF | 0d |  | pedreiro [200%]; servente | 52.8h | 3,735.07 | 14. Casa 14 | 0. Térreo | 8. Contrapiso 1 | Própria |  |  |  |
| 626 | 1.3.14.1.9 | 9.1. Chapisco | 0.5d | 2024-10-14 | 2024-10-14 | 599 | 84.5d | 0d | pedreiro [600%]; servente [400%] | 44h | 5,131.51 | 14. Casa 14 | 0. Térreo | 9. Fachada 1 | Própria |  |  |  |
| 627 | 1.3.14.1.10 | 9.2. Emboço | 1.5d | 2024-12-13 | 2024-12-16 | 647 | 84.5d | 0d | pedreiro [600%]; servente [400%] | 132h | 7,697.26 | 14. Casa 14 | 0. Térreo | 9. Fachada 1 | Própria |  |  |  |
| 628 | 1.3.14.1.11 | 9.3. Pint. 1 Demão | 1d | 2025-01-31 | 2025-02-03 | 648 | 84.5d | 0d | pintor [400%]; aux.pintor [200%] | 52.8h | 1,135.92 | 14. Casa 14 | 0. Térreo | 9. Fachada 1 | Própria |  |  |  |
| 629 | 1.3.14.1.12 | 9.4. Pint. 2 Demão | 2d | 2025-05-05 | 2025-05-07 | 649 | 84.5d | 0d | pintor [400%]; aux.pintor [200%] | 105.6h | 757.28 | 14. Casa 14 | 0. Térreo | 9. Fachada 1 | Própria |  |  |  |
| 630 | 1.3.14.1.13 | 10. Cer. Piso | 4d | 2024-11-04 | 2024-11-07 | 603 | 150d | 0d | pedreiro [400%]; servente [200%] | 211.2h | 25,485.98 | 14. Casa 14 | 0. Térreo | 10. Cer. Piso 1 | Própria | 10 | 10 | 10 |
| 631 | 1.3.14.1.14 | 11. Cer. Parede | 3d | 2025-01-15 | 2025-01-17 | 604 | 150d | 0d | pedreiro [400%]; servente [200%] | 158.4h | 4,238.82 | 14. Casa 14 | 0. Térreo | 11. Cer. Parede 1 | Própria | 11 | 11 | 11 |
| 632 | 1.3.14.1.15 | 12. Forro (WC's e cozinha) | 1d | 2025-02-19 | 2025-02-19 | 605 | 134d | 0d | gesseiro; aux. gesseiro | 17.6h | 635.82 | 14. Casa 14 | 0. Térreo | 12. Forro (WC's e cozinha) 1 | Própria | 12 | 12 | 12 |
| 633 | 1.3.14.1.16 | 13. Esq. Alumínio | 2d | 2025-04-07 | 2025-04-08 | 606 | 100d | 0d | montador esquadrias | 17.6h | 11,307.22 | 14. Casa 14 | 0. Térreo | 13. Esq. Alumínio 1 | Própria | 13 | 13 | 13 |
| 634 | 1.3.14.1.17 | 14. Portas | 2d | 2025-04-09 | 2025-04-10 | 607 | 98d | 0d | marceneiro [200%] | 35.2h | 2,827.85 | 14. Casa 14 | 0. Térreo | 14. Portas 1 | Própria | 14 | 14 | 14 |
| 635 | 1.3.14.1.18 | 15. Pintura (1ª Demão) | 4d | 2025-05-12 | 2025-05-15 | 608 | 18d | 0d | pintor [600%]; aux.pintor [300%] | 316.8h | 3,764.82 | 14. Casa 14 | 0. Térreo | 15. Pintura (1ª Demão) 1 | Própria | 15 | 15 | 15 |
| 636 | 1.3.14.1.19 | 16. Bancadas | 1d | 2025-07-02 | 2025-07-02 | 609 | 49d | 0d | pedreiro [200%]; servente | 26.4h | 10,458.12 | 14. Casa 14 | 0. Térreo | 16. Bancadas 1 | Própria | 16 | 16 | 16 |
| 637 | 1.3.14.1.20 | 17. Pintura (2ª Demão) | 3d | 2025-07-29 | 2025-07-31 | 610 | 18d | 0d | aux.pintor [300%]; pintor [600%] | 237.6h | 1,563.98 | 14. Casa 14 | 0. Térreo | 17. Pintura (2ª Demão) 1 | Própria | 17 | 17 | 17 |
| 638 | 1.3.14.1.21 | 18. Limp. Interna | 1d | 2025-09-09 | 2025-09-09 | 611 | 0d |  | Diarista [200%] | 17.6h | 418.75 | 14. Casa 14 | 0. Térreo | 18. Limp. Interna 1 | Própria | 18 | 18 | 18 |
| 639 | 1.3.14.2 | **1. Pav. Superior** | 398d | 2024-02-01 | 2025-09-10 |  | 4d |  |  | 3256h | 114,879.9 |  |  |  |  |  |  |  |
| 640 | 1.3.14.2.1 | 2. Estrutura | 7d | 2024-02-01 | 2024-02-09 | 620 | 367d | 0d | servente estrutura [300%]; aux. Carpinteiro [200%]; aux. ferreiro [200%]; ferreiro [500%]; carpinteiro [200%] | 862.4h | 30,006.55 | 14. Casa 14 | 1. Pav. Superior | 2. Estrutura 1 | Própria |  |  |  |
| 641 | 1.3.14.2.2 | 3. Alvenarias | 5d | 2024-03-04 | 2024-03-08 | 621 | 349d | 0d | servente [400%]; pedreiro [400%] | 352h | 10,101.74 | 14. Casa 14 | 1. Pav. Superior | 3. Alvenarias 1 | Própria |  |  |  |
| 642 | 1.3.14.2.3 | 5. Ref. Inter. Arg (Parede) | 4d | 2024-07-08 | 2024-07-11 | 622 | 274d | 0d | pedreiro [600%]; servente [600%] | 422.4h | 5,398.69 | 14. Casa 14 | 1. Pav. Superior | 5. Ref. Inter. Arg (Parede) 1 | Própria |  |  |  |
| 643 | 1.3.14.2.4 | 6. Revest. Gesso (Parede + Teto) | 4d | 2024-07-17 | 2024-07-23 | 670SF | 288d | 0d | aux. gesseiro [200%]; gesseiro [400%] | 211.2h | 2,119.41 | 14. Casa 14 | 1. Pav. Superior | 6. Revest. Gesso (Parede + Teto) 1 | Própria |  |  |  |
| 644 | 1.3.14.2.5 | 7. Impermeabilização | 1d | 2024-09-09 | 2024-09-09 | 624 | -2d | 0d | gesseiro [300%]; servente | 35.2h | 2,046.85 | 14. Casa 14 | 1. Pav. Superior | 7. Impermeabilização 1 | Própria |  |  |  |
| 645 | 1.3.14.2.6 | 8. Contrapiso | 2d | 2024-09-11 | 2024-09-13 | 625SF | 0d |  | pedreiro [200%]; servente | 52.8h | 2,476.11 | 14. Casa 14 | 1. Pav. Superior | 8. Contrapiso 1 | Própria |  |  |  |
| 646 | 1.3.14.2.7 | 9.1. Chapisco | 0.5d | 2024-10-14 | 2024-10-14 | 626 | 84.5d | 0d | pedreiro [600%]; servente [400%] | 44h | 5,131.51 | 14. Casa 14 | 1. Pav. Superior | 9. Fachada 1 | Própria |  |  |  |
| 647 | 1.3.14.2.8 | 9.2. Emboço | 1.5d | 2024-12-12 | 2024-12-13 | 580 | 84.5d | 0d | pedreiro [600%]; servente [400%] | 132h | 7,697.26 | 14. Casa 14 | 1. Pav. Superior | 9. Fachada 1 | Própria |  |  |  |
| 648 | 1.3.14.2.9 | 9.3. Pint. 1 Demão | 1d | 2025-01-30 | 2025-01-31 | 581 | 84.5d | 0d | pintor [400%]; aux.pintor [200%] | 52.8h | 1,135.92 | 14. Casa 14 | 1. Pav. Superior | 9. Fachada 1 | Própria |  |  |  |
| 649 | 1.3.14.2.10 | 9.4. Pint. 2 Demão | 2d | 2025-04-30 | 2025-05-05 | 582 | 84.5d | 0d | pintor [400%]; aux.pintor [200%] | 105.6h | 757.28 | 14. Casa 14 | 1. Pav. Superior | 9. Fachada 1 | Própria |  |  |  |
| 650 | 1.3.14.2.11 | 10. Cer. Piso | 4d | 2024-11-08 | 2024-11-13 | 630 | 150d | 0d | pedreiro [400%]; servente [200%] | 211.2h | 19,807.17 | 14. Casa 14 | 1. Pav. Superior | 10. Cer. Piso 1 | Própria | 10 | 10 | 10 |
| 651 | 1.3.14.2.12 | 11. Cer. Parede | 2d | 2025-01-20 | 2025-01-21 | 631 | 150d | 0d | pedreiro [400%]; servente [200%] | 105.6h | 4,238.82 | 14. Casa 14 | 1. Pav. Superior | 11. Cer. Parede 1 | Própria | 11 | 11 | 11 |
| 652 | 1.3.14.2.13 | 12. Forro (WC's e cozinha) | 1d | 2025-02-20 | 2025-02-20 | 632 | 134d | 0d | aux. gesseiro; gesseiro | 17.6h | 895 | 14. Casa 14 | 1. Pav. Superior | 12. Forro (WC's e cozinha) 1 | Própria | 12 | 12 | 12 |
| 653 | 1.3.14.2.14 | 13. Esq. Alumínio | 2d | 2025-04-09 | 2025-04-10 | 633 | 100d | 0d | montador esquadrias | 17.6h | 8,489.61 | 14. Casa 14 | 1. Pav. Superior | 13. Esq. Alumínio 1 | Própria | 13 | 13 | 13 |
| 654 | 1.3.14.2.15 | 14. Portas | 2d | 2025-04-11 | 2025-04-14 | 634 | 98d | 0d | marceneiro [200%] | 35.2h | 1,858.35 | 14. Casa 14 | 1. Pav. Superior | 14. Portas 1 | Própria | 14 | 14 | 14 |
| 655 | 1.3.14.2.16 | 15. Pintura (1ª Demão) | 4d | 2025-05-16 | 2025-05-21 | 635 | 18d | 0d | pintor [600%]; aux.pintor [300%] | 316.8h | 3,764.82 | 14. Casa 14 | 1. Pav. Superior | 15. Pintura (1ª Demão) 1 | Própria | 15 | 15 | 15 |
| 656 | 1.3.14.2.17 | 16. Bancadas | 1d | 2025-07-03 | 2025-07-03 | 636 | 49d | 0d | servente; pedreiro [200%] | 26.4h | 6,972.08 | 14. Casa 14 | 1. Pav. Superior | 16. Bancadas 1 | Própria | 16 | 16 | 16 |
| 657 | 1.3.14.2.18 | 17. Pintura (2ª Demão) | 3d | 2025-08-01 | 2025-08-05 | 637 | 18d | 0d | aux.pintor [300%]; pintor [600%] | 237.6h | 1,563.98 | 14. Casa 14 | 1. Pav. Superior | 17. Pintura (2ª Demão) 1 | Própria | 17 | 17 | 17 |
| 658 | 1.3.14.2.19 | 18. Limp. Interna | 1d | 2025-09-10 | 2025-09-10 | 638 | 0d |  | Diarista [200%] | 17.6h | 418.75 | 14. Casa 14 | 1. Pav. Superior | 18. Limp. Interna 1 | Própria | 18 | 18 | 18 |

| ID | WBS | Task | Duration | Start | Finish | Predecessors | Total slack | Free slack | Resources | Work | Cost | Casa | Pav | Equipe | Empresa | Pacote | Cor | LB |
| --- | --- | --- | --- | --- | --- | --- | --- | --- | --- | --- | --- | --- | --- | --- | --- | --- | --- | --- |
| 659 | 1.3.14.3 | **2. Coberta** | 126d | 2024-03-11 | 2024-09-10 |  | 123d |  |  | 536.8h | 58,163.18 |  |  |  |  |  |  |  |
| 660 | 1.3.14.3.1 | 1. Alvenarias | 3d | 2024-03-11 | 2024-03-13 | 641 | 349d | 0d | pedreiro [400%]; servente [400%] | 211.2h | 9,834.12 | 14. Casa 14 | 2. Coberta | 3. Alvenarias 1 | Própria |  |  |  |
| 661 | 1.3.14.3.2 | 2. Impermeabilização | 1d | 2024-09-10 | 2024-09-10 | 644 | -2d | 0d | aplicador de manta | 8.8h | 24,164.53 | 14. Casa 14 | 2. Coberta | 7. Impermeabilização 1 | Própria |  |  |  |
| 662 | 1.3.14.3.3 | 3. Coberta | 6d | 2024-06-18 | 2024-06-25 | 615 | 295d | 0d | carpinteiro [400%]; aux. Carpinteiro [200%] | 316.8h | 24,164.53 | 14. Casa 14 | 2. Coberta | 4. Coberta 1 | Própria |  |  |  |
| 663 | 1.3.15 | **15. Casa 15** | 495d | 2023-09-08 | 2025-09-12 |  | 2d |  |  | 7594.4h | 338,552.33 |  |  |  |  |  |  |  |
| 664 | 1.3.15.1 | **0. Térreo** | 494d | 2023-09-08 | 2025-09-11 |  | 3d |  |  | 3801.6h | 165,509.25 |  |  |  |  |  |  |  |
| 665 | 1.3.15.1.1 | 0. Locação | 2d | 2023-09-08 | 2023-09-11 | 618 | 493d | 0d | carpinteiro; aux. Carpinteiro | 35.2h | 456.99 | 15. Casa 15 | 0. Térreo | 0. Locação 1 | Própria |  |  |  |
| 666 | 1.3.15.1.2 | 1. Fundação | 9d | 2023-11-13 | 2023-11-24 | 619 | 435d | 0d | servente estrutura [300%]; aux. Carpinteiro; aux. ferreiro; ferreiro; carpinteiro [200%] | 633.6h | 19,882.86 | 15. Casa 15 | 0. Térreo | 1. Fundação 1 | Própria |  |  |  |
| 667 | 1.3.15.1.3 | 2. Estrutura | 7d | 2024-02-15 | 2024-02-23 | 640 | 367d | 0d | servente estrutura [300%]; aux. Carpinteiro [200%]; aux. ferreiro [200%]; ferreiro [500%]; carpinteiro [200%] | 862.4h | 46,439.03 | 15. Casa 15 | 0. Térreo | 2. Estrutura 1 | Própria |  |  |  |
| 668 | 1.3.15.1.4 | 3. Alvenarias | 5d | 2024-03-14 | 2024-03-21 | 660 | 349d | 0d | pedreiro [400%]; servente [400%] | 352h | 8,388.41 | 15. Casa 15 | 0. Térreo | 3. Alvenarias 1 | Própria |  |  |  |
| 669 | 1.3.15.1.5 | 5. Ref. Inter. Arg (Parede) | 3d | 2024-07-12 | 2024-07-16 | 642 | 274d | 0d | pedreiro [600%]; servente [600%] | 316.8h | 5,776 | 15. Casa 15 | 0. Térreo | 5. Ref. Inter. Arg (Parede) 1 | Própria |  |  |  |
| 670 | 1.3.15.1.6 | 6. Revest. Gesso (Parede + Teto) | 3d | 2024-07-23 | 2024-07-26 | 690SF | 285d | 0d | gesseiro [400%]; aux. gesseiro [200%] | 158.4h | 2,119.41 | 15. Casa 15 | 0. Térreo | 6. Revest. Gesso (Parede + Teto) 1 | Própria |  |  |  |
| 671 | 1.3.15.1.7 | 7. Impermeabilização | 2d | 2024-09-11 | 2024-09-12 | 661 | -2d | 0d | aplicador de manta | 17.6h | 3,288.15 | 15. Casa 15 | 0. Térreo | 7. Impermeabilização 1 | Própria |  |  |  |
| 672 | 1.3.15.1.8 | 8. Contrapiso | 2d | 2024-09-19 | 2024-09-23 | 739SF | 0d |  | pedreiro [200%]; servente | 52.8h | 3,735.07 | 15. Casa 15 | 0. Térreo | 8. Contrapiso 1 | Própria |  |  |  |
| 673 | 1.3.15.1.9 | 9.1. Chapisco | 0.5d | 2024-10-15 | 2024-10-15 | 646 | 84.5d | 0d | pedreiro [600%]; servente [400%] | 44h | 5,131.51 | 15. Casa 15 | 0. Térreo | 9. Fachada 1 | Própria |  |  |  |
| 674 | 1.3.15.1.10 | 9.2. Emboço | 1.5d | 2024-12-18 | 2024-12-19 | 694 | 84.5d | 0d | pedreiro [600%]; servente [400%] | 132h | 7,697.26 | 15. Casa 15 | 0. Térreo | 9. Fachada 1 | Própria |  |  |  |
| 675 | 1.3.15.1.11 | 9.3. Pint. 1 Demão | 1d | 2025-02-04 | 2025-02-05 | 695 | 84.5d | 0d | pintor [400%]; aux.pintor [200%] | 52.8h | 1,135.92 | 15. Casa 15 | 0. Térreo | 9. Fachada 1 | Própria |  |  |  |
| 676 | 1.3.15.1.12 | 9.4. Pint. 2 Demão | 2d | 2025-05-09 | 2025-05-13 | 696 | 84.5d | 0d | pintor [400%]; aux.pintor [200%] | 105.6h | 757.28 | 15. Casa 15 | 0. Térreo | 9. Fachada 1 | Própria |  |  |  |
| 677 | 1.3.15.1.13 | 10. Cer. Piso | 4d | 2024-11-14 | 2024-11-20 | 650 | 150d | 0d | pedreiro [400%]; servente [200%] | 211.2h | 25,485.98 | 15. Casa 15 | 0. Térreo | 10. Cer. Piso 1 | Própria | 10 | 10 | 10 |
| 678 | 1.3.15.1.14 | 11. Cer. Parede | 3d | 2025-01-22 | 2025-01-24 | 651 | 150d | 0d | pedreiro [400%]; servente [200%] | 158.4h | 4,238.82 | 15. Casa 15 | 0. Térreo | 11. Cer. Parede 1 | Própria | 11 | 11 | 11 |
| 679 | 1.3.15.1.15 | 12. Forro (WC's e cozinha) | 1d | 2025-02-21 | 2025-02-21 | 652 | 134d | 0d | gesseiro; aux. gesseiro | 17.6h | 635.82 | 15. Casa 15 | 0. Térreo | 12. Forro (WC's e cozinha) 1 | Própria | 12 | 12 | 12 |
| 680 | 1.3.15.1.16 | 13. Esq. Alumínio | 2d | 2025-04-11 | 2025-04-14 | 653 | 100d | 0d | montador esquadrias | 17.6h | 11,307.22 | 15. Casa 15 | 0. Térreo | 13. Esq. Alumínio 1 | Própria | 13 | 13 | 13 |
| 681 | 1.3.15.1.17 | 14. Portas | 2d | 2025-04-15 | 2025-04-16 | 654 | 98d | 0d | marceneiro [200%] | 35.2h | 2,827.85 | 15. Casa 15 | 0. Térreo | 14. Portas 1 | Própria | 14 | 14 | 14 |
| 682 | 1.3.15.1.18 | 15. Pintura (1ª Demão) | 4d | 2025-05-22 | 2025-05-27 | 655 | 18d | 0d | pintor [600%]; aux.pintor [300%] | 316.8h | 3,764.82 | 15. Casa 15 | 0. Térreo | 15. Pintura (1ª Demão) 1 | Própria | 15 | 15 | 15 |
| 683 | 1.3.15.1.19 | 16. Bancadas | 1d | 2025-07-04 | 2025-07-04 | 656 | 49d | 0d | pedreiro [200%]; servente | 26.4h | 10,458.12 | 15. Casa 15 | 0. Térreo | 16. Bancadas 1 | Própria | 16 | 16 | 16 |
| 684 | 1.3.15.1.20 | 17. Pintura (2ª Demão) | 3d | 2025-08-06 | 2025-08-08 | 657 | 18d | 0d | aux.pintor [300%]; pintor [600%] | 237.6h | 1,563.98 | 15. Casa 15 | 0. Térreo | 17. Pintura (2ª Demão) 1 | Própria | 17 | 17 | 17 |
| 685 | 1.3.15.1.21 | 18. Limp. Interna | 1d | 2025-09-11 | 2025-09-11 | 658 | 0d |  | Diarista [200%] | 17.6h | 418.75 | 15. Casa 15 | 0. Térreo | 18. Limp. Interna 1 | Própria | 18 | 18 | 18 |

| ID | WBS | Task | Duration | Start | Finish | Predecessors | Total slack | Free slack | Resources | Work | Cost | Casa | Pav | Equipe | Empresa | Pacote | Cor | LB |
| --- | --- | --- | --- | --- | --- | --- | --- | --- | --- | --- | --- | --- | --- | --- | --- | --- | --- | --- |
| 686 | 1.3.15.2 | **1. Pav. Superior** | 386d | 2024-02-26 | 2025-09-12 |  | 0d |  |  | 3256h | 114,879.9 |  |  |  |  |  |  |  |
| 687 | 1.3.15.2.1 | 2. Estrutura | 7d | 2024-02-26 | 2024-03-05 | 667 | 367d | 0d | servente estrutura [300%]; aux. Carpinteiro [200%]; aux. ferreiro [200%]; ferreiro [500%]; carpinteiro [200%] | 862.4h | 30,006.55 | 15. Casa 15 | 1. Pav. Superior | 2. Estrutura 1 | Própria |  |  |  |
| 688 | 1.3.15.2.2 | 3. Alvenarias | 5d | 2024-03-22 | 2024-04-01 | 668 | 349d | 0d | servente [400%]; pedreiro [400%] | 352h | 10,101.74 | 15. Casa 15 | 1. Pav. Superior | 3. Alvenarias 1 | Própria |  |  |  |
| 689 | 1.3.15.2.3 | 5. Ref. Inter. Arg (Parede) | 4d | 2024-07-17 | 2024-07-22 | 669 | 274d | 0d | pedreiro [600%]; servente [600%] | 422.4h | 5,398.69 | 15. Casa 15 | 1. Pav. Superior | 5. Ref. Inter. Arg (Parede) 1 | Própria |  |  |  |
| 690 | 1.3.15.2.4 | 6. Revest. Gesso (Parede + Teto) | 4d | 2024-07-26 | 2024-07-31 | 716 | 274d | 0d | aux. gesseiro [200%]; gesseiro [400%] | 211.2h | 2,119.41 | 15. Casa 15 | 1. Pav. Superior | 6. Revest. Gesso (Parede + Teto) 1 | Própria |  |  |  |
| 691 | 1.3.15.2.5 | 7. Impermeabilização | 1d | 2024-09-13 | 2024-09-13 | 671 | -2d | 0d | gesseiro [300%]; servente | 35.2h | 2,046.85 | 15. Casa 15 | 1. Pav. Superior | 7. Impermeabilização 1 | Própria |  |  |  |
| 692 | 1.3.15.2.6 | 8. Contrapiso | 2d | 2024-09-17 | 2024-09-19 | 672SF | 0d |  | pedreiro [200%]; servente | 52.8h | 2,476.11 | 15. Casa 15 | 1. Pav. Superior | 8. Contrapiso 1 | Própria |  |  |  |
| 693 | 1.3.15.2.7 | 9.1. Chapisco | 0.5d | 2024-10-15 | 2024-10-15 | 673 | 84.5d | 0d | pedreiro [600%]; servente [400%] | 44h | 5,131.51 | 15. Casa 15 | 1. Pav. Superior | 9. Fachada 1 | Própria |  |  |  |
| 694 | 1.3.15.2.8 | 9.2. Emboço | 1.5d | 2024-12-17 | 2024-12-18 | 627 | 84.5d | 0d | pedreiro [600%]; servente [400%] | 132h | 7,697.26 | 15. Casa 15 | 1. Pav. Superior | 9. Fachada 1 | Própria |  |  |  |
| 695 | 1.3.15.2.9 | 9.3. Pint. 1 Demão | 1d | 2025-02-03 | 2025-02-04 | 628 | 84.5d | 0d | pintor [400%]; aux.pintor [200%] | 52.8h | 1,135.92 | 15. Casa 15 | 1. Pav. Superior | 9. Fachada 1 | Própria |  |  |  |
| 696 | 1.3.15.2.10 | 9.4. Pint. 2 Demão | 2d | 2025-05-07 | 2025-05-09 | 629 | 84.5d | 0d | pintor [400%]; aux.pintor [200%] | 105.6h | 757.28 | 15. Casa 15 | 1. Pav. Superior | 9. Fachada 1 | Própria |  |  |  |
| 697 | 1.3.15.2.11 | 10. Cer. Piso | 4d | 2024-11-21 | 2024-11-26 | 677 | 150d | 0d | servente [200%]; pedreiro [400%] | 211.2h | 19,807.17 | 15. Casa 15 | 1. Pav. Superior | 10. Cer. Piso 1 | Própria | 10 | 10 | 10 |
| 698 | 1.3.15.2.12 | 11. Cer. Parede | 2d | 2025-01-27 | 2025-01-28 | 678 | 150d | 0d | pedreiro [400%]; servente [200%] | 105.6h | 4,238.82 | 15. Casa 15 | 1. Pav. Superior | 11. Cer. Parede 1 | Própria | 11 | 11 | 11 |
| 699 | 1.3.15.2.13 | 12. Forro (WC's e cozinha) | 1d | 2025-02-24 | 2025-02-24 | 679 | 134d | 0d | aux. gesseiro; gesseiro | 17.6h | 895 | 15. Casa 15 | 1. Pav. Superior | 12. Forro (WC's e cozinha) 1 | Própria | 12 | 12 | 12 |
| 700 | 1.3.15.2.14 | 13. Esq. Alumínio | 2d | 2025-04-15 | 2025-04-16 | 680 | 100d | 0d | montador esquadrias | 17.6h | 8,489.61 | 15. Casa 15 | 1. Pav. Superior | 13. Esq. Alumínio 1 | Própria | 13 | 13 | 13 |
| 701 | 1.3.15.2.15 | 14. Portas | 2d | 2025-04-17 | 2025-04-22 | 681 | 98d | 0d | marceneiro [200%] | 35.2h | 1,858.35 | 15. Casa 15 | 1. Pav. Superior | 14. Portas 1 | Própria | 14 | 14 | 14 |
| 702 | 1.3.15.2.16 | 15. Pintura (1ª Demão) | 4d | 2025-05-28 | 2025-06-02 | 682 | 18d | 0d | pintor [600%]; aux.pintor [300%] | 316.8h | 3,764.82 | 15. Casa 15 | 1. Pav. Superior | 15. Pintura (1ª Demão) 1 | Própria | 15 | 15 | 15 |
| 703 | 1.3.15.2.17 | 16. Bancadas | 1d | 2025-07-07 | 2025-07-07 | 683 | 49d | 0d | servente; pedreiro [200%] | 26.4h | 6,972.08 | 15. Casa 15 | 1. Pav. Superior | 16. Bancadas 1 | Própria | 16 | 16 | 16 |
| 704 | 1.3.15.2.18 | 17. Pintura (2ª Demão) | 3d | 2025-08-11 | 2025-08-13 | 684 | 18d | 0d | aux.pintor [300%]; pintor [600%] | 237.6h | 1,563.98 | 15. Casa 15 | 1. Pav. Superior | 17. Pintura (2ª Demão) 1 | Própria | 17 | 17 | 17 |
| 705 | 1.3.15.2.19 | 18. Limp. Interna | 1d | 2025-09-12 | 2025-09-12 | 685 | 0d |  | Diarista [200%] | 17.6h | 418.75 | 15. Casa 15 | 1. Pav. Superior | 18. Limp. Interna 1 | Própria | 18 | 18 | 18 |
| 706 | 1.3.15.3 | **2. Coberta** | 117d | 2024-04-02 | 2024-09-16 |  | 114d |  |  | 536.8h | 58,163.18 |  |  |  |  |  |  |  |
| 707 | 1.3.15.3.1 | 1. Alvenarias | 3d | 2024-04-02 | 2024-04-04 | 688 | 349d | 0d | pedreiro [400%]; servente [400%] | 211.2h | 9,834.12 | 15. Casa 15 | 2. Coberta | 3. Alvenarias 1 | Própria |  |  |  |
| 708 | 1.3.15.3.2 | 2. Impermeabilização | 1d | 2024-09-16 | 2024-09-16 | 691 | -2d | 0d | aplicador de manta | 8.8h | 24,164.53 | 15. Casa 15 | 2. Coberta | 7. Impermeabilização 1 | Própria |  |  |  |
| 709 | 1.3.15.3.3 | 3. Coberta | 6d | 2024-06-26 | 2024-07-03 | 662 | 295d | 0d | carpinteiro [400%]; aux. Carpinteiro [200%] | 316.8h | 24,164.53 | 15. Casa 15 | 2. Coberta | 4. Coberta 1 | Própria |  |  |  |

| ID | WBS | Task | Duration | Start | Finish | Predecessors | Total slack | Free slack | Resources | Work | Cost | Casa | Pav | Equipe | Empresa | Pacote | Cor | LB |
| --- | --- | --- | --- | --- | --- | --- | --- | --- | --- | --- | --- | --- | --- | --- | --- | --- | --- | --- |
| 710 | 1.3.16 | **16. Casa 16** | 495d | 2023-09-12 | 2025-09-16 |  | 0d |  |  | 7594.4h | 338,552.33 |  |  |  |  |  |  |  |
| 711 | 1.3.16.1 | **0. Térreo** | 494d | 2023-09-12 | 2025-09-15 |  | 1d |  |  | 3801.6h | 165,509.25 |  |  |  |  |  |  |  |
| 712 | 1.3.16.1.1 | 0. Locação | 2d | 2023-09-12 | 2023-09-13 | 665 | 805d |  | carpinteiro; aux. Carpinteiro | 35.2h | 456.99 | 16. Casa 16 | 0. Térreo | 0. Locação 1 | Própria |  |  |  |
| 713 | 1.3.16.1.2 | 1. Fundação | 9d | 2023-11-27 | 2023-12-07 | 666 | 747d |  | servente estrutura [300%]; aux. Carpinteiro; aux. ferreiro; ferreiro; carpinteiro [200%] | 633.6h | 19,882.86 | 16. Casa 16 | 0. Térreo | 1. Fundação 1 | Própria |  |  |  |
| 714 | 1.3.16.1.3 | 2. Estrutura | 7d | 2024-03-06 | 2024-03-14 | 687 | 367d | 0d | servente estrutura [300%]; aux. Carpinteiro [200%]; aux. ferreiro [200%]; ferreiro [500%]; carpinteiro [200%] | 862.4h | 46,439.03 | 16. Casa 16 | 0. Térreo | 2. Estrutura 1 | Própria |  |  |  |
| 715 | 1.3.16.1.4 | 3. Alvenarias | 5d | 2024-04-05 | 2024-04-11 | 707 | 349d | 0d | pedreiro [400%]; servente [400%] | 352h | 8,388.41 | 16. Casa 16 | 0. Térreo | 3. Alvenarias 1 | Própria |  |  |  |
| 716 | 1.3.16.1.5 | 5. Ref. Inter. Arg (Parede) | 3d | 2024-07-23 | 2024-07-25 | 689 | 274d | 0d | pedreiro [600%]; servente [600%] | 316.8h | 5,776 | 16. Casa 16 | 0. Térreo | 5. Ref. Inter. Arg (Parede) 1 | Própria |  |  |  |
| 717 | 1.3.16.1.6 | 6. Revest. Gesso (Parede + Teto) | 3d | 2024-08-01 | 2024-08-05 | 690 | 274d | 0d | gesseiro [400%]; aux. gesseiro [200%] | 158.4h | 2,119.41 | 16. Casa 16 | 0. Térreo | 6. Revest. Gesso (Parede + Teto) 1 | Própria |  |  |  |
| 718 | 1.3.16.1.7 | 7. Impermeabilização | 2d | 2024-09-17 | 2024-09-18 | 708 | -2d | 0d | aplicador de manta | 17.6h | 3,288.15 | 16. Casa 16 | 0. Térreo | 7. Impermeabilização 1 | Própria |  |  |  |
| 719 | 1.3.16.1.8 | 8. Contrapiso | 2d | 2024-09-25 | 2024-09-26 | 739 | 240d |  | pedreiro [200%]; servente | 52.8h | 3,735.07 | 16. Casa 16 | 0. Térreo | 8. Contrapiso 1 | Própria |  |  |  |
| 720 | 1.3.16.1.9 | 9.1. Chapisco | 0.5d | 2024-10-16 | 2024-10-16 | 693 | 84.5d | 0d | pedreiro [600%]; servente [400%] | 44h | 5,131.51 | 16. Casa 16 | 0. Térreo | 9. Fachada 1 | Própria |  |  |  |
| 721 | 1.3.16.1.10 | 9.2. Emboço | 1.5d | 2024-12-23 | 2024-12-24 | 741 | 178d |  | pedreiro [600%]; servente [400%] | 132h | 7,697.26 | 16. Casa 16 | 0. Térreo | 9. Fachada 1 | Própria |  |  |  |
| 722 | 1.3.16.1.11 | 9.3. Pint. 1 Demão | 1d | 2025-02-06 | 2025-02-07 | 742 | 147.5d |  | pintor [400%]; aux.pintor [200%] | 52.8h | 1,135.92 | 16. Casa 16 | 0. Térreo | 9. Fachada 1 | Própria |  |  |  |
| 723 | 1.3.16.1.12 | 9.4. Pint. 2 Demão | 2d | 2025-05-15 | 2025-05-19 | 743 | 84.5d |  | pintor [400%]; aux.pintor [200%] | 105.6h | 757.28 | 16. Casa 16 | 0. Térreo | 9. Fachada 1 | Própria |  |  |  |
| 724 | 1.3.16.1.13 | 10. Cer. Piso | 4d | 2024-11-27 | 2024-12-02 | 697 | 150d | 0d | pedreiro [400%]; servente [200%] | 211.2h | 25,485.98 | 16. Casa 16 | 0. Térreo | 10. Cer. Piso 1 | Própria | 10 | 10 | 10 |
| 725 | 1.3.16.1.14 | 11. Cer. Parede | 3d | 2025-01-29 | 2025-01-31 | 698 | 150d | 0d | pedreiro [400%]; servente [200%] | 158.4h | 4,238.82 | 16. Casa 16 | 0. Térreo | 11. Cer. Parede 1 | Própria | 11 | 11 | 11 |
| 726 | 1.3.16.1.15 | 12. Forro (WC's e cozinha) | 1d | 2025-02-25 | 2025-02-25 | 699 | 134d | 0d | gesseiro; aux. gesseiro | 17.6h | 635.82 | 16. Casa 16 | 0. Térreo | 12. Forro (WC's e cozinha) 1 | Própria | 12 | 12 | 12 |
| 727 | 1.3.16.1.16 | 13. Esq. Alumínio | 2d | 2025-04-17 | 2025-04-22 | 700 | 100d | 0d | montador esquadrias | 17.6h | 11,307.22 | 16. Casa 16 | 0. Térreo | 13. Esq. Alumínio 1 | Própria | 13 | 13 | 13 |
| 728 | 1.3.16.1.17 | 14. Portas | 2d | 2025-04-23 | 2025-04-24 | 701 | 98d | 0d | marceneiro [200%] | 35.2h | 2,827.85 | 16. Casa 16 | 0. Térreo | 14. Portas 1 | Própria | 14 | 14 | 14 |
| 729 | 1.3.16.1.18 | 15. Pintura (1ª Demão) | 4d | 2025-06-03 | 2025-06-06 | 702 | 18d | 0d | pintor [600%]; aux.pintor [300%] | 316.8h | 3,764.82 | 16. Casa 16 | 0. Térreo | 15. Pintura (1ª Demão) 1 | Própria | 15 | 15 | 15 |
| 730 | 1.3.16.1.19 | 16. Bancadas | 1d | 2025-07-08 | 2025-07-08 | 703 | 49d | 0d | pedreiro [200%]; servente | 26.4h | 10,458.12 | 16. Casa 16 | 0. Térreo | 16. Bancadas 1 | Própria | 16 | 16 | 16 |
| 731 | 1.3.16.1.20 | 17. Pintura (2ª Demão) | 3d | 2025-08-14 | 2025-08-18 | 704 | 18d | 0d | aux.pintor [300%]; pintor [600%] | 237.6h | 1,563.98 | 16. Casa 16 | 0. Térreo | 17. Pintura (2ª Demão) 1 | Própria | 17 | 17 | 17 |
| 732 | 1.3.16.1.21 | 18. Limp. Interna | 1d | 2025-09-15 | 2025-09-15 | 705 | 0d |  | Diarista [200%] | 17.6h | 418.75 | 16. Casa 16 | 0. Térreo | 18. Limp. Interna 1 | Própria | 18 | 18 | 18 |
| 733 | 1.3.16.2 | **1. Pav. Superior** | 374d | 2024-03-15 | 2025-09-16 |  | 0d |  |  | 3256h | 114,879.9 |  |  |  |  |  |  |  |
| 734 | 1.3.16.2.1 | 2. Estrutura | 7d | 2024-03-15 | 2024-03-27 | 714 | 367d |  | servente estrutura [300%]; aux. Carpinteiro [200%]; aux. ferreiro [200%]; ferreiro [500%]; carpinteiro [200%] | 862.4h | 30,006.55 | 16. Casa 16 | 1. Pav. Superior | 2. Estrutura 1 | Própria |  |  |  |
| 735 | 1.3.16.2.2 | 3. Alvenarias | 5d | 2024-04-12 | 2024-04-18 | 715 | 349d | 0d | servente [400%]; pedreiro [400%] | 352h | 10,101.74 | 16. Casa 16 | 1. Pav. Superior | 3. Alvenarias 1 | Própria |  |  |  |
| 736 | 1.3.16.2.3 | 5. Ref. Inter. Arg (Parede) | 4d | 2024-07-26 | 2024-07-31 | 716 | 281d |  | pedreiro [600%]; servente [600%] | 422.4h | 5,398.69 | 16. Casa 16 | 1. Pav. Superior | 5. Ref. Inter. Arg (Parede) 1 | Própria |  |  |  |
| 737 | 1.3.16.2.4 | 6. Revest. Gesso (Parede + Teto) | 4d | 2024-08-06 | 2024-08-09 | 717 | 274d |  | aux. gesseiro [200%]; gesseiro [400%] | 211.2h | 2,119.41 | 16. Casa 16 | 1. Pav. Superior | 6. Revest. Gesso (Parede + Teto) 1 | Própria |  |  |  |
| 738 | 1.3.16.2.5 | 7. Impermeabilização | 1d | 2024-09-19 | 2024-09-19 | 718 | -2d | 0d | gesseiro [300%]; servente | 35.2h | 2,046.85 | 16. Casa 16 | 1. Pav. Superior | 7. Impermeabilização 1 | Própria |  |  |  |
| 739 | 1.3.16.2.6 | 8. Contrapiso | 2d | 2024-09-23 | 2024-09-24 | 738FS+3ed | 0d |  | pedreiro [200%]; servente | 52.8h | 2,476.11 | 16. Casa 16 | 1. Pav. Superior | 8. Contrapiso 1 | Própria |  |  |  |
| 740 | 1.3.16.2.7 | 9.1. Chapisco | 0.5d | 2024-10-16 | 2024-10-16 | 720 | 84.5d | 0d | pedreiro [600%]; servente [400%] | 44h | 5,131.51 | 16. Casa 16 | 1. Pav. Superior | 9. Fachada 1 | Própria |  |  |  |
| 741 | 1.3.16.2.8 | 9.2. Emboço | 1.5d | 2024-12-20 | 2024-12-23 | 674 | 84.5d | 0d | pedreiro [600%]; servente [400%] | 132h | 7,697.26 | 16. Casa 16 | 1. Pav. Superior | 9. Fachada 1 | Própria |  |  |  |
| 742 | 1.3.16.2.9 | 9.3. Pint. 1 Demão | 1d | 2025-02-05 | 2025-02-06 | 675 | 84.5d | 0d | pintor [400%]; aux.pintor [200%] | 52.8h | 1,135.92 | 16. Casa 16 | 1. Pav. Superior | 9. Fachada 1 | Própria |  |  |  |
| 743 | 1.3.16.2.10 | 9.4. Pint. 2 Demão | 2d | 2025-05-13 | 2025-05-15 | 676 | 84.5d | 0d | pintor [400%]; aux.pintor [200%] | 105.6h | 757.28 | 16. Casa 16 | 1. Pav. Superior | 9. Fachada 1 | Própria |  |  |  |
| 744 | 1.3.16.2.11 | 10. Cer. Piso | 4d | 2024-12-03 | 2024-12-06 | 724 | 150d | 0d | pedreiro [400%]; servente [200%] | 211.2h | 19,807.17 | 16. Casa 16 | 1. Pav. Superior | 10. Cer. Piso 1 | Própria | 10 | 10 | 10 |
| 745 | 1.3.16.2.12 | 11. Cer. Parede | 2d | 2025-02-03 | 2025-02-04 | 725 | 150d |  | pedreiro [400%]; servente [200%] | 105.6h | 4,238.82 | 16. Casa 16 | 1. Pav. Superior | 11. Cer. Parede 1 | Própria | 11 | 11 | 11 |
| 746 | 1.3.16.2.13 | 12. Forro (WC's e cozinha) | 1d | 2025-02-26 | 2025-02-26 | 726 | 134d |  | aux. gesseiro; gesseiro | 17.6h | 895 | 16. Casa 16 | 1. Pav. Superior | 12. Forro (WC's e cozinha) 1 | Própria | 12 | 12 | 12 |
| 747 | 1.3.16.2.14 | 13. Esq. Alumínio | 2d | 2025-04-23 | 2025-04-24 | 727 | 100d |  | montador esquadrias | 17.6h | 8,489.61 | 16. Casa 16 | 1. Pav. Superior | 13. Esq. Alumínio 1 | Própria | 13 | 13 | 13 |
| 748 | 1.3.16.2.15 | 14. Portas | 2d | 2025-04-25 | 2025-04-28 | 728 | 98d |  | marceneiro [200%] | 35.2h | 1,858.35 | 16. Casa 16 | 1. Pav. Superior | 14. Portas 1 | Própria | 14 | 14 | 14 |
| 749 | 1.3.16.2.16 | 15. Pintura (1ª Demão) | 4d | 2025-06-09 | 2025-06-12 | 729 | 18d | 0d | pintor [600%]; aux.pintor [300%] | 316.8h | 3,764.82 | 16. Casa 16 | 1. Pav. Superior | 15. Pintura (1ª Demão) 1 | Própria | 15 | 15 | 15 |
| 750 | 1.3.16.2.17 | 16. Bancadas | 1d | 2025-07-09 | 2025-07-09 | 730 | 49d |  | servente; pedreiro [200%] | 26.4h | 6,972.08 | 16. Casa 16 | 1. Pav. Superior | 16. Bancadas 1 | Própria | 16 | 16 | 16 |
| 751 | 1.3.16.2.18 | 17. Pintura (2ª Demão) | 3d | 2025-08-19 | 2025-08-21 | 731 | 18d |  | aux.pintor [300%]; pintor [600%] | 237.6h | 1,563.98 | 16. Casa 16 | 1. Pav. Superior | 17. Pintura (2ª Demão) 1 | Própria | 17 | 17 | 17 |
| 752 | 1.3.16.2.19 | 18. Limp. Interna | 1d | 2025-09-16 | 2025-09-16 | 732 | 0d |  | Diarista [200%] | 17.6h | 418.75 | 16. Casa 16 | 1. Pav. Superior | 18. Limp. Interna 1 | Própria | 18 | 18 | 18 |

| ID | WBS | Task | Duration | Start | Finish | Predecessors | Total slack | Resources | Work | Cost | Casa | Pav | Equipe | Empresa | Pacote | LB | Cor |
| --- | --- | --- | --- | --- | --- | --- | --- | --- | --- | --- | --- | --- | --- | --- | --- | --- | --- |
| 753 | 1.3.16.3 | **2. Coberta** | 108d | 2024-04-19 | 2024-09-20 |  | 244d |  | 536.8h | 58,163.18 |  |  |  |  |  |  |  |
| 754 | 1.3.16.3.1 | 1. Alvenarias | 3d | 2024-04-19 | 2024-04-23 | 735 | 349d | pedreiro [400%]; servente [400%] | 211.2h | 9,834.12 | 16. Casa 16 | 2. Coberta | 3. Alvenarias 1 | Própria |  |  |  |
| 755 | 1.3.16.3.2 | 2. Impermeabilização | 1d | 2024-09-20 | 2024-09-20 | 738 | 244d | aplicador de manta | 8.8h | 24,164.53 | 16. Casa 16 | 2. Coberta | 7. Impermeabilização 1 | Própria |  |  |  |
| 756 | 1.3.16.3.3 | 3. Coberta | 6d | 2024-07-04 | 2024-07-11 | 709 | 295d | carpinteiro [400%]; aux. Carpinteiro [200%] | 316.8h | 24,164.53 | 16. Casa 16 | 2. Coberta | 4. Coberta 1 | Própria |  |  |  |
| 757 | 1.4 | **Obra Instalações** | 4d | 2023-07-31 | 2023-08-03 |  | 521d |  | 12390.4h | 1,152,793.92 |  |  |  |  |  |  |  |
| 758 | 1.4.1 | **1. Casa 1** | 4d | 2023-07-31 | 2023-08-03 |  | 521d |  | 774.4h | 72,049.62 |  |  |  |  |  |  |  |
| 759 | 1.4.1.1 | **0. Térreo** | 4d | 2023-07-31 | 2023-08-03 |  | 521d |  | 369.6h | 47,239.83 |  |  |  |  |  |  |  |
| 760 | 1.4.1.1.1 | 1.Inst. Embut. Em Fundações | 2d | 2023-07-31 | 2023-08-01 |  | 1205d | bombeiro; eletricista | 35.2h | 1,554.25 | 1. Casa 1 | 0. Térreo | 19. Instalações1 | Própria | 19 | 19 |  |
| 761 | 1.4.1.1.2 | 2.Inst. Elétricas Laje | 2d | 2023-07-31 | 2023-08-01 |  | 1205d | eletricista; aux. eletricista | 35.2h | 6,661.65 | 1. Casa 1 | 0. Térreo | 20. Elétrica1 | Própria | 20 | 20 |  |
| 762 | 1.4.1.1.3 | 3.Inst. Elétricas Paredes | 2d | 2023-07-31 | 2023-08-01 |  | 1205d | eletricista; aux. eletricista | 35.2h | 1,704.34 | 1. Casa 1 | 0. Térreo | 21. HS1 | Própria | 21 | 21 |  |
| 763 | 1.4.1.1.4 | 4.Inst. Gás | 2d | 2023-07-31 | 2023-08-01 |  | 1205d | aux. bombeiro; bombeiro | 35.2h | 2,592.32 | 1. Casa 1 | 0. Térreo | 21. HS1 | Própria | 22 | 22 |  |
| 764 | 1.4.1.1.5 | 5.Inst. AF e AQ | 2d | 2023-07-31 | 2023-08-01 |  | 1205d | aux. bombeiro; bombeiro | 35.2h | 4,586.31 | 1. Casa 1 | 0. Térreo | 21. HS1 | Própria | 23 | 23 |  |
| 765 | 1.4.1.1.6 | 6.Inst. Esgoto | 2d | 2023-07-31 | 2023-08-01 |  | 1205d | aux. bombeiro; bombeiro | 35.2h | 2,922.8 | 1. Casa 1 | 0. Térreo | 21. HS1 | Própria | 24 | 24 |  |
| 766 | 1.4.1.1.7 | 7.Fiação | 4d | 2023-07-31 | 2023-08-03 |  | 1203d | eletricista; aux. eletricista | 70.4h | 11,873.92 | 1. Casa 1 | 0. Térreo | 20. Elétrica1 | Própria | 25 | 25 |  |
| 767 | 1.4.1.1.8 | 8.Interr. Tom e luminárias | 1d | 2023-07-31 | 2023-07-31 |  | 1206d | eletricista; aux. eletricista | 17.6h | 6,963.62 | 1. Casa 1 | 0. Térreo | 20. Elétrica1 | Própria | 26 | 26 |  |
| 768 | 1.4.1.1.9 | 9.Quadro elétrico | 2d | 2023-07-31 | 2023-08-01 |  | 1205d | eletricista; aux. eletricista | 35.2h | 1,788.87 | 1. Casa 1 | 0. Térreo | 20. Elétrica1 | Própria | 27 | 27 |  |
| 769 | 1.4.1.1.10 | 10.Louças e Metais | 2d | 2023-07-31 | 2023-08-01 |  | 1205d | aux. bombeiro; bombeiro | 35.2h | 6,591.75 | 1. Casa 1 | 0. Térreo | 21. HS1 | Própria | 28 | 28 | 10 |
| 770 | 1.4.1.2 | **1. Pav. Superior** | 4d | 2023-07-31 | 2023-08-03 |  | 521d |  | 334.4h | 21,866.33 |  |  |  |  |  |  |  |
| 771 | 1.4.1.2.1 | 2.Inst. Elétricas Laje | 2d | 2023-07-31 | 2023-08-01 |  | 1205d | eletricista; aux. eletricista | 35.2h | 2,995.3 | 1. Casa 1 | 1. Pav. Superior | 20. Elétrica1 | Própria | 20 | 20 |  |
| 772 | 1.4.1.2.2 | 3.Inst. Elétricas Paredes | 2d | 2023-07-31 | 2023-08-01 |  | 1205d | eletricista; aux. eletricista | 35.2h | 766.33 | 1. Casa 1 | 1. Pav. Superior | 20. Elétrica1 | Própria | 21 | 21 |  |
| 773 | 1.4.1.2.3 | 4.Inst. Gás | 2d | 2023-07-31 | 2023-08-01 |  | 1205d | aux. bombeiro; bombeiro | 35.2h | 1,371.29 | 1. Casa 1 | 1. Pav. Superior | 21. HS1 | Própria | 22 | 22 |  |
| 774 | 1.4.1.2.4 | 5.Inst. AF e AQ | 2d | 2023-07-31 | 2023-08-01 |  | 1205d | aux. bombeiro; bombeiro | 35.2h | 2,426.07 | 1. Casa 1 | 1. Pav. Superior | 21. HS1 | Própria | 23 | 23 |  |
| 775 | 1.4.1.2.5 | 6.Inst. Esgoto | 2d | 2023-07-31 | 2023-08-01 |  | 1205d | aux. bombeiro; bombeiro | 35.2h | 1,546.11 | 1. Casa 1 | 1. Pav. Superior | 21. HS1 | Própria | 24 | 24 |  |
| 776 | 1.4.1.2.6 | 7.Fiação | 4d | 2023-07-31 | 2023-08-03 |  | 1203d | eletricista; aux. eletricista | 70.4h | 5,338.91 | 1. Casa 1 | 1. Pav. Superior | 20. Elétrica1 | Própria | 25 | 25 |  |
| 777 | 1.4.1.2.7 | 8.Interr. Tom e luminárias | 1d | 2023-07-31 | 2023-07-31 |  | 1206d | eletricista; aux. eletricista | 17.6h | 3,131.08 | 1. Casa 1 | 1. Pav. Superior | 20. Elétrica1 | Própria | 26 | 26 |  |
| 778 | 1.4.1.2.8 | 9.Quadro elétrico | 2d | 2023-07-31 | 2023-08-01 |  | 1205d | eletricista; aux. eletricista | 35.2h | 804.33 | 1. Casa 1 | 1. Pav. Superior | 20. Elétrica1 | Própria | 27 | 27 |  |
| 779 | 1.4.1.2.9 | 10.Louças e Metais | 2d | 2023-07-31 | 2023-08-01 |  | 1205d | aux. bombeiro; bombeiro | 35.2h | 3,486.91 | 1. Casa 1 | 1. Pav. Superior | 21. HS1 | Própria | 28 | 28 | 10 |

| ID | WBS | Task | Duration | Start | Finish | Total slack | Resources | Work | Cost | Casa | Pav | Pacote | Cor | Equipe | Empresa | LB |
| --- | --- | --- | --- | --- | --- | --- | --- | --- | --- | --- | --- | --- | --- | --- | --- | --- |
| 780 | 1.4.1.3 | **2. Coberta** | 2d | 2023-07-31 | 2023-08-01 | 523d |  | 70.4h | 2,943.46 |  |  |  |  |  |  |  |
| 781 | 1.4.1.3.1 | Barrilette | 2d | 2023-07-31 | 2023-08-01 | 1205d | aux. bombeiro; bombeiro | 35.2h | 1,177.38 | 1. Casa 1 | 2. Coberta | 29 | 11 | 21. HS1 | Própria | 29 |
| 782 | 1.4.1.3.2 | Caixa D'água | 2d | 2023-07-31 | 2023-08-01 | 1205d | aux. bombeiro; bombeiro | 35.2h | 1,766.08 | 1. Casa 1 | 2. Coberta | 30 | 11 | 21. HS1 | Própria | 30 |
| 783 | 1.4.2 | **2. Casa 2** | 4d | 2023-07-31 | 2023-08-03 | 521d |  | 774.4h | 72,049.62 |  |  |  |  |  |  |  |
| 784 | 1.4.2.1 | **0. Térreo** | 4d | 2023-07-31 | 2023-08-03 | 521d |  | 369.6h | 47,239.83 |  |  |  |  |  |  |  |
| 785 | 1.4.2.1.1 | 1.Inst. Embut. Em Fundações | 2d | 2023-07-31 | 2023-08-01 | 1205d | bombeiro; eletricista | 35.2h | 1,554.25 | 2. Casa 2 | 0. Térreo | 19 |  | 19. Instalações1 | Própria | 19 |
| 786 | 1.4.2.1.2 | 2.Inst. Elétricas Laje | 2d | 2023-07-31 | 2023-08-01 | 1205d | eletricista; aux. eletricista | 35.2h | 6,661.65 | 2. Casa 2 | 0. Térreo | 20 |  | 20. Elétrica1 | Própria | 20 |
| 787 | 1.4.2.1.3 | 3.Inst. Elétricas Paredes | 2d | 2023-07-31 | 2023-08-01 | 1205d | eletricista; aux. eletricista | 35.2h | 1,704.34 | 2. Casa 2 | 0. Térreo | 21 |  | 21. HS1 | Própria | 21 |
| 788 | 1.4.2.1.4 | 4.Inst. Gás | 2d | 2023-07-31 | 2023-08-01 | 1205d | aux. bombeiro; bombeiro | 35.2h | 2,592.32 | 2. Casa 2 | 0. Térreo | 22 |  | 21. HS1 | Própria | 22 |
| 789 | 1.4.2.1.5 | 5.Inst. AF e AQ | 2d | 2023-07-31 | 2023-08-01 | 1205d | aux. bombeiro; bombeiro | 35.2h | 4,586.31 | 2. Casa 2 | 0. Térreo | 23 |  | 21. HS1 | Própria | 23 |
| 790 | 1.4.2.1.6 | 6.Inst. Esgoto | 2d | 2023-07-31 | 2023-08-01 | 1205d | aux. bombeiro; bombeiro | 35.2h | 2,922.8 | 2. Casa 2 | 0. Térreo | 24 |  | 21. HS1 | Própria | 24 |
| 791 | 1.4.2.1.7 | 7.Fiação | 4d | 2023-07-31 | 2023-08-03 | 1203d | eletricista; aux. eletricista | 70.4h | 11,873.92 | 2. Casa 2 | 0. Térreo | 25 |  | 20. Elétrica1 | Própria | 25 |
| 792 | 1.4.2.1.8 | 8.Interr. Tom e luminárias | 1d | 2023-07-31 | 2023-07-31 | 1206d | eletricista; aux. eletricista | 17.6h | 6,963.62 | 2. Casa 2 | 0. Térreo | 26 |  | 20. Elétrica1 | Própria | 26 |
| 793 | 1.4.2.1.9 | 9.Quadro elétrico | 2d | 2023-07-31 | 2023-08-01 | 1205d | eletricista; aux. eletricista | 35.2h | 1,788.87 | 2. Casa 2 | 0. Térreo | 27 |  | 20. Elétrica1 | Própria | 27 |
| 794 | 1.4.2.1.10 | 10.Louças e Metais | 2d | 2023-07-31 | 2023-08-01 | 1205d | aux. bombeiro; bombeiro | 35.2h | 6,591.75 | 2. Casa 2 | 0. Térreo | 28 | 10 | 21. HS1 | Própria | 28 |
| 795 | 1.4.2.2 | **1. Pav. Superior** | 4d | 2023-07-31 | 2023-08-03 | 521d |  | 334.4h | 21,866.33 |  |  |  |  |  |  |  |
| 796 | 1.4.2.2.1 | 2.Inst. Elétricas Laje | 2d | 2023-07-31 | 2023-08-01 | 1205d | eletricista; aux. eletricista | 35.2h | 2,995.3 | 2. Casa 2 | 1. Pav. Superior | 20 |  | 20. Elétrica1 | Própria | 20 |
| 797 | 1.4.2.2.2 | 3.Inst. Elétricas Paredes | 2d | 2023-07-31 | 2023-08-01 | 1205d | eletricista; aux. eletricista | 35.2h | 766.33 | 2. Casa 2 | 1. Pav. Superior | 21 |  | 20. Elétrica1 | Própria | 21 |
| 798 | 1.4.2.2.3 | 4.Inst. Gás | 2d | 2023-07-31 | 2023-08-01 | 1205d | aux. bombeiro; bombeiro | 35.2h | 1,371.29 | 2. Casa 2 | 1. Pav. Superior | 22 |  | 21. HS1 | Própria | 22 |
| 799 | 1.4.2.2.4 | 5.Inst. AF e AQ | 2d | 2023-07-31 | 2023-08-01 | 1205d | aux. bombeiro; bombeiro | 35.2h | 2,426.07 | 2. Casa 2 | 1. Pav. Superior | 23 |  | 21. HS1 | Própria | 23 |
| 800 | 1.4.2.2.5 | 6.Inst. Esgoto | 2d | 2023-07-31 | 2023-08-01 | 1205d | aux. bombeiro; bombeiro | 35.2h | 1,546.11 | 2. Casa 2 | 1. Pav. Superior | 24 |  | 21. HS1 | Própria | 24 |
| 801 | 1.4.2.2.6 | 7.Fiação | 4d | 2023-07-31 | 2023-08-03 | 1203d | eletricista; aux. eletricista | 70.4h | 5,338.91 | 2. Casa 2 | 1. Pav. Superior | 25 |  | 20. Elétrica1 | Própria | 25 |
| 802 | 1.4.2.2.7 | 8.Interr. Tom e luminárias | 1d | 2023-07-31 | 2023-07-31 | 1206d | eletricista; aux. eletricista | 17.6h | 3,131.08 | 2. Casa 2 | 1. Pav. Superior | 26 |  | 20. Elétrica1 | Própria | 26 |
| 803 | 1.4.2.2.8 | 9.Quadro elétrico | 2d | 2023-07-31 | 2023-08-01 | 1205d | eletricista; aux. eletricista | 35.2h | 804.33 | 2. Casa 2 | 1. Pav. Superior | 27 |  | 20. Elétrica1 | Própria | 27 |
| 804 | 1.4.2.2.9 | 10.Louças e Metais | 2d | 2023-07-31 | 2023-08-01 | 1205d | aux. bombeiro; bombeiro | 35.2h | 3,486.91 | 2. Casa 2 | 1. Pav. Superior | 28 | 10 | 21. HS1 | Própria | 28 |

| ID | WBS | Task | Duration | Start | Finish | Total slack | Resources | Work | Cost | Casa | Pav | Pacote | Cor | Equipe | Empresa | LB |
| --- | --- | --- | --- | --- | --- | --- | --- | --- | --- | --- | --- | --- | --- | --- | --- | --- |
| 805 | 1.4.2.3 | **2. Coberta** | 2d | 2023-07-31 | 2023-08-01 | 523d |  | 70.4h | 2,943.46 |  |  |  |  |  |  |  |
| 806 | 1.4.2.3.1 | Barrilette | 2d | 2023-07-31 | 2023-08-01 | 1205d | aux. bombeiro; bombeiro | 35.2h | 1,177.38 | 2. Casa 2 | 2. Coberta | 29 | 11 | 21. HS1 | Própria | 29 |
| 807 | 1.4.2.3.2 | Caixa D'água | 2d | 2023-07-31 | 2023-08-01 | 1205d | aux. bombeiro; bombeiro | 35.2h | 1,766.08 | 2. Casa 2 | 2. Coberta | 30 | 11 | 21. HS1 | Própria | 30 |
| 808 | 1.4.3 | **3. Casa 3** | 4d | 2023-07-31 | 2023-08-03 | 521d |  | 774.4h | 72,049.62 |  |  |  |  |  |  |  |
| 809 | 1.4.3.1 | **0. Térreo** | 4d | 2023-07-31 | 2023-08-03 | 521d |  | 369.6h | 47,239.83 |  |  |  |  |  |  |  |
| 810 | 1.4.3.1.1 | 1.Inst. Embut. Em Fundações | 2d | 2023-07-31 | 2023-08-01 | 1205d | bombeiro; eletricista | 35.2h | 1,554.25 | 3. Casa 3 | 0. Térreo | 19 |  | 19. Instalações1 | Própria | 19 |
| 811 | 1.4.3.1.2 | 2.Inst. Elétricas Laje | 2d | 2023-07-31 | 2023-08-01 | 1205d | eletricista; aux. eletricista | 35.2h | 6,661.65 | 3. Casa 3 | 0. Térreo | 20 |  | 20. Elétrica1 | Própria | 20 |
| 812 | 1.4.3.1.3 | 3.Inst. Elétricas Paredes | 2d | 2023-07-31 | 2023-08-01 | 1205d | eletricista; aux. eletricista | 35.2h | 1,704.34 | 3. Casa 3 | 0. Térreo | 21 |  | 21. HS1 | Própria | 21 |
| 813 | 1.4.3.1.4 | 4.Inst. Gás | 2d | 2023-07-31 | 2023-08-01 | 1205d | aux. bombeiro; bombeiro | 35.2h | 2,592.32 | 3. Casa 3 | 0. Térreo | 22 |  | 21. HS1 | Própria | 22 |
| 814 | 1.4.3.1.5 | 5.Inst. AF e AQ | 2d | 2023-07-31 | 2023-08-01 | 1205d | aux. bombeiro; bombeiro | 35.2h | 4,586.31 | 3. Casa 3 | 0. Térreo | 23 |  | 21. HS1 | Própria | 23 |
| 815 | 1.4.3.1.6 | 6.Inst. Esgoto | 2d | 2023-07-31 | 2023-08-01 | 1205d | aux. bombeiro; bombeiro | 35.2h | 2,922.8 | 3. Casa 3 | 0. Térreo | 24 |  | 21. HS1 | Própria | 24 |
| 816 | 1.4.3.1.7 | 7.Fiação | 4d | 2023-07-31 | 2023-08-03 | 1203d | eletricista; aux. eletricista | 70.4h | 11,873.92 | 3. Casa 3 | 0. Térreo | 25 |  | 20. Elétrica1 | Própria | 25 |
| 817 | 1.4.3.1.8 | 8.Interr. Tom e luminárias | 1d | 2023-07-31 | 2023-07-31 | 1206d | eletricista; aux. eletricista | 17.6h | 6,963.62 | 3. Casa 3 | 0. Térreo | 26 |  | 20. Elétrica1 | Própria | 26 |
| 818 | 1.4.3.1.9 | 9.Quadro elétrico | 2d | 2023-07-31 | 2023-08-01 | 1205d | eletricista; aux. eletricista | 35.2h | 1,788.87 | 3. Casa 3 | 0. Térreo | 27 |  | 20. Elétrica1 | Própria | 27 |
| 819 | 1.4.3.1.10 | 10.Louças e Metais | 2d | 2023-07-31 | 2023-08-01 | 1205d | aux. bombeiro; bombeiro | 35.2h | 6,591.75 | 3. Casa 3 | 0. Térreo | 28 | 10 | 21. HS1 | Própria | 28 |
| 820 | 1.4.3.2 | **1. Pav. Superior** | 4d | 2023-07-31 | 2023-08-03 | 521d |  | 334.4h | 21,866.33 |  |  |  |  |  |  |  |
| 821 | 1.4.3.2.1 | 2.Inst. Elétricas Laje | 2d | 2023-07-31 | 2023-08-01 | 1205d | eletricista; aux. eletricista | 35.2h | 2,995.3 | 3. Casa 3 | 1. Pav. Superior | 20 |  | 20. Elétrica1 | Própria | 20 |
| 822 | 1.4.3.2.2 | 3.Inst. Elétricas Paredes | 2d | 2023-07-31 | 2023-08-01 | 1205d | eletricista; aux. eletricista | 35.2h | 766.33 | 3. Casa 3 | 1. Pav. Superior | 21 |  | 20. Elétrica1 | Própria | 21 |
| 823 | 1.4.3.2.3 | 4.Inst. Gás | 2d | 2023-07-31 | 2023-08-01 | 1205d | aux. bombeiro; bombeiro | 35.2h | 1,371.29 | 3. Casa 3 | 1. Pav. Superior | 22 |  | 21. HS1 | Própria | 22 |
| 824 | 1.4.3.2.4 | 5.Inst. AF e AQ | 2d | 2023-07-31 | 2023-08-01 | 1205d | aux. bombeiro; bombeiro | 35.2h | 2,426.07 | 3. Casa 3 | 1. Pav. Superior | 23 |  | 21. HS1 | Própria | 23 |
| 825 | 1.4.3.2.5 | 6.Inst. Esgoto | 2d | 2023-07-31 | 2023-08-01 | 1205d | aux. bombeiro; bombeiro | 35.2h | 1,546.11 | 3. Casa 3 | 1. Pav. Superior | 24 |  | 21. HS1 | Própria | 24 |
| 826 | 1.4.3.2.6 | 7.Fiação | 4d | 2023-07-31 | 2023-08-03 | 1203d | eletricista; aux. eletricista | 70.4h | 5,338.91 | 3. Casa 3 | 1. Pav. Superior | 25 |  | 20. Elétrica1 | Própria | 25 |
| 827 | 1.4.3.2.7 | 8.Interr. Tom e luminárias | 1d | 2023-07-31 | 2023-07-31 | 1206d | eletricista; aux. eletricista | 17.6h | 3,131.08 | 3. Casa 3 | 1. Pav. Superior | 26 |  | 20. Elétrica1 | Própria | 26 |
| 828 | 1.4.3.2.8 | 9.Quadro elétrico | 2d | 2023-07-31 | 2023-08-01 | 1205d | eletricista; aux. eletricista | 35.2h | 804.33 | 3. Casa 3 | 1. Pav. Superior | 27 |  | 20. Elétrica1 | Própria | 27 |
| 829 | 1.4.3.2.9 | 10.Louças e Metais | 2d | 2023-07-31 | 2023-08-01 | 1205d | aux. bombeiro; bombeiro | 35.2h | 3,486.91 | 3. Casa 3 | 1. Pav. Superior | 28 | 10 | 21. HS1 | Própria | 28 |

| ID | WBS | Task | Duration | Start | Finish | Total slack | Resources | Work | Cost | Casa | Pav | Pacote | Cor | Equipe | Empresa | LB |
| --- | --- | --- | --- | --- | --- | --- | --- | --- | --- | --- | --- | --- | --- | --- | --- | --- |
| 830 | 1.4.3.3 | **2. Coberta** | 2d | 2023-07-31 | 2023-08-01 | 523d |  | 70.4h | 2,943.46 |  |  |  |  |  |  |  |
| 831 | 1.4.3.3.1 | Barrilette | 2d | 2023-07-31 | 2023-08-01 | 1205d | aux. bombeiro; bombeiro | 35.2h | 1,177.38 | 3. Casa 3 | 2. Coberta | 29 | 11 | 21. HS1 | Própria | 29 |
| 832 | 1.4.3.3.2 | Caixa D'água | 2d | 2023-07-31 | 2023-08-01 | 1205d | aux. bombeiro; bombeiro | 35.2h | 1,766.08 | 3. Casa 3 | 2. Coberta | 30 | 11 | 21. HS1 | Própria | 30 |
| 833 | 1.4.4 | **4. Casa 4** | 4d | 2023-07-31 | 2023-08-03 | 521d |  | 774.4h | 72,049.62 |  |  |  |  |  |  |  |
| 834 | 1.4.4.1 | **0. Térreo** | 4d | 2023-07-31 | 2023-08-03 | 521d |  | 369.6h | 47,239.83 |  |  |  |  |  |  |  |
| 835 | 1.4.4.1.1 | 1.Inst. Embut. Em Fundações | 2d | 2023-07-31 | 2023-08-01 | 1205d | bombeiro; eletricista | 35.2h | 1,554.25 | 4. Casa 4 | 0. Térreo | 19 |  | 19. Instalações1 | Própria | 19 |
| 836 | 1.4.4.1.2 | 2.Inst. Elétricas Laje | 2d | 2023-07-31 | 2023-08-01 | 1205d | eletricista; aux. eletricista | 35.2h | 6,661.65 | 4. Casa 4 | 0. Térreo | 20 |  | 20. Elétrica1 | Própria | 20 |
| 837 | 1.4.4.1.3 | 3.Inst. Elétricas Paredes | 2d | 2023-07-31 | 2023-08-01 | 1205d | eletricista; aux. eletricista | 35.2h | 1,704.34 | 4. Casa 4 | 0. Térreo | 21 |  | 21. HS1 | Própria | 21 |
| 838 | 1.4.4.1.4 | 4.Inst. Gás | 2d | 2023-07-31 | 2023-08-01 | 1205d | aux. bombeiro; bombeiro | 35.2h | 2,592.32 | 4. Casa 4 | 0. Térreo | 22 |  | 21. HS1 | Própria | 22 |
| 839 | 1.4.4.1.5 | 5.Inst. AF e AQ | 2d | 2023-07-31 | 2023-08-01 | 1205d | aux. bombeiro; bombeiro | 35.2h | 4,586.31 | 4. Casa 4 | 0. Térreo | 23 |  | 21. HS1 | Própria | 23 |
| 840 | 1.4.4.1.6 | 6.Inst. Esgoto | 2d | 2023-07-31 | 2023-08-01 | 1205d | aux. bombeiro; bombeiro | 35.2h | 2,922.8 | 4. Casa 4 | 0. Térreo | 24 |  | 21. HS1 | Própria | 24 |
| 841 | 1.4.4.1.7 | 7.Fiação | 4d | 2023-07-31 | 2023-08-03 | 1203d | eletricista; aux. eletricista | 70.4h | 11,873.92 | 4. Casa 4 | 0. Térreo | 25 |  | 20. Elétrica1 | Própria | 25 |
| 842 | 1.4.4.1.8 | 8.Interr. Tom e luminárias | 1d | 2023-07-31 | 2023-07-31 | 1206d | eletricista; aux. eletricista | 17.6h | 6,963.62 | 4. Casa 4 | 0. Térreo | 26 |  | 20. Elétrica1 | Própria | 26 |
| 843 | 1.4.4.1.9 | 9.Quadro elétrico | 2d | 2023-07-31 | 2023-08-01 | 1205d | eletricista; aux. eletricista | 35.2h | 1,788.87 | 4. Casa 4 | 0. Térreo | 27 |  | 20. Elétrica1 | Própria | 27 |
| 844 | 1.4.4.1.10 | 10.Louças e Metais | 2d | 2023-07-31 | 2023-08-01 | 1205d | aux. bombeiro; bombeiro | 35.2h | 6,591.75 | 4. Casa 4 | 0. Térreo | 28 | 10 | 21. HS1 | Própria | 28 |
| 845 | 1.4.4.2 | **1. Pav. Superior** | 4d | 2023-07-31 | 2023-08-03 | 521d |  | 334.4h | 21,866.33 |  |  |  |  |  |  |  |
| 846 | 1.4.4.2.1 | 2.Inst. Elétricas Laje | 2d | 2023-07-31 | 2023-08-01 | 1205d | eletricista; aux. eletricista | 35.2h | 2,995.3 | 4. Casa 4 | 1. Pav. Superior | 20 |  | 20. Elétrica1 | Própria | 20 |
| 847 | 1.4.4.2.2 | 3.Inst. Elétricas Paredes | 2d | 2023-07-31 | 2023-08-01 | 1205d | eletricista; aux. eletricista | 35.2h | 766.33 | 4. Casa 4 | 1. Pav. Superior | 21 |  | 20. Elétrica1 | Própria | 21 |
| 848 | 1.4.4.2.3 | 4.Inst. Gás | 2d | 2023-07-31 | 2023-08-01 | 1205d | aux. bombeiro; bombeiro | 35.2h | 1,371.29 | 4. Casa 4 | 1. Pav. Superior | 22 |  | 21. HS1 | Própria | 22 |
| 849 | 1.4.4.2.4 | 5.Inst. AF e AQ | 2d | 2023-07-31 | 2023-08-01 | 1205d | aux. bombeiro; bombeiro | 35.2h | 2,426.07 | 4. Casa 4 | 1. Pav. Superior | 23 |  | 21. HS1 | Própria | 23 |
| 850 | 1.4.4.2.5 | 6.Inst. Esgoto | 2d | 2023-07-31 | 2023-08-01 | 1205d | aux. bombeiro; bombeiro | 35.2h | 1,546.11 | 4. Casa 4 | 1. Pav. Superior | 24 |  | 21. HS1 | Própria | 24 |
| 851 | 1.4.4.2.6 | 7.Fiação | 4d | 2023-07-31 | 2023-08-03 | 1203d | eletricista; aux. eletricista | 70.4h | 5,338.91 | 4. Casa 4 | 1. Pav. Superior | 25 |  | 20. Elétrica1 | Própria | 25 |
| 852 | 1.4.4.2.7 | 8.Interr. Tom e luminárias | 1d | 2023-07-31 | 2023-07-31 | 1206d | eletricista; aux. eletricista | 17.6h | 3,131.08 | 4. Casa 4 | 1. Pav. Superior | 26 |  | 20. Elétrica1 | Própria | 26 |
| 853 | 1.4.4.2.8 | 9.Quadro elétrico | 2d | 2023-07-31 | 2023-08-01 | 1205d | eletricista; aux. eletricista | 35.2h | 804.33 | 4. Casa 4 | 1. Pav. Superior | 27 |  | 20. Elétrica1 | Própria | 27 |
| 854 | 1.4.4.2.9 | 10.Louças e Metais | 2d | 2023-07-31 | 2023-08-01 | 1205d | aux. bombeiro; bombeiro | 35.2h | 3,486.91 | 4. Casa 4 | 1. Pav. Superior | 28 | 10 | 21. HS1 | Própria | 28 |

| ID | WBS | Task | Duration | Start | Finish | Total slack | Resources | Work | Cost | Casa | Pav | Pacote | Cor | Equipe | Empresa | LB |
| --- | --- | --- | --- | --- | --- | --- | --- | --- | --- | --- | --- | --- | --- | --- | --- | --- |
| 855 | 1.4.4.3 | **2. Coberta** | 2d | 2023-07-31 | 2023-08-01 | 523d |  | 70.4h | 2,943.46 |  |  |  |  |  |  |  |
| 856 | 1.4.4.3.1 | Barrilette | 2d | 2023-07-31 | 2023-08-01 | 1205d | aux. bombeiro; bombeiro | 35.2h | 1,177.38 | 4. Casa 4 | 2. Coberta | 29 | 11 | 21. HS1 | Própria | 29 |
| 857 | 1.4.4.3.2 | Caixa D'água | 2d | 2023-07-31 | 2023-08-01 | 1205d | aux. bombeiro; bombeiro | 35.2h | 1,766.08 | 4. Casa 4 | 2. Coberta | 30 | 11 | 21. HS1 | Própria | 30 |
| 858 | 1.4.5 | **5. Casa 5** | 4d | 2023-07-31 | 2023-08-03 | 521d |  | 774.4h | 72,049.62 |  |  |  |  |  |  |  |
| 859 | 1.4.5.1 | **0. Térreo** | 4d | 2023-07-31 | 2023-08-03 | 521d |  | 369.6h | 47,239.83 |  |  |  |  |  |  |  |
| 860 | 1.4.5.1.1 | 1.Inst. Embut. Em Fundações | 2d | 2023-07-31 | 2023-08-01 | 1205d | bombeiro; eletricista | 35.2h | 1,554.25 | 5. Casa 5 | 0. Térreo | 19 |  | 19. Instalações1 | Própria | 19 |
| 861 | 1.4.5.1.2 | 2.Inst. Elétricas Laje | 2d | 2023-07-31 | 2023-08-01 | 1205d | eletricista; aux. eletricista | 35.2h | 6,661.65 | 5. Casa 5 | 0. Térreo | 20 |  | 20. Elétrica1 | Própria | 20 |
| 862 | 1.4.5.1.3 | 3.Inst. Elétricas Paredes | 2d | 2023-07-31 | 2023-08-01 | 1205d | eletricista; aux. eletricista | 35.2h | 1,704.34 | 5. Casa 5 | 0. Térreo | 21 |  | 21. HS1 | Própria | 21 |
| 863 | 1.4.5.1.4 | 4.Inst. Gás | 2d | 2023-07-31 | 2023-08-01 | 1205d | aux. bombeiro; bombeiro | 35.2h | 2,592.32 | 5. Casa 5 | 0. Térreo | 22 |  | 21. HS1 | Própria | 22 |
| 864 | 1.4.5.1.5 | 5.Inst. AF e AQ | 2d | 2023-07-31 | 2023-08-01 | 1205d | aux. bombeiro; bombeiro | 35.2h | 4,586.31 | 5. Casa 5 | 0. Térreo | 23 |  | 21. HS1 | Própria | 23 |
| 865 | 1.4.5.1.6 | 6.Inst. Esgoto | 2d | 2023-07-31 | 2023-08-01 | 1205d | aux. bombeiro; bombeiro | 35.2h | 2,922.8 | 5. Casa 5 | 0. Térreo | 24 |  | 21. HS1 | Própria | 24 |
| 866 | 1.4.5.1.7 | 7.Fiação | 4d | 2023-07-31 | 2023-08-03 | 1203d | eletricista; aux. eletricista | 70.4h | 11,873.92 | 5. Casa 5 | 0. Térreo | 25 |  | 20. Elétrica1 | Própria | 25 |
| 867 | 1.4.5.1.8 | 8.Interr. Tom e luminárias | 1d | 2023-07-31 | 2023-07-31 | 1206d | eletricista; aux. eletricista | 17.6h | 6,963.62 | 5. Casa 5 | 0. Térreo | 26 |  | 20. Elétrica1 | Própria | 26 |
| 868 | 1.4.5.1.9 | 9.Quadro elétrico | 2d | 2023-07-31 | 2023-08-01 | 1205d | eletricista; aux. eletricista | 35.2h | 1,788.87 | 5. Casa 5 | 0. Térreo | 27 |  | 20. Elétrica1 | Própria | 27 |
| 869 | 1.4.5.1.10 | 10.Louças e Metais | 2d | 2023-07-31 | 2023-08-01 | 1205d | aux. bombeiro; bombeiro | 35.2h | 6,591.75 | 5. Casa 5 | 0. Térreo | 28 | 10 | 21. HS1 | Própria | 28 |
| 870 | 1.4.5.2 | **1. Pav. Superior** | 4d | 2023-07-31 | 2023-08-03 | 521d |  | 334.4h | 21,866.33 |  |  |  |  |  |  |  |
| 871 | 1.4.5.2.1 | 2.Inst. Elétricas Laje | 2d | 2023-07-31 | 2023-08-01 | 1205d | eletricista; aux. eletricista | 35.2h | 2,995.3 | 5. Casa 5 | 1. Pav. Superior | 20 |  | 20. Elétrica1 | Própria | 20 |
| 872 | 1.4.5.2.2 | 3.Inst. Elétricas Paredes | 2d | 2023-07-31 | 2023-08-01 | 1205d | eletricista; aux. eletricista | 35.2h | 766.33 | 5. Casa 5 | 1. Pav. Superior | 21 |  | 20. Elétrica1 | Própria | 21 |
| 873 | 1.4.5.2.3 | 4.Inst. Gás | 2d | 2023-07-31 | 2023-08-01 | 1205d | aux. bombeiro; bombeiro | 35.2h | 1,371.29 | 5. Casa 5 | 1. Pav. Superior | 22 |  | 21. HS1 | Própria | 22 |
| 874 | 1.4.5.2.4 | 5.Inst. AF e AQ | 2d | 2023-07-31 | 2023-08-01 | 1205d | aux. bombeiro; bombeiro | 35.2h | 2,426.07 | 5. Casa 5 | 1. Pav. Superior | 23 |  | 21. HS1 | Própria | 23 |
| 875 | 1.4.5.2.5 | 6.Inst. Esgoto | 2d | 2023-07-31 | 2023-08-01 | 1205d | aux. bombeiro; bombeiro | 35.2h | 1,546.11 | 5. Casa 5 | 1. Pav. Superior | 24 |  | 21. HS1 | Própria | 24 |
| 876 | 1.4.5.2.6 | 7.Fiação | 4d | 2023-07-31 | 2023-08-03 | 1203d | eletricista; aux. eletricista | 70.4h | 5,338.91 | 5. Casa 5 | 1. Pav. Superior | 25 |  | 20. Elétrica1 | Própria | 25 |
| 877 | 1.4.5.2.7 | 8.Interr. Tom e luminárias | 1d | 2023-07-31 | 2023-07-31 | 1206d | eletricista; aux. eletricista | 17.6h | 3,131.08 | 5. Casa 5 | 1. Pav. Superior | 26 |  | 20. Elétrica1 | Própria | 26 |
| 878 | 1.4.5.2.8 | 9.Quadro elétrico | 2d | 2023-07-31 | 2023-08-01 | 1205d | eletricista; aux. eletricista | 35.2h | 804.33 | 5. Casa 5 | 1. Pav. Superior | 27 |  | 20. Elétrica1 | Própria | 27 |
| 879 | 1.4.5.2.9 | 10.Louças e Metais | 2d | 2023-07-31 | 2023-08-01 | 1205d | aux. bombeiro; bombeiro | 35.2h | 3,486.91 | 5. Casa 5 | 1. Pav. Superior | 28 | 10 | 21. HS1 | Própria | 28 |

| ID | WBS | Task | Duration | Start | Finish | Total slack | Resources | Work | Cost | Casa | Pav | Pacote | Cor | Equipe | Empresa | LB |
| --- | --- | --- | --- | --- | --- | --- | --- | --- | --- | --- | --- | --- | --- | --- | --- | --- |
| 880 | 1.4.5.3 | **2. Coberta** | 2d | 2023-07-31 | 2023-08-01 | 523d |  | 70.4h | 2,943.46 |  |  |  |  |  |  |  |
| 881 | 1.4.5.3.1 | Barrilette | 2d | 2023-07-31 | 2023-08-01 | 1205d | aux. bombeiro; bombeiro | 35.2h | 1,177.38 | 5. Casa 5 | 2. Coberta | 29 | 11 | 21. HS1 | Própria | 29 |
| 882 | 1.4.5.3.2 | Caixa D'água | 2d | 2023-07-31 | 2023-08-01 | 1205d | aux. bombeiro; bombeiro | 35.2h | 1,766.08 | 5. Casa 5 | 2. Coberta | 30 | 11 | 21. HS1 | Própria | 30 |
| 883 | 1.4.6 | **6. Casa 6** | 4d | 2023-07-31 | 2023-08-03 | 521d |  | 774.4h | 72,049.62 |  |  |  |  |  |  |  |
| 884 | 1.4.6.1 | **0. Térreo** | 4d | 2023-07-31 | 2023-08-03 | 521d |  | 369.6h | 47,239.83 |  |  |  |  |  |  |  |
| 885 | 1.4.6.1.1 | 1.Inst. Embut. Em Fundações | 2d | 2023-07-31 | 2023-08-01 | 1205d | bombeiro; eletricista | 35.2h | 1,554.25 | 6. Casa 6 | 0. Térreo | 19 |  | 19. Instalações1 | Própria | 19 |
| 886 | 1.4.6.1.2 | 2.Inst. Elétricas Laje | 2d | 2023-07-31 | 2023-08-01 | 1205d | eletricista; aux. eletricista | 35.2h | 6,661.65 | 6. Casa 6 | 0. Térreo | 20 |  | 20. Elétrica1 | Própria | 20 |
| 887 | 1.4.6.1.3 | 3.Inst. Elétricas Paredes | 2d | 2023-07-31 | 2023-08-01 | 1205d | eletricista; aux. eletricista | 35.2h | 1,704.34 | 6. Casa 6 | 0. Térreo | 21 |  | 21. HS1 | Própria | 21 |
| 888 | 1.4.6.1.4 | 4.Inst. Gás | 2d | 2023-07-31 | 2023-08-01 | 1205d | aux. bombeiro; bombeiro | 35.2h | 2,592.32 | 6. Casa 6 | 0. Térreo | 22 |  | 21. HS1 | Própria | 22 |
| 889 | 1.4.6.1.5 | 5.Inst. AF e AQ | 2d | 2023-07-31 | 2023-08-01 | 1205d | aux. bombeiro; bombeiro | 35.2h | 4,586.31 | 6. Casa 6 | 0. Térreo | 23 |  | 21. HS1 | Própria | 23 |
| 890 | 1.4.6.1.6 | 6.Inst. Esgoto | 2d | 2023-07-31 | 2023-08-01 | 1205d | aux. bombeiro; bombeiro | 35.2h | 2,922.8 | 6. Casa 6 | 0. Térreo | 24 |  | 21. HS1 | Própria | 24 |
| 891 | 1.4.6.1.7 | 7.Fiação | 4d | 2023-07-31 | 2023-08-03 | 1203d | eletricista; aux. eletricista | 70.4h | 11,873.92 | 6. Casa 6 | 0. Térreo | 25 |  | 20. Elétrica1 | Própria | 25 |
| 892 | 1.4.6.1.8 | 8.Interr. Tom e luminárias | 1d | 2023-07-31 | 2023-07-31 | 1206d | eletricista; aux. eletricista | 17.6h | 6,963.62 | 6. Casa 6 | 0. Térreo | 26 |  | 20. Elétrica1 | Própria | 26 |
| 893 | 1.4.6.1.9 | 9.Quadro elétrico | 2d | 2023-07-31 | 2023-08-01 | 1205d | eletricista; aux. eletricista | 35.2h | 1,788.87 | 6. Casa 6 | 0. Térreo | 27 |  | 20. Elétrica1 | Própria | 27 |
| 894 | 1.4.6.1.10 | 10.Louças e Metais | 2d | 2023-07-31 | 2023-08-01 | 1205d | aux. bombeiro; bombeiro | 35.2h | 6,591.75 | 6. Casa 6 | 0. Térreo | 28 | 10 | 21. HS1 | Própria | 28 |
| 895 | 1.4.6.2 | **1. Pav. Superior** | 4d | 2023-07-31 | 2023-08-03 | 521d |  | 334.4h | 21,866.33 |  |  |  |  |  |  |  |
| 896 | 1.4.6.2.1 | 2.Inst. Elétricas Laje | 2d | 2023-07-31 | 2023-08-01 | 1205d | eletricista; aux. eletricista | 35.2h | 2,995.3 | 6. Casa 6 | 1. Pav. Superior | 20 |  | 20. Elétrica1 | Própria | 20 |
| 897 | 1.4.6.2.2 | 3.Inst. Elétricas Paredes | 2d | 2023-07-31 | 2023-08-01 | 1205d | eletricista; aux. eletricista | 35.2h | 766.33 | 6. Casa 6 | 1. Pav. Superior | 21 |  | 20. Elétrica1 | Própria | 21 |
| 898 | 1.4.6.2.3 | 4.Inst. Gás | 2d | 2023-07-31 | 2023-08-01 | 1205d | aux. bombeiro; bombeiro | 35.2h | 1,371.29 | 6. Casa 6 | 1. Pav. Superior | 22 |  | 21. HS1 | Própria | 22 |
| 899 | 1.4.6.2.4 | 5.Inst. AF e AQ | 2d | 2023-07-31 | 2023-08-01 | 1205d | aux. bombeiro; bombeiro | 35.2h | 2,426.07 | 6. Casa 6 | 1. Pav. Superior | 23 |  | 21. HS1 | Própria | 23 |
| 900 | 1.4.6.2.5 | 6.Inst. Esgoto | 2d | 2023-07-31 | 2023-08-01 | 1205d | aux. bombeiro; bombeiro | 35.2h | 1,546.11 | 6. Casa 6 | 1. Pav. Superior | 24 |  | 21. HS1 | Própria | 24 |
| 901 | 1.4.6.2.6 | 7.Fiação | 4d | 2023-07-31 | 2023-08-03 | 1203d | eletricista; aux. eletricista | 70.4h | 5,338.91 | 6. Casa 6 | 1. Pav. Superior | 25 |  | 20. Elétrica1 | Própria | 25 |
| 902 | 1.4.6.2.7 | 8.Interr. Tom e luminárias | 1d | 2023-07-31 | 2023-07-31 | 1206d | eletricista; aux. eletricista | 17.6h | 3,131.08 | 6. Casa 6 | 1. Pav. Superior | 26 |  | 20. Elétrica1 | Própria | 26 |
| 903 | 1.4.6.2.8 | 9.Quadro elétrico | 2d | 2023-07-31 | 2023-08-01 | 1205d | eletricista; aux. eletricista | 35.2h | 804.33 | 6. Casa 6 | 1. Pav. Superior | 27 |  | 20. Elétrica1 | Própria | 27 |
| 904 | 1.4.6.2.9 | 10.Louças e Metais | 2d | 2023-07-31 | 2023-08-01 | 1205d | aux. bombeiro; bombeiro | 35.2h | 3,486.91 | 6. Casa 6 | 1. Pav. Superior | 28 | 10 | 21. HS1 | Própria | 28 |

| ID | WBS | Task | Duration | Start | Finish | Total slack | Resources | Work | Cost | Casa | Pav | Pacote | Cor | Equipe | Empresa | LB |
| --- | --- | --- | --- | --- | --- | --- | --- | --- | --- | --- | --- | --- | --- | --- | --- | --- |
| 905 | 1.4.6.3 | **2. Coberta** | 2d | 2023-07-31 | 2023-08-01 | 523d |  | 70.4h | 2,943.46 |  |  |  |  |  |  |  |
| 906 | 1.4.6.3.1 | Barrilette | 2d | 2023-07-31 | 2023-08-01 | 1205d | aux. bombeiro; bombeiro | 35.2h | 1,177.38 | 6. Casa 6 | 2. Coberta | 29 | 11 | 21. HS1 | Própria | 29 |
| 907 | 1.4.6.3.2 | Caixa D'água | 2d | 2023-07-31 | 2023-08-01 | 1205d | aux. bombeiro; bombeiro | 35.2h | 1,766.08 | 6. Casa 6 | 2. Coberta | 30 | 11 | 21. HS1 | Própria | 30 |
| 908 | 1.4.7 | **7. Casa 7** | 4d | 2023-07-31 | 2023-08-03 | 521d |  | 774.4h | 72,049.62 |  |  |  |  |  |  |  |
| 909 | 1.4.7.1 | **0. Térreo** | 4d | 2023-07-31 | 2023-08-03 | 521d |  | 369.6h | 47,239.83 |  |  |  |  |  |  |  |
| 910 | 1.4.7.1.1 | 1.Inst. Embut. Em Fundações | 2d | 2023-07-31 | 2023-08-01 | 1205d | bombeiro; eletricista | 35.2h | 1,554.25 | 7. Casa 7 | 0. Térreo | 19 |  | 19. Instalações1 | Própria | 19 |
| 911 | 1.4.7.1.2 | 2.Inst. Elétricas Laje | 2d | 2023-07-31 | 2023-08-01 | 1205d | eletricista; aux. eletricista | 35.2h | 6,661.65 | 7. Casa 7 | 0. Térreo | 20 |  | 20. Elétrica1 | Própria | 20 |
| 912 | 1.4.7.1.3 | 3.Inst. Elétricas Paredes | 2d | 2023-07-31 | 2023-08-01 | 1205d | eletricista; aux. eletricista | 35.2h | 1,704.34 | 7. Casa 7 | 0. Térreo | 21 |  | 21. HS1 | Própria | 21 |
| 913 | 1.4.7.1.4 | 4.Inst. Gás | 2d | 2023-07-31 | 2023-08-01 | 1205d | aux. bombeiro; bombeiro | 35.2h | 2,592.32 | 7. Casa 7 | 0. Térreo | 22 |  | 21. HS1 | Própria | 22 |
| 914 | 1.4.7.1.5 | 5.Inst. AF e AQ | 2d | 2023-07-31 | 2023-08-01 | 1205d | aux. bombeiro; bombeiro | 35.2h | 4,586.31 | 7. Casa 7 | 0. Térreo | 23 |  | 21. HS1 | Própria | 23 |
| 915 | 1.4.7.1.6 | 6.Inst. Esgoto | 2d | 2023-07-31 | 2023-08-01 | 1205d | aux. bombeiro; bombeiro | 35.2h | 2,922.8 | 7. Casa 7 | 0. Térreo | 24 |  | 21. HS1 | Própria | 24 |
| 916 | 1.4.7.1.7 | 7.Fiação | 4d | 2023-07-31 | 2023-08-03 | 1203d | eletricista; aux. eletricista | 70.4h | 11,873.92 | 7. Casa 7 | 0. Térreo | 25 |  | 20. Elétrica1 | Própria | 25 |
| 917 | 1.4.7.1.8 | 8.Interr. Tom e luminárias | 1d | 2023-07-31 | 2023-07-31 | 1206d | eletricista; aux. eletricista | 17.6h | 6,963.62 | 7. Casa 7 | 0. Térreo | 26 |  | 20. Elétrica1 | Própria | 26 |
| 918 | 1.4.7.1.9 | 9.Quadro elétrico | 2d | 2023-07-31 | 2023-08-01 | 1205d | eletricista; aux. eletricista | 35.2h | 1,788.87 | 7. Casa 7 | 0. Térreo | 27 |  | 20. Elétrica1 | Própria | 27 |
| 919 | 1.4.7.1.10 | 10.Louças e Metais | 2d | 2023-07-31 | 2023-08-01 | 1205d | aux. bombeiro; bombeiro | 35.2h | 6,591.75 | 7. Casa 7 | 0. Térreo | 28 | 10 | 21. HS1 | Própria | 28 |
| 920 | 1.4.7.2 | **1. Pav. Superior** | 4d | 2023-07-31 | 2023-08-03 | 521d |  | 334.4h | 21,866.33 |  |  |  |  |  |  |  |
| 921 | 1.4.7.2.1 | 2.Inst. Elétricas Laje | 2d | 2023-07-31 | 2023-08-01 | 1205d | eletricista; aux. eletricista | 35.2h | 2,995.3 | 7. Casa 7 | 1. Pav. Superior | 20 |  | 20. Elétrica1 | Própria | 20 |
| 922 | 1.4.7.2.2 | 3.Inst. Elétricas Paredes | 2d | 2023-07-31 | 2023-08-01 | 1205d | eletricista; aux. eletricista | 35.2h | 766.33 | 7. Casa 7 | 1. Pav. Superior | 21 |  | 20. Elétrica1 | Própria | 21 |
| 923 | 1.4.7.2.3 | 4.Inst. Gás | 2d | 2023-07-31 | 2023-08-01 | 1205d | aux. bombeiro; bombeiro | 35.2h | 1,371.29 | 7. Casa 7 | 1. Pav. Superior | 22 |  | 21. HS1 | Própria | 22 |
| 924 | 1.4.7.2.4 | 5.Inst. AF e AQ | 2d | 2023-07-31 | 2023-08-01 | 1205d | aux. bombeiro; bombeiro | 35.2h | 2,426.07 | 7. Casa 7 | 1. Pav. Superior | 23 |  | 21. HS1 | Própria | 23 |
| 925 | 1.4.7.2.5 | 6.Inst. Esgoto | 2d | 2023-07-31 | 2023-08-01 | 1205d | aux. bombeiro; bombeiro | 35.2h | 1,546.11 | 7. Casa 7 | 1. Pav. Superior | 24 |  | 21. HS1 | Própria | 24 |
| 926 | 1.4.7.2.6 | 7.Fiação | 4d | 2023-07-31 | 2023-08-03 | 1203d | eletricista; aux. eletricista | 70.4h | 5,338.91 | 7. Casa 7 | 1. Pav. Superior | 25 |  | 20. Elétrica1 | Própria | 25 |
| 927 | 1.4.7.2.7 | 8.Interr. Tom e luminárias | 1d | 2023-07-31 | 2023-07-31 | 1206d | eletricista; aux. eletricista | 17.6h | 3,131.08 | 7. Casa 7 | 1. Pav. Superior | 26 |  | 20. Elétrica1 | Própria | 26 |
| 928 | 1.4.7.2.8 | 9.Quadro elétrico | 2d | 2023-07-31 | 2023-08-01 | 1205d | eletricista; aux. eletricista | 35.2h | 804.33 | 7. Casa 7 | 1. Pav. Superior | 27 |  | 20. Elétrica1 | Própria | 27 |
| 929 | 1.4.7.2.9 | 10.Louças e Metais | 2d | 2023-07-31 | 2023-08-01 | 1205d | aux. bombeiro; bombeiro | 35.2h | 3,486.91 | 7. Casa 7 | 1. Pav. Superior | 28 | 10 | 21. HS1 | Própria | 28 |

| ID | WBS | Task | Duration | Start | Finish | Total slack | Resources | Work | Cost | Casa | Pav | Pacote | Cor | Equipe | Empresa | LB |
| --- | --- | --- | --- | --- | --- | --- | --- | --- | --- | --- | --- | --- | --- | --- | --- | --- |
| 930 | 1.4.7.3 | **2. Coberta** | 2d | 2023-07-31 | 2023-08-01 | 523d |  | 70.4h | 2,943.46 |  |  |  |  |  |  |  |
| 931 | 1.4.7.3.1 | Barrilette | 2d | 2023-07-31 | 2023-08-01 | 1205d | aux. bombeiro; bombeiro | 35.2h | 1,177.38 | 7. Casa 7 | 2. Coberta | 29 | 11 | 21. HS1 | Própria | 29 |
| 932 | 1.4.7.3.2 | Caixa D'água | 2d | 2023-07-31 | 2023-08-01 | 1205d | aux. bombeiro; bombeiro | 35.2h | 1,766.08 | 7. Casa 7 | 2. Coberta | 30 | 11 | 21. HS1 | Própria | 30 |
| 933 | 1.4.8 | **8. Casa 8** | 4d | 2023-07-31 | 2023-08-03 | 521d |  | 774.4h | 72,049.62 |  |  |  |  |  |  |  |
| 934 | 1.4.8.1 | **0. Térreo** | 4d | 2023-07-31 | 2023-08-03 | 521d |  | 369.6h | 47,239.83 |  |  |  |  |  |  |  |
| 935 | 1.4.8.1.1 | 1.Inst. Embut. Em Fundações | 2d | 2023-07-31 | 2023-08-01 | 1205d | bombeiro; eletricista | 35.2h | 1,554.25 | 8. Casa 8 | 0. Térreo | 19 |  | 19. Instalações1 | Própria | 19 |
| 936 | 1.4.8.1.2 | 2.Inst. Elétricas Laje | 2d | 2023-07-31 | 2023-08-01 | 1205d | eletricista; aux. eletricista | 35.2h | 6,661.65 | 8. Casa 8 | 0. Térreo | 20 |  | 20. Elétrica1 | Própria | 20 |
| 937 | 1.4.8.1.3 | 3.Inst. Elétricas Paredes | 2d | 2023-07-31 | 2023-08-01 | 1205d | eletricista; aux. eletricista | 35.2h | 1,704.34 | 8. Casa 8 | 0. Térreo | 21 |  | 21. HS1 | Própria | 21 |
| 938 | 1.4.8.1.4 | 4.Inst. Gás | 2d | 2023-07-31 | 2023-08-01 | 1205d | aux. bombeiro; bombeiro | 35.2h | 2,592.32 | 8. Casa 8 | 0. Térreo | 22 |  | 21. HS1 | Própria | 22 |
| 939 | 1.4.8.1.5 | 5.Inst. AF e AQ | 2d | 2023-07-31 | 2023-08-01 | 1205d | aux. bombeiro; bombeiro | 35.2h | 4,586.31 | 8. Casa 8 | 0. Térreo | 23 |  | 21. HS1 | Própria | 23 |
| 940 | 1.4.8.1.6 | 6.Inst. Esgoto | 2d | 2023-07-31 | 2023-08-01 | 1205d | aux. bombeiro; bombeiro | 35.2h | 2,922.8 | 8. Casa 8 | 0. Térreo | 24 |  | 21. HS1 | Própria | 24 |
| 941 | 1.4.8.1.7 | 7.Fiação | 4d | 2023-07-31 | 2023-08-03 | 1203d | eletricista; aux. eletricista | 70.4h | 11,873.92 | 8. Casa 8 | 0. Térreo | 25 |  | 20. Elétrica1 | Própria | 25 |
| 942 | 1.4.8.1.8 | 8.Interr. Tom e luminárias | 1d | 2023-07-31 | 2023-07-31 | 1206d | eletricista; aux. eletricista | 17.6h | 6,963.62 | 8. Casa 8 | 0. Térreo | 26 |  | 20. Elétrica1 | Própria | 26 |
| 943 | 1.4.8.1.9 | 9.Quadro elétrico | 2d | 2023-07-31 | 2023-08-01 | 1205d | eletricista; aux. eletricista | 35.2h | 1,788.87 | 8. Casa 8 | 0. Térreo | 27 |  | 20. Elétrica1 | Própria | 27 |
| 944 | 1.4.8.1.10 | 10.Louças e Metais | 2d | 2023-07-31 | 2023-08-01 | 1205d | aux. bombeiro; bombeiro | 35.2h | 6,591.75 | 8. Casa 8 | 0. Térreo | 28 | 10 | 21. HS1 | Própria | 28 |
| 945 | 1.4.8.2 | **1. Pav. Superior** | 4d | 2023-07-31 | 2023-08-03 | 521d |  | 334.4h | 21,866.33 |  |  |  |  |  |  |  |
| 946 | 1.4.8.2.1 | 2.Inst. Elétricas Laje | 2d | 2023-07-31 | 2023-08-01 | 1205d | eletricista; aux. eletricista | 35.2h | 2,995.3 | 8. Casa 8 | 1. Pav. Superior | 20 |  | 20. Elétrica1 | Própria | 20 |
| 947 | 1.4.8.2.2 | 3.Inst. Elétricas Paredes | 2d | 2023-07-31 | 2023-08-01 | 1205d | eletricista; aux. eletricista | 35.2h | 766.33 | 8. Casa 8 | 1. Pav. Superior | 21 |  | 20. Elétrica1 | Própria | 21 |
| 948 | 1.4.8.2.3 | 4.Inst. Gás | 2d | 2023-07-31 | 2023-08-01 | 1205d | aux. bombeiro; bombeiro | 35.2h | 1,371.29 | 8. Casa 8 | 1. Pav. Superior | 22 |  | 21. HS1 | Própria | 22 |
| 949 | 1.4.8.2.4 | 5.Inst. AF e AQ | 2d | 2023-07-31 | 2023-08-01 | 1205d | aux. bombeiro; bombeiro | 35.2h | 2,426.07 | 8. Casa 8 | 1. Pav. Superior | 23 |  | 21. HS1 | Própria | 23 |
| 950 | 1.4.8.2.5 | 6.Inst. Esgoto | 2d | 2023-07-31 | 2023-08-01 | 1205d | aux. bombeiro; bombeiro | 35.2h | 1,546.11 | 8. Casa 8 | 1. Pav. Superior | 24 |  | 21. HS1 | Própria | 24 |
| 951 | 1.4.8.2.6 | 7.Fiação | 4d | 2023-07-31 | 2023-08-03 | 1203d | eletricista; aux. eletricista | 70.4h | 5,338.91 | 8. Casa 8 | 1. Pav. Superior | 25 |  | 20. Elétrica1 | Própria | 25 |
| 952 | 1.4.8.2.7 | 8.Interr. Tom e luminárias | 1d | 2023-07-31 | 2023-07-31 | 1206d | eletricista; aux. eletricista | 17.6h | 3,131.08 | 8. Casa 8 | 1. Pav. Superior | 26 |  | 20. Elétrica1 | Própria | 26 |
| 953 | 1.4.8.2.8 | 9.Quadro elétrico | 2d | 2023-07-31 | 2023-08-01 | 1205d | eletricista; aux. eletricista | 35.2h | 804.33 | 8. Casa 8 | 1. Pav. Superior | 27 |  | 20. Elétrica1 | Própria | 27 |
| 954 | 1.4.8.2.9 | 10.Louças e Metais | 2d | 2023-07-31 | 2023-08-01 | 1205d | aux. bombeiro; bombeiro | 35.2h | 3,486.91 | 8. Casa 8 | 1. Pav. Superior | 28 | 10 | 21. HS1 | Própria | 28 |

| ID | WBS | Task | Duration | Start | Finish | Total slack | Resources | Work | Cost | Casa | Pav | Pacote | Cor | Equipe | Empresa | LB |
| --- | --- | --- | --- | --- | --- | --- | --- | --- | --- | --- | --- | --- | --- | --- | --- | --- |
| 955 | 1.4.8.3 | **2. Coberta** | 2d | 2023-07-31 | 2023-08-01 | 523d |  | 70.4h | 2,943.46 |  |  |  |  |  |  |  |
| 956 | 1.4.8.3.1 | Barrilette | 2d | 2023-07-31 | 2023-08-01 | 1205d | aux. bombeiro; bombeiro | 35.2h | 1,177.38 | 8. Casa 8 | 2. Coberta | 29 | 11 | 21. HS1 | Própria | 29 |
| 957 | 1.4.8.3.2 | Caixa D'água | 2d | 2023-07-31 | 2023-08-01 | 1205d | aux. bombeiro; bombeiro | 35.2h | 1,766.08 | 8. Casa 8 | 2. Coberta | 30 | 11 | 21. HS1 | Própria | 30 |
| 958 | 1.4.9 | **9. Casa 9** | 4d | 2023-07-31 | 2023-08-03 | 521d |  | 774.4h | 72,049.62 |  |  |  |  |  |  |  |
| 959 | 1.4.9.1 | **0. Térreo** | 4d | 2023-07-31 | 2023-08-03 | 521d |  | 369.6h | 47,239.83 |  |  |  |  |  |  |  |
| 960 | 1.4.9.1.1 | 1.Inst. Embut. Em Fundações | 2d | 2023-07-31 | 2023-08-01 | 1205d | bombeiro; eletricista | 35.2h | 1,554.25 | 9. Casa 9 | 0. Térreo | 19 |  | 19. Instalações1 | Própria | 19 |
| 961 | 1.4.9.1.2 | 2.Inst. Elétricas Laje | 2d | 2023-07-31 | 2023-08-01 | 1205d | eletricista; aux. eletricista | 35.2h | 6,661.65 | 9. Casa 9 | 0. Térreo | 20 |  | 20. Elétrica1 | Própria | 20 |
| 962 | 1.4.9.1.3 | 3.Inst. Elétricas Paredes | 2d | 2023-07-31 | 2023-08-01 | 1205d | eletricista; aux. eletricista | 35.2h | 1,704.34 | 9. Casa 9 | 0. Térreo | 21 |  | 21. HS1 | Própria | 21 |
| 963 | 1.4.9.1.4 | 4.Inst. Gás | 2d | 2023-07-31 | 2023-08-01 | 1205d | aux. bombeiro; bombeiro | 35.2h | 2,592.32 | 9. Casa 9 | 0. Térreo | 22 |  | 21. HS1 | Própria | 22 |
| 964 | 1.4.9.1.5 | 5.Inst. AF e AQ | 2d | 2023-07-31 | 2023-08-01 | 1205d | aux. bombeiro; bombeiro | 35.2h | 4,586.31 | 9. Casa 9 | 0. Térreo | 23 |  | 21. HS1 | Própria | 23 |
| 965 | 1.4.9.1.6 | 6.Inst. Esgoto | 2d | 2023-07-31 | 2023-08-01 | 1205d | aux. bombeiro; bombeiro | 35.2h | 2,922.8 | 9. Casa 9 | 0. Térreo | 24 |  | 21. HS1 | Própria | 24 |
| 966 | 1.4.9.1.7 | 7.Fiação | 4d | 2023-07-31 | 2023-08-03 | 1203d | eletricista; aux. eletricista | 70.4h | 11,873.92 | 9. Casa 9 | 0. Térreo | 25 |  | 20. Elétrica1 | Própria | 25 |
| 967 | 1.4.9.1.8 | 8.Interr. Tom e luminárias | 1d | 2023-07-31 | 2023-07-31 | 1206d | eletricista; aux. eletricista | 17.6h | 6,963.62 | 9. Casa 9 | 0. Térreo | 26 |  | 20. Elétrica1 | Própria | 26 |
| 968 | 1.4.9.1.9 | 9.Quadro elétrico | 2d | 2023-07-31 | 2023-08-01 | 1205d | eletricista; aux. eletricista | 35.2h | 1,788.87 | 9. Casa 9 | 0. Térreo | 27 |  | 20. Elétrica1 | Própria | 27 |
| 969 | 1.4.9.1.10 | 10.Louças e Metais | 2d | 2023-07-31 | 2023-08-01 | 1205d | aux. bombeiro; bombeiro | 35.2h | 6,591.75 | 9. Casa 9 | 0. Térreo | 28 | 10 | 21. HS1 | Própria | 28 |
| 970 | 1.4.9.2 | **1. Pav. Superior** | 4d | 2023-07-31 | 2023-08-03 | 521d |  | 334.4h | 21,866.33 |  |  |  |  |  |  |  |
| 971 | 1.4.9.2.1 | 2.Inst. Elétricas Laje | 2d | 2023-07-31 | 2023-08-01 | 1205d | eletricista; aux. eletricista | 35.2h | 2,995.3 | 9. Casa 9 | 1. Pav. Superior | 20 |  | 20. Elétrica1 | Própria | 20 |
| 972 | 1.4.9.2.2 | 3.Inst. Elétricas Paredes | 2d | 2023-07-31 | 2023-08-01 | 1205d | eletricista; aux. eletricista | 35.2h | 766.33 | 9. Casa 9 | 1. Pav. Superior | 21 |  | 20. Elétrica1 | Própria | 21 |
| 973 | 1.4.9.2.3 | 4.Inst. Gás | 2d | 2023-07-31 | 2023-08-01 | 1205d | aux. bombeiro; bombeiro | 35.2h | 1,371.29 | 9. Casa 9 | 1. Pav. Superior | 22 |  | 21. HS1 | Própria | 22 |
| 974 | 1.4.9.2.4 | 5.Inst. AF e AQ | 2d | 2023-07-31 | 2023-08-01 | 1205d | aux. bombeiro; bombeiro | 35.2h | 2,426.07 | 9. Casa 9 | 1. Pav. Superior | 23 |  | 21. HS1 | Própria | 23 |
| 975 | 1.4.9.2.5 | 6.Inst. Esgoto | 2d | 2023-07-31 | 2023-08-01 | 1205d | aux. bombeiro; bombeiro | 35.2h | 1,546.11 | 9. Casa 9 | 1. Pav. Superior | 24 |  | 21. HS1 | Própria | 24 |
| 976 | 1.4.9.2.6 | 7.Fiação | 4d | 2023-07-31 | 2023-08-03 | 1203d | eletricista; aux. eletricista | 70.4h | 5,338.91 | 9. Casa 9 | 1. Pav. Superior | 25 |  | 20. Elétrica1 | Própria | 25 |
| 977 | 1.4.9.2.7 | 8.Interr. Tom e luminárias | 1d | 2023-07-31 | 2023-07-31 | 1206d | eletricista; aux. eletricista | 17.6h | 3,131.08 | 9. Casa 9 | 1. Pav. Superior | 26 |  | 20. Elétrica1 | Própria | 26 |
| 978 | 1.4.9.2.8 | 9.Quadro elétrico | 2d | 2023-07-31 | 2023-08-01 | 1205d | eletricista; aux. eletricista | 35.2h | 804.33 | 9. Casa 9 | 1. Pav. Superior | 27 |  | 20. Elétrica1 | Própria | 27 |
| 979 | 1.4.9.2.9 | 10.Louças e Metais | 2d | 2023-07-31 | 2023-08-01 | 1205d | aux. bombeiro; bombeiro | 35.2h | 3,486.91 | 9. Casa 9 | 1. Pav. Superior | 28 | 10 | 21. HS1 | Própria | 28 |

| ID | WBS | Task | Duration | Start | Finish | Total slack | Resources | Work | Cost | Casa | Pav | Pacote | Cor | Equipe | Empresa | LB |
| --- | --- | --- | --- | --- | --- | --- | --- | --- | --- | --- | --- | --- | --- | --- | --- | --- |
| 980 | 1.4.9.3 | **2. Coberta** | 2d | 2023-07-31 | 2023-08-01 | 523d |  | 70.4h | 2,943.46 |  |  |  |  |  |  |  |
| 981 | 1.4.9.3.1 | Barrilette | 2d | 2023-07-31 | 2023-08-01 | 1205d | aux. bombeiro; bombeiro | 35.2h | 1,177.38 | 9. Casa 9 | 2. Coberta | 29 | 11 | 21. HS1 | Própria | 29 |
| 982 | 1.4.9.3.2 | Caixa D'água | 2d | 2023-07-31 | 2023-08-01 | 1205d | aux. bombeiro; bombeiro | 35.2h | 1,766.08 | 9. Casa 9 | 2. Coberta | 30 | 11 | 21. HS1 | Própria | 30 |
| 983 | 1.4.10 | **10. Casa 10** | 4d | 2023-07-31 | 2023-08-03 | 521d |  | 774.4h | 72,049.62 |  |  |  |  |  |  |  |
| 984 | 1.4.10.1 | **0. Térreo** | 4d | 2023-07-31 | 2023-08-03 | 521d |  | 369.6h | 47,239.83 |  |  |  |  |  |  |  |
| 985 | 1.4.10.1.1 | 1.Inst. Embut. Em Fundações | 2d | 2023-07-31 | 2023-08-01 | 1205d | bombeiro; eletricista | 35.2h | 1,554.25 | 10. Casa 10 | 0. Térreo | 19 |  | 19. Instalações1 | Própria | 19 |
| 986 | 1.4.10.1.2 | 2.Inst. Elétricas Laje | 2d | 2023-07-31 | 2023-08-01 | 1205d | eletricista; aux. eletricista | 35.2h | 6,661.65 | 10. Casa 10 | 0. Térreo | 20 |  | 20. Elétrica1 | Própria | 20 |
| 987 | 1.4.10.1.3 | 3.Inst. Elétricas Paredes | 2d | 2023-07-31 | 2023-08-01 | 1205d | eletricista; aux. eletricista | 35.2h | 1,704.34 | 10. Casa 10 | 0. Térreo | 21 |  | 21. HS1 | Própria | 21 |
| 988 | 1.4.10.1.4 | 4.Inst. Gás | 2d | 2023-07-31 | 2023-08-01 | 1205d | aux. bombeiro; bombeiro | 35.2h | 2,592.32 | 10. Casa 10 | 0. Térreo | 22 |  | 21. HS1 | Própria | 22 |
| 989 | 1.4.10.1.5 | 5.Inst. AF e AQ | 2d | 2023-07-31 | 2023-08-01 | 1205d | aux. bombeiro; bombeiro | 35.2h | 4,586.31 | 10. Casa 10 | 0. Térreo | 23 |  | 21. HS1 | Própria | 23 |
| 990 | 1.4.10.1.6 | 6.Inst. Esgoto | 2d | 2023-07-31 | 2023-08-01 | 1205d | aux. bombeiro; bombeiro | 35.2h | 2,922.8 | 1 0. Casa 10 | 0. Térreo | 24 |  | 21. HS1 | Própria | 24 |
| 991 | 1.4.10.1.7 | 7.Fiação | 4d | 2023-07-31 | 2023-08-03 | 1203d | eletricista; aux. eletricista | 70.4h | 11,873.92 | 10. Casa 10 | 0. Térreo | 25 |  | 20. Elétrica1 | Própria | 25 |
| 992 | 1.4.10.1.8 | 8.Interr. Tom e luminárias | 1d | 2023-07-31 | 2023-07-31 | 1206d | eletricista; aux. eletricista | 17.6h | 6,963.62 | 10. Casa 10 | 0. Térreo | 26 |  | 20. Elétrica1 | Própria | 26 |
| 993 | 1.4.10.1.9 | 9.Quadro elétrico | 2d | 2023-07-31 | 2023-08-01 | 1205d | eletricista; aux. eletricista | 35.2h | 1,788.87 | 10. Casa 10 | 0. Térreo | 27 |  | 20. Elétrica1 | Própria | 27 |
| 994 | 1.4.10.1.10 | 10.Louças e Metais | 2d | 2023-07-31 | 2023-08-01 | 1205d | aux. bombeiro; bombeiro | 35.2h | 6,591.75 | 10. Casa 10 | 0. Térreo | 28 | 10 | 21. HS1 | Própria | 28 |
| 995 | 1.4.10.2 | **1. Pav. Superior** | 4d | 2023-07-31 | 2023-08-03 | 521d |  | 334.4h | 21,866.33 |  |  |  |  |  |  |  |
| 996 | 1.4.10.2.1 | 2.Inst. Elétricas Laje | 2d | 2023-07-31 | 2023-08-01 | 1205d | eletricista; aux. eletricista | 35.2h | 2,995.3 | 10. Casa 10 | 1. Pav. Superior | 20 |  | 20. Elétrica1 | Própria | 20 |
| 997 | 1.4.10.2.2 | 3.Inst. Elétricas Paredes | 2d | 2023-07-31 | 2023-08-01 | 1205d | eletricista; aux. eletricista | 35.2h | 766.33 | 10. Casa 10 | 1. Pav. Superior | 21 |  | 20. Elétrica1 | Própria | 21 |
| 998 | 1.4.10.2.3 | 4.Inst. Gás | 2d | 2023-07-31 | 2023-08-01 | 1205d | aux. bombeiro; bombeiro | 35.2h | 1,371.29 | 10. Casa 10 | 1. Pav. Superior | 22 |  | 21. HS1 | Própria | 22 |
| 999 | 1.4.10.2.4 | 5.Inst. AF e AQ | 2d | 2023-07-31 | 2023-08-01 | 1205d | aux. bombeiro; bombeiro | 35.2h | 2,426.07 | 10. Casa 10 | 1. Pav. Superior | 23 |  | 21. HS1 | Própria | 23 |
| 1000 | 1.4.10.2.5 | 6.Inst. Esgoto | 2d | 2023-07-31 | 2023-08-01 | 1205d | aux. bombeiro; bombeiro | 35.2h | 1,546.11 | 10. Casa 10 | 1. Pav. Superior | 24 |  | 21. HS1 | Própria | 24 |
| 1001 | 1.4.10.2.6 | 7.Fiação | 4d | 2023-07-31 | 2023-08-03 | 1203d | eletricista; aux. eletricista | 70.4h | 5,338.91 | 10. Casa 10 | 1. Pav. Superior | 25 |  | 20. Elétrica1 | Própria | 25 |
| 1002 | 1.4.10.2.7 | 8.Interr. Tom e luminárias | 1d | 2023-07-31 | 2023-07-31 | 1206d | eletricista; aux. eletricista | 17.6h | 3,131.08 | 10. Casa 10 | 1. Pav. Superior | 26 |  | 20. Elétrica1 | Própria | 26 |
| 1003 | 1.4.10.2.8 | 9.Quadro elétrico | 2d | 2023-07-31 | 2023-08-01 | 1205d | eletricista; aux. eletricista | 35.2h | 804.33 | 10. Casa 10 | 1. Pav. Superior | 27 |  | 20. Elétrica1 | Própria | 27 |
| 1004 | 1.4.10.2.9 | 10.Louças e Metais | 2d | 2023-07-31 | 2023-08-01 | 1205d | aux. bombeiro; bombeiro | 35.2h | 3,486.91 | 10. Casa 10 | 1. Pav. Superior | 28 | 10 | 21. HS1 | Própria | 28 |

| ID | WBS | Task | Duration | Start | Finish | Total slack | Resources | Work | Cost | Casa | Pav | Pacote | Cor | Equipe | Empresa | LB |
| --- | --- | --- | --- | --- | --- | --- | --- | --- | --- | --- | --- | --- | --- | --- | --- | --- |
| 1005 | 1.4.10.3 | **2. Coberta** | 2d | 2023-07-31 | 2023-08-01 | 523d |  | 70.4h | 2,943.46 |  |  |  |  |  |  |  |
| 1006 | 1.4.10.3.1 | Barrilette | 2d | 2023-07-31 | 2023-08-01 | 1205d | aux. bombeiro; bombeiro | 35.2h | 1,177.38 | 10. Casa 10 | 2. Coberta | 29 | 11 | 21. HS1 | Própria | 29 |
| 1007 | 1.4.10.3.2 | Caixa D'água | 2d | 2023-07-31 | 2023-08-01 | 1205d | aux. bombeiro; bombeiro | 35.2h | 1,766.08 | 10. Casa 10 | 2. Coberta | 30 | 11 | 21. HS1 | Própria | 30 |
| 1008 | 1.4.11 | **11. Casa 11** | 4d | 2023-07-31 | 2023-08-03 | 521d |  | 774.4h | 72,049.62 |  |  |  |  |  |  |  |
| 1009 | 1.4.11.1 | **0. Térreo** | 4d | 2023-07-31 | 2023-08-03 | 521d |  | 369.6h | 47,239.83 |  |  |  |  |  |  |  |
| 1010 | 1.4.11.1.1 | 1.Inst. Embut. Em Fundações | 2d | 2023-07-31 | 2023-08-01 | 1205d | bombeiro; eletricista | 35.2h | 1,554.25 | 11. Casa 11 | 0. Térreo | 19 |  | 19. Instalações1 | Própria | 19 |
| 1011 | 1.4.11.1.2 | 2.Inst. Elétricas Laje | 2d | 2023-07-31 | 2023-08-01 | 1205d | eletricista; aux. eletricista | 35.2h | 6,661.65 | 11. Casa 11 | 0. Térreo | 20 |  | 20. Elétrica1 | Própria | 20 |
| 1012 | 1.4.11.1.3 | 3.Inst. Elétricas Paredes | 2d | 2023-07-31 | 2023-08-01 | 1205d | eletricista; aux. eletricista | 35.2h | 1,704.34 | 11. Casa 11 | 0. Térreo | 21 |  | 21. HS1 | Própria | 21 |
| 1013 | 1.4.11.1.4 | 4.Inst. Gás | 2d | 2023-07-31 | 2023-08-01 | 1205d | aux. bombeiro; bombeiro | 35.2h | 2,592.32 | 11. Casa 11 | 0. Térreo | 22 |  | 21. HS1 | Própria | 22 |
| 1014 | 1.4.11.1.5 | 5.Inst. AF e AQ | 2d | 2023-07-31 | 2023-08-01 | 1205d | aux. bombeiro; bombeiro | 35.2h | 4,586.31 | 11. Casa 11 | 0. Térreo | 23 |  | 21. HS1 | Própria | 23 |
| 1015 | 1.4.11.1.6 | 6.Inst. Esgoto | 2d | 2023-07-31 | 2023-08-01 | 1205d | aux. bombeiro; bombeiro | 35.2h | 2,922.8 | 11. Casa 11 | 0. Térreo | 24 |  | 21. HS1 | Própria | 24 |
| 1016 | 1.4.11.1.7 | 7.Fiação | 4d | 2023-07-31 | 2023-08-03 | 1203d | eletricista; aux. eletricista | 70.4h | 11,873.92 | 11. Casa 11 | 0. Térreo | 25 |  | 20. Elétrica1 | Própria | 25 |
| 1017 | 1.4.11.1.8 | 8.Interr. Tom e luminárias | 1d | 2023-07-31 | 2023-07-31 | 1206d | eletricista; aux. eletricista | 17.6h | 6,963.62 | 11. Casa 11 | 0. Térreo | 26 |  | 20. Elétrica1 | Própria | 26 |
| 1018 | 1.4.11.1.9 | 9.Quadro elétrico | 2d | 2023-07-31 | 2023-08-01 | 1205d | eletricista; aux. eletricista | 35.2h | 1,788.87 | 11. Casa 11 | 0. Térreo | 27 |  | 20. Elétrica1 | Própria | 27 |
| 1019 | 1.4.11.1.10 | 10.Louças e Metais | 2d | 2023-07-31 | 2023-08-01 | 1205d | aux. bombeiro; bombeiro | 35.2h | 6,591.75 | 11. Casa 11 | 0. Térreo | 28 | 10 | 21. HS1 | Própria | 28 |
| 1020 | 1.4.11.2 | **1. Pav. Superior** | 4d | 2023-07-31 | 2023-08-03 | 521d |  | 334.4h | 21,866.33 |  |  |  |  |  |  |  |
| 1021 | 1.4.11.2.1 | 2.Inst. Elétricas Laje | 2d | 2023-07-31 | 2023-08-01 | 1205d | eletricista; aux. eletricista | 35.2h | 2,995.3 | 11. Casa 11 | 1. Pav. Superior | 20 |  | 20. Elétrica1 | Própria | 20 |
| 1022 | 1.4.11.2.2 | 3.Inst. Elétricas Paredes | 2d | 2023-07-31 | 2023-08-01 | 1205d | eletricista; aux. eletricista | 35.2h | 766.33 | 11. Casa 11 | 1. Pav. Superior | 21 |  | 20. Elétrica1 | Própria | 21 |
| 1023 | 1.4.11.2.3 | 4.Inst. Gás | 2d | 2023-07-31 | 2023-08-01 | 1205d | aux. bombeiro; bombeiro | 35.2h | 1,371.29 | 11. Casa 11 | 1. Pav. Superior | 22 |  | 21. HS1 | Própria | 22 |
| 1024 | 1.4.11.2.4 | 5.Inst. AF e AQ | 2d | 2023-07-31 | 2023-08-01 | 1205d | aux. bombeiro; bombeiro | 35.2h | 2,426.07 | 11. Casa 11 | 1. Pav. Superior | 23 |  | 21. HS1 | Própria | 23 |
| 1025 | 1.4.11.2.5 | 6.Inst. Esgoto | 2d | 2023-07-31 | 2023-08-01 | 1205d | aux. bombeiro; bombeiro | 35.2h | 1,546.11 | 11. Casa 11 | 1. Pav. Superior | 24 |  | 21. HS1 | Própria | 24 |
| 1026 | 1.4.11.2.6 | 7.Fiação | 4d | 2023-07-31 | 2023-08-03 | 1203d | eletricista; aux. eletricista | 70.4h | 5,338.91 | 11. Casa 11 | 1. Pav. Superior | 25 |  | 20. Elétrica1 | Própria | 25 |
| 1027 | 1.4.11.2.7 | 8.Interr. Tom e luminárias | 1d | 2023-07-31 | 2023-07-31 | 1206d | eletricista; aux. eletricista | 17.6h | 3,131.08 | 11. Casa 11 | 1. Pav. Superior | 26 |  | 20. Elétrica1 | Própria | 26 |
| 1028 | 1.4.11.2.8 | 9.Quadro elétrico | 2d | 2023-07-31 | 2023-08-01 | 1205d | eletricista; aux. eletricista | 35.2h | 804.33 | 11. Casa 11 | 1. Pav. Superior | 27 |  | 20. Elétrica1 | Própria | 27 |
| 1029 | 1.4.11.2.9 | 10.Louças e Metais | 2d | 2023-07-31 | 2023-08-01 | 1205d | aux. bombeiro; bombeiro | 35.2h | 3,486.91 | 11. Casa 11 | 1. Pav. Superior | 28 | 10 | 21. HS1 | Própria | 28 |

| ID | WBS | Task | Duration | Start | Finish | Total slack | Resources | Work | Cost | Casa | Pav | Pacote | Cor | Equipe | Empresa | LB |
| --- | --- | --- | --- | --- | --- | --- | --- | --- | --- | --- | --- | --- | --- | --- | --- | --- |
| 1030 | 1.4.11.3 | **2. Coberta** | 2d | 2023-07-31 | 2023-08-01 | 523d |  | 70.4h | 2,943.46 |  |  |  |  |  |  |  |
| 1031 | 1.4.11.3.1 | Barrilette | 2d | 2023-07-31 | 2023-08-01 | 1205d | aux. bombeiro; bombeiro | 35.2h | 1,177.38 | 11. Casa 11 | 2. Coberta | 29 | 11 | 21. HS1 | Própria | 29 |
| 1032 | 1.4.11.3.2 | Caixa D'água | 2d | 2023-07-31 | 2023-08-01 | 1205d | aux. bombeiro; bombeiro | 35.2h | 1,766.08 | 11. Casa 11 | 2. Coberta | 30 | 11 | 21. HS1 | Própria | 30 |
| 1033 | 1.4.12 | **12. Casa 12** | 4d | 2023-07-31 | 2023-08-03 | 521d |  | 774.4h | 72,049.62 |  |  |  |  |  |  |  |
| 1034 | 1.4.12.1 | **0. Térreo** | 4d | 2023-07-31 | 2023-08-03 | 521d |  | 369.6h | 47,239.83 |  |  |  |  |  |  |  |
| 1035 | 1.4.12.1.1 | 1.Inst. Embut. Em Fundações | 2d | 2023-07-31 | 2023-08-01 | 1205d | bombeiro; eletricista | 35.2h | 1,554.25 | 12. Casa 12 | 0. Térreo | 19 |  | 19. Instalações1 | Própria | 19 |
| 1036 | 1.4.12.1.2 | 2.Inst. Elétricas Laje | 2d | 2023-07-31 | 2023-08-01 | 1205d | eletricista; aux. eletricista | 35.2h | 6,661.65 | 12. Casa 12 | 0. Térreo | 20 |  | 20. Elétrica1 | Própria | 20 |
| 1037 | 1.4.12.1.3 | 3.Inst. Elétricas Paredes | 2d | 2023-07-31 | 2023-08-01 | 1205d | eletricista; aux. eletricista | 35.2h | 1,704.34 | 12. Casa 12 | 0. Térreo | 21 |  | 21. HS1 | Própria | 21 |
| 1038 | 1.4.12.1.4 | 4.Inst. Gás | 2d | 2023-07-31 | 2023-08-01 | 1205d | aux. bombeiro; bombeiro | 35.2h | 2,592.32 | 12. Casa 12 | 0. Térreo | 22 |  | 21. HS1 | Própria | 22 |
| 1039 | 1.4.12.1.5 | 5.Inst. AF e AQ | 2d | 2023-07-31 | 2023-08-01 | 1205d | aux. bombeiro; bombeiro | 35.2h | 4,586.31 | 12. Casa 12 | 0. Térreo | 23 |  | 21. HS1 | Própria | 23 |
| 1040 | 1.4.12.1.6 | 6.Inst. Esgoto | 2d | 2023-07-31 | 2023-08-01 | 1205d | aux. bombeiro; bombeiro | 35.2h | 2,922.8 | 12. Casa 12 | 0. Térreo | 24 |  | 21. HS1 | Própria | 24 |
| 1041 | 1.4.12.1.7 | 7.Fiação | 4d | 2023-07-31 | 2023-08-03 | 1203d | eletricista; aux. eletricista | 70.4h | 11,873.92 | 12. Casa 12 | 0. Térreo | 25 |  | 20. Elétrica1 | Própria | 25 |
| 1042 | 1.4.12.1.8 | 8.Interr. Tom e luminárias | 1d | 2023-07-31 | 2023-07-31 | 1206d | eletricista; aux. eletricista | 17.6h | 6,963.62 | 12. Casa 12 | 0. Térreo | 26 |  | 20. Elétrica1 | Própria | 26 |
| 1043 | 1.4.12.1.9 | 9.Quadro elétrico | 2d | 2023-07-31 | 2023-08-01 | 1205d | eletricista; aux. eletricista | 35.2h | 1,788.87 | 12. Casa 12 | 0. Térreo | 27 |  | 20. Elétrica1 | Própria | 27 |
| 1044 | 1.4.12.1.10 | 10.Louças e Metais | 2d | 2023-07-31 | 2023-08-01 | 1205d | aux. bombeiro; bombeiro | 35.2h | 6,591.75 | 12. Casa 12 | 0. Térreo | 28 | 10 | 21. HS1 | Própria | 28 |
| 1045 | 1.4.12.2 | **1. Pav. Superior** | 4d | 2023-07-31 | 2023-08-03 | 521d |  | 334.4h | 21,866.33 |  |  |  |  |  |  |  |
| 1046 | 1.4.12.2.1 | 2.Inst. Elétricas Laje | 2d | 2023-07-31 | 2023-08-01 | 1205d | eletricista; aux. eletricista | 35.2h | 2,995.3 | 12. Casa 12 | 1. Pav. Superior | 20 |  | 20. Elétrica1 | Própria | 20 |
| 1047 | 1.4.12.2.2 | 3.Inst. Elétricas Paredes | 2d | 2023-07-31 | 2023-08-01 | 1205d | eletricista; aux. eletricista | 35.2h | 766.33 | 12. Casa 12 | 1. Pav. Superior | 21 |  | 20. Elétrica1 | Própria | 21 |
| 1048 | 1.4.12.2.3 | 4.Inst. Gás | 2d | 2023-07-31 | 2023-08-01 | 1205d | aux. bombeiro; bombeiro | 35.2h | 1,371.29 | 12. Casa 12 | 1. Pav. Superior | 22 |  | 21. HS1 | Própria | 22 |
| 1049 | 1.4.12.2.4 | 5.Inst. AF e AQ | 2d | 2023-07-31 | 2023-08-01 | 1205d | aux. bombeiro; bombeiro | 35.2h | 2,426.07 | 12. Casa 12 | 1. Pav. Superior | 23 |  | 21. HS1 | Própria | 23 |
| 1050 | 1.4.12.2.5 | 6.Inst. Esgoto | 2d | 2023-07-31 | 2023-08-01 | 1205d | aux. bombeiro; bombeiro | 35.2h | 1,546.11 | 12. Casa 12 | 1. Pav. Superior | 24 |  | 21. HS1 | Própria | 24 |
| 1051 | 1.4.12.2.6 | 7.Fiação | 4d | 2023-07-31 | 2023-08-03 | 1203d | eletricista; aux. eletricista | 70.4h | 5,338.91 | 12. Casa 12 | 1. Pav. Superior | 25 |  | 20. Elétrica1 | Própria | 25 |
| 1052 | 1.4.12.2.7 | 8.Interr. Tom e luminárias | 1d | 2023-07-31 | 2023-07-31 | 1206d | eletricista; aux. eletricista | 17.6h | 3,131.08 | 12. Casa 12 | 1. Pav. Superior | 26 |  | 20. Elétrica1 | Própria | 26 |
| 1053 | 1.4.12.2.8 | 9.Quadro elétrico | 2d | 2023-07-31 | 2023-08-01 | 1205d | eletricista; aux. eletricista | 35.2h | 804.33 | 12. Casa 12 | 1. Pav. Superior | 27 |  | 20. Elétrica1 | Própria | 27 |
| 1054 | 1.4.12.2.9 | 10.Louças e Metais | 2d | 2023-07-31 | 2023-08-01 | 1205d | aux. bombeiro; bombeiro | 35.2h | 3,486.91 | 12. Casa 12 | 1. Pav. Superior | 28 | 10 | 21. HS1 | Própria | 28 |

| ID | WBS | Task | Duration | Start | Finish | Total slack | Resources | Work | Cost | Casa | Pav | Pacote | Cor | Equipe | Empresa | LB |
| --- | --- | --- | --- | --- | --- | --- | --- | --- | --- | --- | --- | --- | --- | --- | --- | --- |
| 1055 | 1.4.12.3 | **2. Coberta** | 2d | 2023-07-31 | 2023-08-01 | 523d |  | 70.4h | 2,943.46 |  |  |  |  |  |  |  |
| 1056 | 1.4.12.3.1 | Barrilette | 2d | 2023-07-31 | 2023-08-01 | 1205d | aux. bombeiro; bombeiro | 35.2h | 1,177.38 | 12. Casa 12 | 2. Coberta | 29 | 11 | 21. HS1 | Própria | 29 |
| 1057 | 1.4.12.3.2 | Caixa D'água | 2d | 2023-07-31 | 2023-08-01 | 1205d | aux. bombeiro; bombeiro | 35.2h | 1,766.08 | 12. Casa 12 | 2. Coberta | 30 | 11 | 21. HS1 | Própria | 30 |
| 1058 | 1.4.13 | **13. Casa 13** | 4d | 2023-07-31 | 2023-08-03 | 521d |  | 774.4h | 72,049.62 |  |  |  |  |  |  |  |
| 1059 | 1.4.13.1 | **0. Térreo** | 4d | 2023-07-31 | 2023-08-03 | 521d |  | 369.6h | 47,239.83 |  |  |  |  |  |  |  |
| 1060 | 1.4.13.1.1 | 1.Inst. Embut. Em Fundações | 2d | 2023-07-31 | 2023-08-01 | 1205d | bombeiro; eletricista | 35.2h | 1,554.25 | 13. Casa 13 | 0. Térreo | 19 |  | 19. Instalações1 | Própria | 19 |
| 1061 | 1.4.13.1.2 | 2.Inst. Elétricas Laje | 2d | 2023-07-31 | 2023-08-01 | 1205d | eletricista; aux. eletricista | 35.2h | 6,661.65 | 13. Casa 13 | 0. Térreo | 20 |  | 20. Elétrica1 | Própria | 20 |
| 1062 | 1.4.13.1.3 | 3.Inst. Elétricas Paredes | 2d | 2023-07-31 | 2023-08-01 | 1205d | eletricista; aux. eletricista | 35.2h | 1,704.34 | 13. Casa 13 | 0. Térreo | 21 |  | 21. HS1 | Própria | 21 |
| 1063 | 1.4.13.1.4 | 4.Inst. Gás | 2d | 2023-07-31 | 2023-08-01 | 1205d | aux. bombeiro; bombeiro | 35.2h | 2,592.32 | 13. Casa 13 | 0. Térreo | 22 |  | 21. HS1 | Própria | 22 |
| 1064 | 1.4.13.1.5 | 5.Inst. AF e AQ | 2d | 2023-07-31 | 2023-08-01 | 1205d | aux. bombeiro; bombeiro | 35.2h | 4,586.31 | 13. Casa 13 | 0. Térreo | 23 |  | 21. HS1 | Própria | 23 |
| 1065 | 1.4.13.1.6 | 6.Inst. Esgoto | 2d | 2023-07-31 | 2023-08-01 | 1205d | aux. bombeiro; bombeiro | 35.2h | 2,922.8 | 13. Casa 13 | 0. Térreo | 24 |  | 21. HS1 | Própria | 24 |
| 1066 | 1.4.13.1.7 | 7.Fiação | 4d | 2023-07-31 | 2023-08-03 | 1203d | eletricista; aux. eletricista | 70.4h | 11,873.92 | 13. Casa 13 | 0. Térreo | 25 |  | 20. Elétrica1 | Própria | 25 |
| 1067 | 1.4.13.1.8 | 8.Interr. Tom e luminárias | 1d | 2023-07-31 | 2023-07-31 | 1206d | eletricista; aux. eletricista | 17.6h | 6,963.62 | 13. Casa 13 | 0. Térreo | 26 |  | 20. Elétrica1 | Própria | 26 |
| 1068 | 1.4.13.1.9 | 9.Quadro elétrico | 2d | 2023-07-31 | 2023-08-01 | 1205d | eletricista; aux. eletricista | 35.2h | 1,788.87 | 13. Casa 13 | 0. Térreo | 27 |  | 20. Elétrica1 | Própria | 27 |
| 1069 | 1.4.13.1.10 | 10.Louças e Metais | 2d | 2023-07-31 | 2023-08-01 | 1205d | aux. bombeiro; bombeiro | 35.2h | 6,591.75 | 13. Casa 13 | 0. Térreo | 28 | 10 | 21. HS1 | Própria | 28 |
| 1070 | 1.4.13.2 | **1. Pav. Superior** | 4d | 2023-07-31 | 2023-08-03 | 521d |  | 334.4h | 21,866.33 |  |  |  |  |  |  |  |
| 1071 | 1.4.13.2.1 | 2.Inst. Elétricas Laje | 2d | 2023-07-31 | 2023-08-01 | 1205d | eletricista; aux. eletricista | 35.2h | 2,995.3 | 13. Casa 13 | 1. Pav. Superior | 20 |  | 20. Elétrica1 | Própria | 20 |
| 1072 | 1.4.13.2.2 | 3.Inst. Elétricas Paredes | 2d | 2023-07-31 | 2023-08-01 | 1205d | eletricista; aux. eletricista | 35.2h | 766.33 | 13. Casa 13 | 1. Pav. Superior | 21 |  | 20. Elétrica1 | Própria | 21 |
| 1073 | 1.4.13.2.3 | 4.Inst. Gás | 2d | 2023-07-31 | 2023-08-01 | 1205d | aux. bombeiro; bombeiro | 35.2h | 1,371.29 | 13. Casa 13 | 1. Pav. Superior | 22 |  | 21. HS1 | Própria | 22 |
| 1074 | 1.4.13.2.4 | 5.Inst. AF e AQ | 2d | 2023-07-31 | 2023-08-01 | 1205d | aux. bombeiro; bombeiro | 35.2h | 2,426.07 | 13. Casa 13 | 1. Pav. Superior | 23 |  | 21. HS1 | Própria | 23 |
| 1075 | 1.4.13.2.5 | 6.Inst. Esgoto | 2d | 2023-07-31 | 2023-08-01 | 1205d | aux. bombeiro; bombeiro | 35.2h | 1,546.11 | 13. Casa 13 | 1. Pav. Superior | 24 |  | 21. HS1 | Própria | 24 |
| 1076 | 1.4.13.2.6 | 7.Fiação | 4d | 2023-07-31 | 2023-08-03 | 1203d | eletricista; aux. eletricista | 70.4h | 5,338.91 | 13. Casa 13 | 1. Pav. Superior | 25 |  | 20. Elétrica1 | Própria | 25 |
| 1077 | 1.4.13.2.7 | 8.Interr. Tom e luminárias | 1d | 2023-07-31 | 2023-07-31 | 1206d | eletricista; aux. eletricista | 17.6h | 3,131.08 | 13. Casa 13 | 1. Pav. Superior | 26 |  | 20. Elétrica1 | Própria | 26 |
| 1078 | 1.4.13.2.8 | 9.Quadro elétrico | 2d | 2023-07-31 | 2023-08-01 | 1205d | eletricista; aux. eletricista | 35.2h | 804.33 | 13. Casa 13 | 1. Pav. Superior | 27 |  | 20. Elétrica1 | Própria | 27 |
| 1079 | 1.4.13.2.9 | 10.Louças e Metais | 2d | 2023-07-31 | 2023-08-01 | 1205d | aux. bombeiro; bombeiro | 35.2h | 3,486.91 | 13. Casa 13 | 1. Pav. Superior | 28 | 10 | 21. HS1 | Própria | 28 |

| ID | WBS | Task | Duration | Start | Finish | Total slack | Resources | Work | Cost | Casa | Pav | Pacote | Cor | Equipe | Empresa | LB |
| --- | --- | --- | --- | --- | --- | --- | --- | --- | --- | --- | --- | --- | --- | --- | --- | --- |
| 1080 | 1.4.13.3 | **2. Coberta** | 2d | 2023-07-31 | 2023-08-01 | 523d |  | 70.4h | 2,943.46 |  |  |  |  |  |  |  |
| 1081 | 1.4.13.3.1 | Barrilette | 2d | 2023-07-31 | 2023-08-01 | 1205d | aux. bombeiro; bombeiro | 35.2h | 1,177.38 | 13. Casa 13 | 2. Coberta | 29 | 11 | 21. HS1 | Própria | 29 |
| 1082 | 1.4.13.3.2 | Caixa D'água | 2d | 2023-07-31 | 2023-08-01 | 1205d | aux. bombeiro; bombeiro | 35.2h | 1,766.08 | 13. Casa 13 | 2. Coberta | 30 | 11 | 21. HS1 | Própria | 30 |
| 1083 | 1.4.14 | **14. Casa 14** | 4d | 2023-07-31 | 2023-08-03 | 521d |  | 774.4h | 72,049.62 |  |  |  |  |  |  |  |
| 1084 | 1.4.14.1 | **0. Térreo** | 4d | 2023-07-31 | 2023-08-03 | 521d |  | 369.6h | 47,239.83 |  |  |  |  |  |  |  |
| 1085 | 1.4.14.1.1 | 1.Inst. Embut. Em Fundações | 2d | 2023-07-31 | 2023-08-01 | 1205d | bombeiro; eletricista | 35.2h | 1,554.25 | 14. Casa 14 | 0. Térreo | 19 |  | 19. Instalações1 | Própria | 19 |
| 1086 | 1.4.14.1.2 | 2.Inst. Elétricas Laje | 2d | 2023-07-31 | 2023-08-01 | 1205d | eletricista; aux. eletricista | 35.2h | 6,661.65 | 14. Casa 14 | 0. Térreo | 20 |  | 20. Elétrica1 | Própria | 20 |
| 1087 | 1.4.14.1.3 | 3.Inst. Elétricas Paredes | 2d | 2023-07-31 | 2023-08-01 | 1205d | eletricista; aux. eletricista | 35.2h | 1,704.34 | 14. Casa 14 | 0. Térreo | 21 |  | 21. HS1 | Própria | 21 |
| 1088 | 1.4.14.1.4 | 4.Inst. Gás | 2d | 2023-07-31 | 2023-08-01 | 1205d | aux. bombeiro; bombeiro | 35.2h | 2,592.32 | 14. Casa 14 | 0. Térreo | 22 |  | 21. HS1 | Própria | 22 |
| 1089 | 1.4.14.1.5 | 5.Inst. AF e AQ | 2d | 2023-07-31 | 2023-08-01 | 1205d | aux. bombeiro; bombeiro | 35.2h | 4,586.31 | 14. Casa 14 | 0. Térreo | 23 |  | 21. HS1 | Própria | 23 |
| 1090 | 1.4.14.1.6 | 6.Inst. Esgoto | 2d | 2023-07-31 | 2023-08-01 | 1205d | aux. bombeiro; bombeiro | 35.2h | 2,922.8 | 14. Casa 14 | 0. Térreo | 24 |  | 21. HS1 | Própria | 24 |
| 1091 | 1.4.14.1.7 | 7.Fiação | 4d | 2023-07-31 | 2023-08-03 | 1203d | eletricista; aux. eletricista | 70.4h | 11,873.92 | 14. Casa 14 | 0. Térreo | 25 |  | 20. Elétrica1 | Própria | 25 |
| 1092 | 1.4.14.1.8 | 8.Interr. Tom e luminárias | 1d | 2023-07-31 | 2023-07-31 | 1206d | eletricista; aux. eletricista | 17.6h | 6,963.62 | 14. Casa 14 | 0. Térreo | 26 |  | 20. Elétrica1 | Própria | 26 |
| 1093 | 1.4.14.1.9 | 9.Quadro elétrico | 2d | 2023-07-31 | 2023-08-01 | 1205d | eletricista; aux. eletricista | 35.2h | 1,788.87 | 14. Casa 14 | 0. Térreo | 27 |  | 20. Elétrica1 | Própria | 27 |
| 1094 | 1.4.14.1.10 | 10.Louças e Metais | 2d | 2023-07-31 | 2023-08-01 | 1205d | aux. bombeiro; bombeiro | 35.2h | 6,591.75 | 14. Casa 14 | 0. Térreo | 28 | 10 | 21. HS1 | Própria | 28 |
| 1095 | 1.4.14.2 | **1. Pav. Superior** | 4d | 2023-07-31 | 2023-08-03 | 521d |  | 334.4h | 21,866.33 |  |  |  |  |  |  |  |
| 1096 | 1.4.14.2.1 | 2.Inst. Elétricas Laje | 2d | 2023-07-31 | 2023-08-01 | 1205d | eletricista; aux. eletricista | 35.2h | 2,995.3 | 14. Casa 14 | 1. Pav. Superior | 20 |  | 20. Elétrica1 | Própria | 20 |
| 1097 | 1.4.14.2.2 | 3.Inst. Elétricas Paredes | 2d | 2023-07-31 | 2023-08-01 | 1205d | eletricista; aux. eletricista | 35.2h | 766.33 | 14. Casa 14 | 1. Pav. Superior | 21 |  | 20. Elétrica1 | Própria | 21 |
| 1098 | 1.4.14.2.3 | 4.Inst. Gás | 2d | 2023-07-31 | 2023-08-01 | 1205d | aux. bombeiro; bombeiro | 35.2h | 1,371.29 | 14. Casa 14 | 1. Pav. Superior | 22 |  | 21. HS1 | Própria | 22 |
| 1099 | 1.4.14.2.4 | 5.Inst. AF e AQ | 2d | 2023-07-31 | 2023-08-01 | 1205d | aux. bombeiro; bombeiro | 35.2h | 2,426.07 | 14. Casa 14 | 1. Pav. Superior | 23 |  | 21. HS1 | Própria | 23 |
| 1100 | 1.4.14.2.5 | 6.Inst. Esgoto | 2d | 2023-07-31 | 2023-08-01 | 1205d | aux. bombeiro; bombeiro | 35.2h | 1,546.11 | 14. Casa 14 | 1. Pav. Superior | 24 |  | 21. HS1 | Própria | 24 |
| 1101 | 1.4.14.2.6 | 7.Fiação | 4d | 2023-07-31 | 2023-08-03 | 1203d | eletricista; aux. eletricista | 70.4h | 5,338.91 | 14. Casa 14 | 1. Pav. Superior | 25 |  | 20. Elétrica1 | Própria | 25 |
| 1102 | 1.4.14.2.7 | 8.Interr. Tom e luminárias | 1d | 2023-07-31 | 2023-07-31 | 1206d | eletricista; aux. eletricista | 17.6h | 3,131.08 | 14. Casa 14 | 1. Pav. Superior | 26 |  | 20. Elétrica1 | Própria | 26 |
| 1103 | 1.4.14.2.8 | 9.Quadro elétrico | 2d | 2023-07-31 | 2023-08-01 | 1205d | eletricista; aux. eletricista | 35.2h | 804.33 | 14. Casa 14 | 1. Pav. Superior | 27 |  | 20. Elétrica1 | Própria | 27 |
| 1104 | 1.4.14.2.9 | 10.Louças e Metais | 2d | 2023-07-31 | 2023-08-01 | 1205d | aux. bombeiro; bombeiro | 35.2h | 3,486.91 | 14. Casa 14 | 1. Pav. Superior | 28 | 10 | 21. HS1 | Própria | 28 |

| ID | WBS | Task | Duration | Start | Finish | Total slack | Resources | Work | Cost | Casa | Pav | Pacote | Cor | Equipe | Empresa | LB |
| --- | --- | --- | --- | --- | --- | --- | --- | --- | --- | --- | --- | --- | --- | --- | --- | --- |
| 1105 | 1.4.14.3 | **2. Coberta** | 2d | 2023-07-31 | 2023-08-01 | 523d |  | 70.4h | 2,943.46 |  |  |  |  |  |  |  |
| 1106 | 1.4.14.3.1 | Barrilette | 2d | 2023-07-31 | 2023-08-01 | 1205d | aux. bombeiro; bombeiro | 35.2h | 1,177.38 | 14. Casa 14 | 2. Coberta | 29 | 11 | 21. HS1 | Própria | 29 |
| 1107 | 1.4.14.3.2 | Caixa D'água | 2d | 2023-07-31 | 2023-08-01 | 1205d | aux. bombeiro; bombeiro | 35.2h | 1,766.08 | 14. Casa 14 | 2. Coberta | 30 | 11 | 21. HS1 | Própria | 30 |
| 1108 | 1.4.15 | **15. Casa 15** | 4d | 2023-07-31 | 2023-08-03 | 521d |  | 774.4h | 72,049.62 |  |  |  |  |  |  |  |
| 1109 | 1.4.15.1 | **0. Térreo** | 4d | 2023-07-31 | 2023-08-03 | 521d |  | 369.6h | 47,239.83 |  |  |  |  |  |  |  |
| 1110 | 1.4.15.1.1 | 1.Inst. Embut. Em Fundações | 2d | 2023-07-31 | 2023-08-01 | 1205d | bombeiro; eletricista | 35.2h | 1,554.25 | 15. Casa 15 | 0. Térreo | 19 |  | 19. Instalações1 | Própria | 19 |
| 1111 | 1.4.15.1.2 | 2.Inst. Elétricas Laje | 2d | 2023-07-31 | 2023-08-01 | 1205d | eletricista; aux. eletricista | 35.2h | 6,661.65 | 15. Casa 15 | 0. Térreo | 20 |  | 20. Elétrica1 | Própria | 20 |
| 1112 | 1.4.15.1.3 | 3.Inst. Elétricas Paredes | 2d | 2023-07-31 | 2023-08-01 | 1205d | eletricista; aux. eletricista | 35.2h | 1,704.34 | 15. Casa 15 | 0. Térreo | 21 |  | 21. HS1 | Própria | 21 |
| 1113 | 1.4.15.1.4 | 4.Inst. Gás | 2d | 2023-07-31 | 2023-08-01 | 1205d | aux. bombeiro; bombeiro | 35.2h | 2,592.32 | 15. Casa 15 | 0. Térreo | 22 |  | 21. HS1 | Própria | 22 |
| 1114 | 1.4.15.1.5 | 5.Inst. AF e AQ | 2d | 2023-07-31 | 2023-08-01 | 1205d | aux. bombeiro; bombeiro | 35.2h | 4,586.31 | 15. Casa 15 | 0. Térreo | 23 |  | 21. HS1 | Própria | 23 |
| 1115 | 1.4.15.1.6 | 6.Inst. Esgoto | 2d | 2023-07-31 | 2023-08-01 | 1205d | aux. bombeiro; bombeiro | 35.2h | 2,922.8 | 15. Casa 15 | 0. Térreo | 24 |  | 21. HS1 | Própria | 24 |
| 1116 | 1.4.15.1.7 | 7.Fiação | 4d | 2023-07-31 | 2023-08-03 | 1203d | eletricista; aux. eletricista | 70.4h | 11,873.92 | 15. Casa 15 | 0. Térreo | 25 |  | 20. Elétrica1 | Própria | 25 |
| 1117 | 1.4.15.1.8 | 8.Interr. Tom e luminárias | 1d | 2023-07-31 | 2023-07-31 | 1206d | eletricista; aux. eletricista | 17.6h | 6,963.62 | 15. Casa 15 | 0. Térreo | 26 |  | 20. Elétrica1 | Própria | 26 |
| 1118 | 1.4.15.1.9 | 9.Quadro elétrico | 2d | 2023-07-31 | 2023-08-01 | 1205d | eletricista; aux. eletricista | 35.2h | 1,788.87 | 15. Casa 15 | 0. Térreo | 27 |  | 20. Elétrica1 | Própria | 27 |
| 1119 | 1.4.15.1.10 | 10.Louças e Metais | 2d | 2023-07-31 | 2023-08-01 | 1205d | aux. bombeiro; bombeiro | 35.2h | 6,591.75 | 15. Casa 15 | 0. Térreo | 28 | 10 | 21. HS1 | Própria | 28 |
| 1120 | 1.4.15.2 | **1. Pav. Superior** | 4d | 2023-07-31 | 2023-08-03 | 521d |  | 334.4h | 21,866.33 |  |  |  |  |  |  |  |
| 1121 | 1.4.15.2.1 | 2.Inst. Elétricas Laje | 2d | 2023-07-31 | 2023-08-01 | 1205d | eletricista; aux. eletricista | 35.2h | 2,995.3 | 15. Casa 15 | 1. Pav. Superior | 20 |  | 20. Elétrica1 | Própria | 20 |
| 1122 | 1.4.15.2.2 | 3.Inst. Elétricas Paredes | 2d | 2023-07-31 | 2023-08-01 | 1205d | eletricista; aux. eletricista | 35.2h | 766.33 | 15. Casa 15 | 1. Pav. Superior | 21 |  | 20. Elétrica1 | Própria | 21 |
| 1123 | 1.4.15.2.3 | 4.Inst. Gás | 2d | 2023-07-31 | 2023-08-01 | 1205d | aux. bombeiro; bombeiro | 35.2h | 1,371.29 | 15. Casa 15 | 1. Pav. Superior | 22 |  | 21. HS1 | Própria | 22 |
| 1124 | 1.4.15.2.4 | 5.Inst. AF e AQ | 2d | 2023-07-31 | 2023-08-01 | 1205d | aux. bombeiro; bombeiro | 35.2h | 2,426.07 | 15. Casa 15 | 1. Pav. Superior | 23 |  | 21. HS1 | Própria | 23 |
| 1125 | 1.4.15.2.5 | 6.Inst. Esgoto | 2d | 2023-07-31 | 2023-08-01 | 1205d | aux. bombeiro; bombeiro | 35.2h | 1,546.11 | 15. Casa 15 | 1. Pav. Superior | 24 |  | 21. HS1 | Própria | 24 |
| 1126 | 1.4.15.2.6 | 7.Fiação | 4d | 2023-07-31 | 2023-08-03 | 1203d | eletricista; aux. eletricista | 70.4h | 5,338.91 | 15. Casa 15 | 1. Pav. Superior | 25 |  | 20. Elétrica1 | Própria | 25 |
| 1127 | 1.4.15.2.7 | 8.Interr. Tom e luminárias | 1d | 2023-07-31 | 2023-07-31 | 1206d | eletricista; aux. eletricista | 17.6h | 3,131.08 | 15. Casa 15 | 1. Pav. Superior | 26 |  | 20. Elétrica1 | Própria | 26 |
| 1128 | 1.4.15.2.8 | 9.Quadro elétrico | 2d | 2023-07-31 | 2023-08-01 | 1205d | eletricista; aux. eletricista | 35.2h | 804.33 | 15. Casa 15 | 1. Pav. Superior | 27 |  | 20. Elétrica1 | Própria | 27 |
| 1129 | 1.4.15.2.9 | 10.Louças e Metais | 2d | 2023-07-31 | 2023-08-01 | 1205d | aux. bombeiro; bombeiro | 35.2h | 3,486.91 | 15. Casa 15 | 1. Pav. Superior | 28 | 10 | 21. HS1 | Própria | 28 |

| ID | WBS | Task | Duration | Start | Finish | Total slack | Resources | Work | Cost | Casa | Pav | Pacote | Cor | Equipe | Empresa | LB |
| --- | --- | --- | --- | --- | --- | --- | --- | --- | --- | --- | --- | --- | --- | --- | --- | --- |
| 1130 | 1.4.15.3 | **2. Coberta** | 2d | 2023-07-31 | 2023-08-01 | 523d |  | 70.4h | 2,943.46 |  |  |  |  |  |  |  |
| 1131 | 1.4.15.3.1 | Barrilette | 2d | 2023-07-31 | 2023-08-01 | 1205d | aux. bombeiro; bombeiro | 35.2h | 1,177.38 | 15. Casa 15 | 2. Coberta | 29 | 11 | 21. HS1 | Própria | 29 |
| 1132 | 1.4.15.3.2 | Caixa D'água | 2d | 2023-07-31 | 2023-08-01 | 1205d | aux. bombeiro; bombeiro | 35.2h | 1,766.08 | 15. Casa 15 | 2. Coberta | 30 | 11 | 21. HS1 | Própria | 30 |
| 1133 | 1.4.16 | **16. Casa 16** | 4d | 2023-07-31 | 2023-08-03 | 521d |  | 774.4h | 72,049.62 |  |  |  |  |  |  |  |
| 1134 | 1.4.16.1 | **0. Térreo** | 4d | 2023-07-31 | 2023-08-03 | 521d |  | 369.6h | 47,239.83 |  |  |  |  |  |  |  |
| 1135 | 1.4.16.1.1 | 1.Inst. Embut. Em Fundações | 2d | 2023-07-31 | 2023-08-01 | 1205d | bombeiro; eletricista | 35.2h | 1,554.25 | 16. Casa 16 | 0. Térreo | 19 |  | 19. Instalações1 | Própria | 19 |
| 1136 | 1.4.16.1.2 | 2.Inst. Elétricas Laje | 2d | 2023-07-31 | 2023-08-01 | 1205d | eletricista; aux. eletricista | 35.2h | 6,661.65 | 16. Casa 16 | 0. Térreo | 20 |  | 20. Elétrica1 | Própria | 20 |
| 1137 | 1.4.16.1.3 | 3.Inst. Elétricas Paredes | 2d | 2023-07-31 | 2023-08-01 | 1205d | eletricista; aux. eletricista | 35.2h | 1,704.34 | 16. Casa 16 | 0. Térreo | 21 |  | 21. HS1 | Própria | 21 |
| 1138 | 1.4.16.1.4 | 4.Inst. Gás | 2d | 2023-07-31 | 2023-08-01 | 1205d | aux. bombeiro; bombeiro | 35.2h | 2,592.32 | 16. Casa 16 | 0. Térreo | 22 |  | 21. HS1 | Própria | 22 |
| 1139 | 1.4.16.1.5 | 5.Inst. AF e AQ | 2d | 2023-07-31 | 2023-08-01 | 1205d | aux. bombeiro; bombeiro | 35.2h | 4,586.31 | 16. Casa 16 | 0. Térreo | 23 |  | 21. HS1 | Própria | 23 |
| 1140 | 1.4.16.1.6 | 6.Inst. Esgoto | 2d | 2023-07-31 | 2023-08-01 | 1205d | aux. bombeiro; bombeiro | 35.2h | 2,922.8 | 16. Casa 16 | 0. Térreo | 24 |  | 21. HS1 | Própria | 24 |
| 1141 | 1.4.16.1.7 | 7.Fiação | 4d | 2023-07-31 | 2023-08-03 | 1203d | eletricista; aux. eletricista | 70.4h | 11,873.92 | 16. Casa 16 | 0. Térreo | 25 |  | 20. Elétrica1 | Própria | 25 |
| 1142 | 1.4.16.1.8 | 8.Interr. Tom e luminárias | 1d | 2023-07-31 | 2023-07-31 | 1206d | eletricista; aux. eletricista | 17.6h | 6,963.62 | 16. Casa 16 | 0. Térreo | 26 |  | 20. Elétrica1 | Própria | 26 |
| 1143 | 1.4.16.1.9 | 9.Quadro elétrico | 2d | 2023-07-31 | 2023-08-01 | 1205d | eletricista; aux. eletricista | 35.2h | 1,788.87 | 16. Casa 16 | 0. Térreo | 27 |  | 20. Elétrica1 | Própria | 27 |
| 1144 | 1.4.16.1.10 | 10.Louças e Metais | 2d | 2023-07-31 | 2023-08-01 | 1205d | aux. bombeiro; bombeiro | 35.2h | 6,591.75 | 16. Casa 16 | 0. Térreo | 28 | 10 | 21. HS1 | Própria | 28 |
| 1145 | 1.4.16.2 | **1. Pav. Superior** | 4d | 2023-07-31 | 2023-08-03 | 521d |  | 334.4h | 21,866.33 |  |  |  |  |  |  |  |
| 1146 | 1.4.16.2.1 | 2.Inst. Elétricas Laje | 2d | 2023-07-31 | 2023-08-01 | 1205d | eletricista; aux. eletricista | 35.2h | 2,995.3 | 16. Casa 16 | 1. Pav. Superior | 20 |  | 20. Elétrica1 | Própria | 20 |
| 1147 | 1.4.16.2.2 | 3.Inst. Elétricas Paredes | 2d | 2023-07-31 | 2023-08-01 | 1205d | eletricista; aux. eletricista | 35.2h | 766.33 | 16. Casa 16 | 1. Pav. Superior | 21 |  | 20. Elétrica1 | Própria | 21 |
| 1148 | 1.4.16.2.3 | 4.Inst. Gás | 2d | 2023-07-31 | 2023-08-01 | 1205d | aux. bombeiro; bombeiro | 35.2h | 1,371.29 | 16. Casa 16 | 1. Pav. Superior | 22 |  | 21. HS1 | Própria | 22 |
| 1149 | 1.4.16.2.4 | 5.Inst. AF e AQ | 2d | 2023-07-31 | 2023-08-01 | 1205d | aux. bombeiro; bombeiro | 35.2h | 2,426.07 | 16. Casa 16 | 1. Pav. Superior | 23 |  | 21. HS1 | Própria | 23 |
| 1150 | 1.4.16.2.5 | 6.Inst. Esgoto | 2d | 2023-07-31 | 2023-08-01 | 1205d | aux. bombeiro; bombeiro | 35.2h | 1,546.11 | 16. Casa 16 | 1. Pav. Superior | 24 |  | 21. HS1 | Própria | 24 |
| 1151 | 1.4.16.2.6 | 7.Fiação | 4d | 2023-07-31 | 2023-08-03 | 1203d | eletricista; aux. eletricista | 70.4h | 5,338.91 | 16. Casa 16 | 1. Pav. Superior | 25 |  | 20. Elétrica1 | Própria | 25 |
| 1152 | 1.4.16.2.7 | 8.Interr. Tom e luminárias | 1d | 2023-07-31 | 2023-07-31 | 1206d | eletricista; aux. eletricista | 17.6h | 3,131.08 | 16. Casa 16 | 1. Pav. Superior | 26 |  | 20. Elétrica1 | Própria | 26 |
| 1153 | 1.4.16.2.8 | 9.Quadro elétrico | 2d | 2023-07-31 | 2023-08-01 | 1205d | eletricista; aux. eletricista | 35.2h | 804.33 | 16. Casa 16 | 1. Pav. Superior | 27 |  | 20. Elétrica1 | Própria | 27 |
| 1154 | 1.4.16.2.9 | 10.Louças e Metais | 2d | 2023-07-31 | 2023-08-01 | 1205d | aux. bombeiro; bombeiro | 35.2h | 3,486.91 | 16. Casa 16 | 1. Pav. Superior | 28 | 10 | 21. HS1 | Própria | 28 |

| ID | WBS | Task | Duration | Start | Finish | Total slack | Resources | Work | Cost | Casa | Pav | Pacote | Cor | Equipe | Empresa | LB |
| --- | --- | --- | --- | --- | --- | --- | --- | --- | --- | --- | --- | --- | --- | --- | --- | --- |
| 1155 | 1.4.16.3 | **2. Coberta** | 2d | 2023-07-31 | 2023-08-01 | 523d |  | 70.4h | 2,943.46 |  |  |  |  |  |  |  |
| 1156 | 1.4.16.3.1 | Barrilette | 2d | 2023-07-31 | 2023-08-01 | 1205d | aux. bombeiro; bombeiro | 35.2h | 1,177.38 | 16. Casa 16 | 2. Coberta | 29 | 11 | 21. HS1 | Própria | 29 |
| 1157 | 1.4.16.3.2 | Caixa D'água | 2d | 2023-07-31 | 2023-08-01 | 1205d | aux. bombeiro; bombeiro | 35.2h | 1,766.08 | 16. Casa 16 | 2. Coberta | 30 | 11 | 21. HS1 | Própria | 30 |
